# NGAO SD schedule v9

How a schedule from MS Project changed from version to version. A marks actual dates.

## Version 1 (saved 2006-09-23, file NGAO_SD_schedule_v9.mpp)

| ID | WBS | Task | Duration | Start | Finish | Predecessors | Total float | Constraint |
| --- | --- | --- | --- | --- | --- | --- | --- | --- |
| 1 | 1 | **SD Phase Management** | 468d? | 2006-06-21 | 2008-04-04 |  | 0d |  |
| 2 | 1.1 | **Planning and Contracting** | 193d? | 2006-06-21 | 2007-03-16 |  | 275d |  |
| 3 |  | NGAO Proposal to SSC | 0d | 2006-06-21 | 2006-06-21 |  | 447d | start no earlier than 2006-06-21 |
| 4 |  | Management Structure Decision by Directors | 0d | 2006-07-14 | 2006-07-14 | 3 | 430d | start no earlier than 2006-07-14 |
| 5 |  | SD Phase System Engineering Management Plan | 21d? | 2006-09-01 | 2006-09-29 | 4 | 395d | finish no earlier than 2006-09-29 |
| 6 |  | SD Phase Contracts Generated | 23d? | 2006-09-27 | 2006-10-27 |  | 375d | start no earlier than 2006-09-27 |
| 7 |  | Director Approval | 0d | 2006-10-09 | 2006-10-09 |  | 390d | start no earlier than 2006-10-09 |
| 8 |  | SD Partner Contracts Issued | 0d | 2006-10-27 | 2006-10-27 | 6, 7 | 375d | start no earlier than 2006-10-13 |
| 9 |  | Mid-year Replan | 10d | 2007-03-05 | 2007-03-16 |  | 275d | start no earlier than 2007-03-05 |
| 10 |  | FY08 Replan | 8d | 2006-09-05 | 2006-09-15 |  | 405.2d | start no earlier than 2006-09-05 |
| 11 | 1.2 | **Project Meetings** | 407d? | 2006-09-14 | 2008-04-04 |  | 0d |  |
| 12 |  | Executive Committee Telecons | 109.5d? | 2007-10-29 | 2008-03-28 |  | 5d | finish no earlier than 2008-03-28 |
| 13 |  | Science Advisory Committee Telecons | 390d? | 2006-10-02 | 2008-03-28 |  | 5d | start no earlier than 2006-10-02 |
| 14 | 1.2.3 | **Team Meetings** | 407d | 2006-09-14 | 2008-04-04 |  | 0d |  |
| 15 |  | Team Meeting (mgmt, science & technical - Irvine) | 1d | 2006-09-14 | 2006-09-14 |  | 406d | start no earlier than 2006-09-14 |
| 16 |  | Team Meeting (CIT) | 1d | 2006-11-07 | 2006-11-07 |  | 368d | start no earlier than 2006-11-07 |
| 17 |  | Team Videocon | 0.5d | 2006-12-13 | 2006-12-13 |  | 342.5d | start no earlier than 2006-12-13 |
| 18 |  | Team Meeting (Keck) | 1d | 2007-01-22 | 2007-01-22 |  | 314d | start no earlier than 2007-01-22 |
| 19 |  | Team Videocon | 0.5d | 2007-03-07 | 2007-03-07 |  | 282.5d | start no earlier than 2007-03-07 |
| 20 |  | Team Meeting | 1d | 2007-04-18 | 2007-04-18 |  | 252d | start no earlier than 2007-04-18 |
| 21 |  | Team Videocon | 0.5d | 2007-05-30 | 2007-05-30 |  | 222d | finish no earlier than 2007-05-30 |
| 22 |  | Team Retreat (UCSC) | 5d | 2007-07-09 | 2007-07-13 |  | 190d | start no earlier than 2007-07-09 |
| 23 |  | Team Videocon | 0.5d | 2007-08-22 | 2007-08-22 |  | 162.5d | start no earlier than 2007-08-22 |
| 24 |  | Team Meeting (CIT) | 1d | 2007-09-13 | 2007-09-13 |  | 146d | start no earlier than 2007-09-13 |
| 25 |  | Team Videocon | 0.5d | 2007-11-05 | 2007-11-05 |  | 109.5d | start no earlier than 2007-11-05 |
| 26 |  | Team Meeting (Keck) | 3d | 2007-12-12 | 2007-12-14 |  | 80d | start no earlier than 2007-12-12 |
| 27 |  | Team Videocon | 0.5d | 2008-01-09 | 2008-01-09 |  | 62.5d | start no earlier than 2008-01-09 |
| 28 |  | Team Meeting (CA) | 1d | 2008-04-04 | 2008-04-04 | 39 | 0d | start no earlier than 2008-04-04 |
| 29 | 1.3 | **Tracking and Reporting** | 394d? | 2006-09-29 | 2008-04-03 |  | 1d |  |
| 30 |  | Report Preparation/Presentation | 162.5d? | 2006-10-02 | 2007-05-16 |  | 232.5d | start no earlier than 2006-10-02 |
| 31 |  | Keck Science Meeting 06 (UCI) | 0d | 2006-09-29 | 2006-09-29 | 5 | 395d | finish no earlier than 2006-09-16 |
| 32 |  | SSC meeting (UCLA) | 0d | 2006-11-06 | 2006-11-06 |  | 370d | start no earlier than 2006-11-06 |
| 33 |  | SSC meeting (Keck) | 0d | 2007-01-24 | 2007-01-24 |  | 313d | start no earlier than 2007-01-24 |
| 34 |  | SSC meeting (CA) | 0d | 2007-04-03 | 2007-04-03 |  | 264d | start no earlier than 2007-04-03 |
| 35 |  | SSC meeting (Keck) | 0d | 2007-06-20 | 2007-06-20 |  | 208d | start no earlier than 2007-06-20 |
| 36 |  | Keck Science Meeting 07 | 0d | 2007-09-22 | 2007-09-22 |  | 140d | finish no earlier than 2007-09-22 |
| 37 |  | SSC meeting (CA) | 0d | 2007-11-06 | 2007-11-06 |  | 109d | start no earlier than 2007-11-06 |
| 38 |  | SSC meeting (Keck) | 0d | 2008-01-24 | 2008-01-24 |  | 52d | start no earlier than 2008-01-24 |
| 39 |  | SSC meeting (CA) | 0d | 2008-04-03 | 2008-04-03 |  | 0d | finish no earlier than 2008-04-03 |
| 40 | 1.4 | **Proposal & Fundraising Activities** | 326d? | 2006-10-02 | 2007-12-31 |  | 69d |  |
| 41 |  | Dates & deliverables identified by Directors | 0d | 2006-10-02 | 2006-10-02 |  | 134d | start no earlier than 2006-10-02 |
| 42 |  | Activities | 261d? | 2007-01-01 | 2007-12-31 | 41 | 69d | start no earlier than 2007-01-01 |
| 43 | 1.5 | **System Design Report & Review** | 294d? | 2007-01-16 | 2008-02-29 |  | 25d |  |
| 44 |  | System Design Report | 8d? | 2008-01-02 | 2008-01-11 |  | 60d | start no earlier than 2008-01-02 |
| 45 | 1.5.2 | **System Design Review Activities** | 294d? | 2007-01-16 | 2008-02-29 |  | 25d |  |
| 46 |  | Reviewers Identified | 22d? | 2007-11-15 | 2007-12-14 |  | 80d | start no earlier than 2007-11-15 |
| 47 |  | Review Package Distributed | 0d | 2008-02-19 | 2008-02-19 | 299, 278, 132 | 25d | start no earlier than 2008-01-14 |
| 48 |  | Reviewer Comments Received & Addressed | 5d? | 2008-02-20 | 2008-02-26 | 47 | 25d | finish no earlier than 2008-02-01 |
| 49 |  | System Design Review Prep & Attendance | 16d? | 2007-01-16 | 2007-02-06 |  | 300d | start no earlier than 2007-01-16 |
| 50 |  | System Design Review Meeting | 0d | 2008-02-26 | 2008-02-26 | 49, 48 | 25d | start no earlier than 2008-02-06 |
| 51 |  | Reviewer Report Received | 0d | 2008-02-26 | 2008-02-26 | 50 | 25d | start no earlier than 2008-02-15 |
| 52 |  | Response to Reviewer Report & Distribution | 3d? | 2008-02-27 | 2008-02-29 | 51 | 25d | start no earlier than 2008-02-18 |
| 53 | 2 | **System Requirements** | 355d? | 2006-09-05 | 2008-01-15 |  | 59d |  |
| 54 | 2.1 | **Science Requirements** | 344d? | 2006-09-05 | 2007-12-28 |  | 70d |  |
| 55 | 2.1.1 | **Solar System** | 135d? | 2006-10-02 | 2007-04-06 |  | 260d |  |
| 56 | 2.1.1.1 | **Companions & Multiplicity of Small Solar System Bodies** | 75d? | 2006-10-02 | 2007-01-12 |  | 320d |  |
| 57 |  | Point Source Companion Sensitivity Requirements | 45d? | 2006-10-02 | 2006-12-01 |  | 350d | finish no earlier than 2006-12-01 |
| 58 |  | Spectral Sensitivity & Spectral Resolution Requirements | 45d? | 2006-10-02 | 2006-12-01 |  | 350d | finish no earlier than 2006-12-01 |
| 59 |  | Observing Scenarios | 30d? | 2006-12-04 | 2007-01-12 |  | 320d | finish no earlier than 2007-01-12 |
| 60 |  | Science Instrument Requirements | 30d? | 2006-12-04 | 2007-01-12 |  | 320d | start no earlier than 2006-12-04 |
| 61 | 2.1.1.2 | **Moons of the Giant Planets** | 70d? | 2006-12-04 | 2007-03-09 |  | 280d |  |
| 62 |  | Performance Requirements | 40d? | 2006-12-04 | 2007-01-26 |  | 310d | start no earlier than 2006-12-04 |
| 63 |  | Observing Scenarios | 30d? | 2007-01-29 | 2007-03-09 |  | 280d | finish no earlier than 2007-03-09 |
| 64 |  | Science Instrument Requirements | 30d? | 2007-01-29 | 2007-03-09 |  | 280d | start no earlier than 2007-01-29 |
| 65 | 2.1.1.3 | **Shape & Size of Asteroids** | 50d? | 2007-01-29 | 2007-04-06 |  | 260d |  |
| 66 |  | Spatial Resolution Requirements | 25d? | 2007-01-29 | 2007-03-02 |  | 285d | start no earlier than 2007-01-29 |
| 67 |  | Spectral Sensitivity & Spectral Resolution Requirements | 25d? | 2007-01-29 | 2007-03-02 |  | 285d | start no earlier than 2007-01-29 |
| 68 |  | Observing Scenarios | 25d? | 2007-03-05 | 2007-04-06 |  | 260d | finish no earlier than 2007-04-06 |
| 69 |  | Science Instrument Requirements | 25d? | 2007-03-05 | 2007-04-06 |  | 260d | start no earlier than 2007-03-05 |
| 70 | 2.1.2 | **Galactic** | 145d? | 2006-09-18 | 2007-04-06 |  | 260d |  |

| ID | WBS | Task | Duration | Start | Finish | Predecessors | Total float | Constraint |
| --- | --- | --- | --- | --- | --- | --- | --- | --- |
| 71 | 2.1.2.1 | **Galactic Center Proper Motions: Astrometry** | 85d? | 2006-09-18 | 2007-01-12 |  | 320d |  |
| 72 |  | Astrometry requirements | 50d? | 2006-09-18 | 2006-11-24 |  | 355d | finish no earlier than 2006-11-24 |
| 73 |  | Observing Scenarios | 35d? | 2006-11-27 | 2007-01-12 |  | 320d | finish no earlier than 2007-01-12 |
| 74 |  | Science Instrument Requirements | 35d? | 2006-11-27 | 2007-01-12 |  | 320d | start no earlier than 2006-11-27 |
| 75 | 2.1.2.2 | **Galactic Center Radial Velocities & Stellar Populations: Integral Field Spectroscopy** | 75d? | 2006-11-27 | 2007-03-09 |  | 280d |  |
| 76 |  | Performance Requirements | 45d? | 2006-11-27 | 2007-01-26 |  | 310d | finish no earlier than 2007-01-26 |
| 77 |  | Observing Scenarios | 30d? | 2007-01-29 | 2007-03-09 |  | 280d | start no earlier than 2007-01-29 |
| 78 |  | Science Instrument Requirements | 30d? | 2007-01-29 | 2007-03-09 |  | 280d | start no earlier than 2007-01-29 |
| 79 | 2.1.2.3 | **Galactic Center Nature of Sgr A*: 3-5 um Color & 2 um Polarimetry Variability** | 50d? | 2007-01-29 | 2007-04-06 |  | 260d |  |
| 80 |  | Performance Requirements | 25d? | 2007-01-29 | 2007-03-02 |  | 285d | finish no earlier than 2007-03-02 |
| 81 |  | Observing Scenarios | 25d? | 2007-03-05 | 2007-04-06 |  | 260d | start no earlier than 2007-03-05 |
| 82 |  | Science Instrument Requirements | 25d? | 2007-03-05 | 2007-04-06 |  | 260d | finish no earlier than 2007-04-06 |
| 83 | 2.1.2.4 | **Planets around Low Mass Stars & Brown Dwarfs: Companion Sensitivity** | 85d? | 2006-09-18 | 2007-01-12 |  | 320d |  |
| 84 |  | Companion Sensitivity Performance Requirements | 50d? | 2006-09-18 | 2006-11-24 |  | 355d | finish no earlier than 2006-11-24 |
| 85 |  | Observing Scenarios | 35d? | 2006-11-27 | 2007-01-12 |  | 320d | start no earlier than 2006-11-27 |
| 86 |  | Science Instrument Requirements | 35d? | 2006-11-27 | 2007-01-12 |  | 320d | start no earlier than 2006-11-27 |
| 87 | 2.1.2.5 | **Debris Disks, Protostellar Envelopes & Outflows: Contrast** | 50d? | 2007-01-29 | 2007-04-06 |  | 260d |  |
| 88 |  | Contrast Performance Requirements | 25d? | 2007-01-29 | 2007-03-02 |  | 285d | finish no earlier than 2007-03-02 |
| 89 |  | Observing Scenarios | 25d? | 2007-03-05 | 2007-04-06 |  | 260d | start no earlier than 2007-03-05 |
| 90 |  | Science Instrument Requirements | 25d? | 2007-03-05 | 2007-04-06 |  | 260d | start no earlier than 2007-03-05 |
| 91 | 2.1.2.6 | **Debris Disks, Protostellar Envelopes & Outflows: Polarimetry** | 75d? | 2006-11-27 | 2007-03-09 |  | 280d |  |
| 92 |  | Polarimetry Performance Requirements | 45d? | 2006-11-27 | 2007-01-26 |  | 310d | finish no earlier than 2007-01-26 |
| 93 |  | Observing Scenarios | 30d? | 2007-01-29 | 2007-03-09 |  | 280d | start no earlier than 2007-01-29 |
| 94 |  | Science Instrument Requirements | 30d? | 2007-01-29 | 2007-03-09 |  | 280d | start no earlier than 2007-01-29 |
| 95 | 2.1.3 | **Extragalactic** | 160d? | 2006-09-18 | 2007-04-27 |  | 245d |  |
| 96 | 2.1.3.1 | **Resolved Stellar Populations in Crowded Fields** | 100d? | 2006-09-18 | 2007-02-02 |  | 305d |  |
| 97 |  | Performance Requirements | 60d? | 2006-09-18 | 2006-12-08 |  | 345d | finish no earlier than 2006-12-08 |
| 98 |  | Observing Scenarios | 40d? | 2006-12-11 | 2007-02-02 |  | 305d | finish no earlier than 2007-02-02 |
| 99 |  | Science Instrument Requirements | 40d? | 2006-12-11 | 2007-02-02 |  | 305d | start no earlier than 2006-12-11 |
| 100 | 2.1.3.2 | **High Redshift Galaxies** | 100d? | 2006-09-18 | 2007-02-02 |  | 305d |  |
| 101 |  | Encircled Energy Performance Requirements | 60d? | 2006-09-18 | 2006-12-08 |  | 345d | finish no earlier than 2006-12-08 |
| 102 |  | Observing Scenarios | 40d? | 2006-12-11 | 2007-02-02 |  | 305d | start no earlier than 2006-12-11 |
| 103 |  | Science Instrument Requirements | 40d? | 2006-12-11 | 2007-02-02 |  | 305d | start no earlier than 2006-12-11 |
| 104 | 2.1.3.3 | **Nearby Galaxies** | 100d? | 2006-12-11 | 2007-04-27 |  | 245d |  |
| 105 |  | Encircled Energy & PSF Performance Requirements | 60d? | 2006-12-11 | 2007-03-02 |  | 285d | finish no earlier than 2007-03-02 |
| 106 |  | Observing Scenarios | 40d? | 2007-03-05 | 2007-04-27 |  | 245d | finish no earlier than 2007-04-27 |
| 107 |  | Science Instrument Requirements | 40d? | 2007-03-05 | 2007-04-27 |  | 245d | start no earlier than 2007-03-05 |
| 108 | 2.1.3.4 | **Gravitational Lensing** | 100d? | 2006-12-11 | 2007-04-27 |  | 245d |  |
| 109 |  | Encircled Energy & PSF Performance Requirements | 60d? | 2006-12-11 | 2007-03-02 |  | 285d | start no earlier than 2006-12-11 |
| 110 |  | Observing Scenarios | 40d? | 2007-03-05 | 2007-04-27 |  | 245d | start no earlier than 2007-03-05 |
| 111 |  | Science Instrument Requirements | 40d? | 2007-03-05 | 2007-04-27 |  | 245d | start no earlier than 2007-03-05 |
| 112 | 2.1.4 | **Science Requirements Summary** | 344d? | 2006-09-05 | 2007-12-28 |  | 70d |  |
| 113 |  | Revision 1 | 29d? | 2006-09-05 | 2006-10-13 |  | 385d | finish no earlier than 2006-10-13 |
| 114 |  | Revision 2 | 21d? | 2007-02-02 | 2007-03-02 |  | 285d | finish no earlier than 2007-03-02 |
| 115 |  | Revision 3 | 15d? | 2007-06-04 | 2007-06-22 |  | 205d | finish no earlier than 2007-06-22 |
| 116 |  | Final SD Version | 20d? | 2007-12-03 | 2007-12-28 |  | 62d | finish no earlier than 2007-12-28 |
| 117 | 2.2 | **Observatory Requirements** | 338.12d? | 2006-09-12 | 2007-12-28 |  | 70d |  |
| 118 |  | Revision 1 | 33.12d? | 2006-09-12 | 2006-10-27 |  | 375d | finish no earlier than 2006-10-27 |
| 119 |  | Revision 2 | 10d? | 2007-02-19 | 2007-03-02 |  | 285d | start no earlier than 2007-02-19 |
| 120 |  | Revision 3 | 15d? | 2007-06-04 | 2007-06-22 |  | 205d | finish no earlier than 2007-06-22 |
| 121 |  | Revision 4 | 20d? | 2007-12-03 | 2007-12-28 |  | 62d | finish no earlier than 2007-12-28 |
| 122 | 2.3 | **System Requirements Document** | 331d? | 2006-10-09 | 2008-01-15 |  | 59d |  |
| 123 | 2.3.1 | **Technical Requirements Flow Down** | 331d? | 2006-10-09 | 2008-01-14 |  | 59d |  |
| 124 |  | Revision 1 | 10d? | 2006-10-09 | 2006-10-20 |  | 380d | finish no earlier than 2006-10-20 |
| 125 |  | Revision 2 | 89d? | 2006-11-01 | 2007-03-05 |  | 284d | start no earlier than 2006-11-01 |
| 126 |  | Revision 3 | 10d? | 2007-06-15 | 2007-06-28 |  | 201d | finish no earlier than 2007-06-28 |
| 127 |  | Revision 4 | 9d? | 2008-01-02 | 2008-01-14 |  | 51d | finish no earlier than 2008-01-14 |
| 128 | 2.3.2 | **System Requirements Document** | 316d | 2006-10-27 | 2008-01-15 |  | 59d |  |
| 129 |  | Revision 1 Release | 0d | 2006-10-27 | 2006-10-27 | 113, 124, 118 | 375d | start no earlier than 2006-10-27 |
| 130 |  | Revision 2 Release | 0d | 2007-03-09 | 2007-03-09 | 114, 125, 119 | 281d | start no earlier than 2007-03-09 |
| 131 |  | Revision 3 Release | 0d | 2007-06-29 | 2007-06-29 | 115, 126, 120 | 201d | start no earlier than 2007-06-29 |
| 132 |  | Final SD Version Release | 0d | 2008-01-15 | 2008-01-15 | 116, 127, 121 | 51d | start no earlier than 2008-01-15 |
| 133 | 3 | **System Design** | 590d? | 2005-11-16 | 2008-02-19 |  | 33d |  |
| 134 | 3.1 | **Systems Engineering** | 554d? | 2005-11-16 | 2007-12-31 |  | 41d |  |
| 135 | 3.1.1 | **Performance Budgets** | 423d? | 2005-11-16 | 2007-06-29 |  | 200d |  |
| 136 | 3.1.1.1 | **Model Assumptions** | 230d? | 2006-08-14 | 2007-06-29 |  | 200d |  |
| 137 | 3.1.1.1.1 | **TMT site monitoring data mining** | 230d? | 2006-08-14 | 2007-06-29 |  | 200d |  |
| 138 |  | Tools in place & 1st release | 24d? | 2006-08-14 | 2006-09-14 |  | 201d | finish no earlier than 2006-09-14 |
| 139 |  | Release updated data (every two months) | 205d? | 2006-09-18 | 2007-06-29 | 138 | 200d | finish no earlier than 2007-06-29 |
| 140 |  | Telescope dynamic performance data | 44d? | 2006-10-02 | 2006-11-30 |  | 316d | start no earlier than 2006-10-02 |

| ID | WBS | Task | Duration | Start | Finish | Predecessors | Total float | Constraint |
| --- | --- | --- | --- | --- | --- | --- | --- | --- |
| 141 |  | Telescope static wavefront errors | 44d? | 2006-10-02 | 2006-11-30 |  | 316d | finish no earlier than 2006-11-30 |
| 142 |  | Sodium return vs laser format | 22d? | 2006-11-01 | 2006-11-30 |  | 329d | start no earlier than 2006-11-01 |
| 143 | 3.1.1.2 | **Model/Tool Validation** | 90d? | 2006-08-14 | 2006-12-15 |  | 318d |  |
| 144 |  | Agreement between Tomography Codes | 35d? | 2006-08-14 | 2006-09-29 |  | 373d | start no earlier than 2006-08-14 |
| 145 |  | Agreement between Sky Coverage Codes | 23d? | 2006-09-18 | 2006-10-18 |  | 360d | start no earlier than 2006-09-18 |
| 146 |  | Anchor to Keck II LGS AO PSFs | 21d? | 2006-10-02 | 2006-10-30 |  | 352d | finish no earlier than 2006-10-30 |
| 147 |  | Anchor to On-sky MGSU Experiments | 3.67d? | 2006-11-10 | 2006-11-15 |  | 340d | finish no earlier than 2006-11-15 |
| 148 |  | Anchor to LAO Lab Experiments | 30d? | 2006-11-06 | 2006-12-15 |  | 318d | start no earlier than 2006-11-06 |
| 149 |  | Throughput | 65d? | 2006-10-02 | 2006-12-29 |  | 330d | finish no earlier than 2006-12-29 |
| 150 | 3.1.1.4 | **Background** | 65d? | 2006-10-02 | 2006-12-29 |  | 330d |  |
| 151 |  | Document Proposal Analysis | 9d? | 2006-10-02 | 2006-10-12 |  | 386d | start no earlier than 2006-10-02 |
| 152 |  | Develop Background Performance Budget | 56d? | 2006-10-02 | 2006-12-29 |  | 330d | start no earlier than 2006-10-02 |
| 153 | 3.1.1.5 | **Wavefront Error vs Sky Coverage** | 131d? | 2006-08-01 | 2007-01-30 |  | 308d |  |
| 154 |  | Document & release version 1 | 24d? | 2006-08-01 | 2006-09-01 |  | 415d | finish no earlier than 2006-09-01 |
| 155 |  | Develop version 2, document & release | 22d? | 2007-01-01 | 2007-01-30 | 138, 142, 143, 182 | 308d | finish no earlier than 2007-01-30 |
| 156 |  | Encircled Energy vs Sky Coverage | 50d? | 2006-10-23 | 2006-12-29 |  | 330d | start no earlier than 2006-10-23 |
| 157 |  | Photometric Accuracy | 75d? | 2006-10-16 | 2007-01-26 |  | 310d | start no earlier than 2006-10-16 |
| 158 |  | Astrometric Accuracy | 55d? | 2006-11-13 | 2007-01-26 |  | 310d | start no earlier than 2006-11-13 |
| 159 |  | Polarimetric Accuracy | 25d? | 2007-02-05 | 2007-03-09 |  | 280d | start no earlier than 2007-02-05 |
| 160 |  | Companion Sensitivity | 55d? | 2006-11-13 | 2007-01-26 |  | 310d | start no earlier than 2006-11-13 |
| 161 |  | Observing Efficiency | 30d? | 2007-02-05 | 2007-03-16 |  | 275d | start no earlier than 2007-02-05 |
| 162 |  | Observing Uptime | 30d? | 2007-02-05 | 2007-03-16 |  | 275d | start no earlier than 2007-02-05 |
| 163 | 3.1.1.13 | **Performance Budgets Summary** | 413d? | 2005-11-16 | 2007-06-15 |  | 166d |  |
| 164 |  | Performance Budgets Version 1 | 20d? | 2005-11-16 | 2007-02-09 |  | 256d |  |
| 165 |  | Performance Budgets Version 2 | 25d? | 2007-05-14 | 2007-06-15 |  | 166d | start no earlier than 2007-05-14 |
| 166 | 3.1.1.14 | **Science Products** | 15d? | 2007-02-12 | 2007-03-02 |  | 285d |  |
| 167 |  | All-In Science Simulations | 15d? | 2007-02-12 | 2007-03-02 | 164 | 285d |  |
| 168 | 3.1.1.14.2 | **Additional Science Characterization Results** | 15d? | 2007-02-12 | 2007-03-02 | 164 | 285d |  |
| 169 |  | Point Source Sensitivities | 15d? | 2007-02-12 | 2007-03-02 |  | 285d | start no earlier than 2007-01-08 |
| 170 |  | PSF Uniformity & Stability | 15d? | 2007-02-12 | 2007-03-02 |  | 285d | finish no earlier than 2007-01-26 |
| 171 |  | Other | 1d? | 2007-02-12 | 2007-02-12 |  | 299d |  |
| 172 | 3.1.2 | **Trade Studies** | 160d? | 2006-10-16 | 2007-05-25 |  | 157d |  |
| 173 | 3.1.2.1 | **System Architecture Trade Studies** | 100d? | 2006-10-16 | 2007-03-02 |  | 285d |  |
| 174 |  | MOAO & MCAO TS | 25d? | 2006-11-13 | 2006-12-15 |  | 340d | finish no earlier than 2006-12-15 |
| 175 |  | NGAO versus Keck AO upgrades TS (meeting 5) | 20d? | 2007-02-05 | 2007-03-02 |  | 285d | start no earlier than 2007-02-05 |
| 176 |  | Adaptive Secondary Mirror option TS (m5) | 20d? | 2007-02-05 | 2007-03-02 |  | 285d | start no earlier than 2007-02-05 |
| 177 |  | K & L-band Science TS (m5) | 20d? | 2007-02-05 | 2007-03-02 |  | 285d | start no earlier than 2007-02-05 |
| 178 |  | Keck Interferometer Support TS (m5) | 100d? | 2006-10-16 | 2007-03-02 |  | 285d | start no earlier than 2006-10-16 |
| 179 |  | Instrument Balance TS | 20d? | 2006-11-13 | 2006-12-08 |  | 345d | start no earlier than 2006-11-13 |
| 180 |  | GLAO for non-NGAO Instruments TS (m5) | 20d? | 2007-02-05 | 2007-03-02 |  | 285d | start no earlier than 2007-02-05 |
| 181 |  | Science Instrument Re-use Cost/Benefit TS (m3) | 20d? | 2006-11-13 | 2006-12-08 |  | 345d | start no earlier than 2006-11-13 |
| 182 |  | Telescope Wavefront Errors TS | 13d? | 2006-12-04 | 2006-12-20 | 140, 141 | 315d | finish no earlier than 2006-12-20 |
| 183 | 3.1.2.2 | **Adaptive Optics System Trade Studies** | 150d? | 2006-10-30 | 2007-05-25 |  | 147d |  |
| 184 |  | AO Enclosure Temperature TS (m6) | 74d? | 2007-01-02 | 2007-04-13 |  | 141d | start no earlier than 2007-01-02 |
| 185 |  | Optical Relay TS (m6) | 74d? | 2007-01-02 | 2007-04-13 |  | 101d | finish no earlier than 2007-04-13 |
| 186 |  | Field Rotation Strategy TS (m6) | 74d? | 2007-01-02 | 2007-04-13 |  | 101d | start no earlier than 2007-01-02 |
| 187 |  | Dichroics & Beamsplitters TS (m6) | 74d? | 2007-01-02 | 2007-04-13 |  | 101d | start no earlier than 2007-01-02 |
| 188 |  | Rayleigh Rejection TS (m3) | 30d? | 2006-10-30 | 2006-12-08 |  | 345d | start no earlier than 2006-10-30 |
| 189 |  | LGS WFS Type TS (m4) | 35d? | 2006-12-04 | 2007-01-19 |  | 226d | start no earlier than 2006-12-04 |
| 190 |  | LGS WFS number of subapertures TS (m4) | 35d? | 2006-12-04 | 2007-01-19 |  | 226d | start no earlier than 2006-12-04 |
| 191 |  | Slow WFS TS (m7) | 25d? | 2007-04-23 | 2007-05-25 |  | 66d | start no earlier than 2007-04-23 |
| 192 |  | LOWFS Architecture TS | 35d? | 2006-12-04 | 2007-01-19 |  | 226d | start no earlier than 2006-12-04 |
| 193 |  | Number & Type of LOWFS TS (m4) | 35d? | 2006-12-04 | 2007-01-19 |  | 226d | start no earlier than 2006-12-04 |
| 194 |  | Centroid Anisoplanatism TS (m7) | 25d? | 2007-04-23 | 2007-05-25 |  | 225d | start no earlier than 2007-04-23 |
| 195 |  | Deformable Mirror Stroke Requirement TS (m6) | 74d? | 2007-01-02 | 2007-04-13 |  | 255d | start no earlier than 2007-01-02 |
| 196 |  | Stand-alone vs DM on T/T Stage TS (m3) | 30d? | 2006-10-30 | 2006-12-08 |  | 345d | start no earlier than 2006-10-30 |
| 197 |  | Correcting Fast T/T with DM TS | 30d? | 2006-10-30 | 2006-12-08 |  | 345d | finish no earlier than 2006-12-08 |
| 198 |  | Focus Compensation TS (m6) | 74d? | 2007-01-02 | 2007-04-13 |  | 255d | start no earlier than 2007-01-02 |
| 199 | 3.1.2.3 | **Laser Facility Trade Studies** | 155d? | 2006-10-23 | 2007-05-25 |  | 225d |  |
| 200 |  | Laser Pulse Format TS (m6) | 74d? | 2007-01-02 | 2007-04-13 |  | 255d | start no earlier than 2007-01-02 |
| 201 |  | Free Space vs Fiber TS (m7) | 25d? | 2007-04-23 | 2007-05-25 |  | 225d | start no earlier than 2007-04-23 |
| 202 |  | LGS Asterism Geometry & Size TS (m2) | 5d? | 2006-10-23 | 2006-10-27 |  | 375d | finish no earlier than 2006-10-27 |
| 203 |  | Variable vs fixed LGS Asterism Cost/Benefit TS (m2) | 5d? | 2006-10-23 | 2006-10-27 |  | 375d | finish no earlier than 2006-10-27 |
| 204 | 3.1.3 | **System Architecture** | 554d? | 2005-11-16 | 2007-12-31 |  | 41d |  |
| 205 |  | System Architecture Version 1 | 36d? | 2006-11-01 | 2006-12-20 |  | 269d | start no earlier than 2006-11-01 |
| 206 |  | System Architecture Version 2 | 20d? | 2007-10-01 | 2007-10-26 |  | 115d | start no earlier than 2007-10-01 |
| 207 | 3.1.3.3 | **Functional Requirements** | 538d? | 2005-11-16 | 2007-12-07 |  | 41d |  |
| 208 |  | AO System Functional Requirements Version 1 | 17.25d? | 2007-01-10 | 2007-02-02 | 205 | 261d | finish no earlier than 2007-02-02 |
| 209 |  | AO System Functional Requirements Version 2 | 25d? | 2005-11-16 | 2007-11-30 |  | 46d |  |
| 210 |  | Laser System Functional Requirements Version 1 | 20d? | 2007-02-05 | 2007-03-02 | 205 | 241d | finish no earlier than 2007-03-02 |

| ID | WBS | Task | Duration | Start | Finish | Predecessors | Total float | Constraint |
| --- | --- | --- | --- | --- | --- | --- | --- | --- |
| 211 |  | Laser System Functional Requirements Version 2 | 25d? | 2005-11-16 | 2007-12-07 |  | 41d |  |
| 212 |  | Science Operations Functional Requirements Version 1 | 24d? | 2007-01-02 | 2007-02-02 | 205 | 261d | finish no earlier than 2007-02-02 |
| 213 |  | Science Operations Functional Requirements Version 2 | 25d? | 2005-11-16 | 2007-11-30 |  | 46d |  |
| 214 |  | Science Instruments Functional Requirements Version 1 | 24d? | 2007-01-02 | 2007-02-02 |  | 261d | start no earlier than 2007-01-02 |
| 215 |  | Science Instruments Functional Requirements Version 2 | 25d? | 2005-11-16 | 2007-11-30 |  | 46d |  |
| 216 |  | Technology Drivers Summary | 21d? | 2007-06-14 | 2007-12-31 |  | 25d | finish no earlier than 2007-12-31 |
| 217 |  | Technical Risk Analysis | 25d? | 2007-06-01 | 2007-12-14 |  | 36d | start no earlier than 2007-06-01 |
| 218 | 3.2 | **AO System** | 219d? | 2007-01-02 | 2007-11-02 |  | 66d |  |
| 219 |  | AO System Architecture | 84d? | 2007-01-02 | 2007-04-27 |  | 201d | finish no earlier than 2007-04-27 |
| 220 |  | AO Enclosure | 70d? | 2007-04-16 | 2007-07-20 | 184 | 141d | start no earlier than 2007-01-22 |
| 221 | 3.2.3 | **Opto-mechanical** | 175d? | 2007-03-05 | 2007-11-02 |  | 66d |  |
| 222 |  | Field Rotation | 55d? | 2007-04-16 | 2007-06-29 | 186 | 101d | finish no earlier than 2007-06-29 |
| 223 |  | Optical Relay | 55d? | 2007-04-16 | 2007-06-29 | 185 | 101d | start no earlier than 2007-03-05 |
| 224 |  | Optical Switchyard | 55d? | 2007-04-16 | 2007-06-29 | 187 | 101d | finish no earlier than 2007-06-29 |
| 225 |  | Optical Support Structure | 55d? | 2007-07-02 | 2007-09-14 | 222, 223, 224 | 101d | start no earlier than 2007-04-16 |
| 226 | 3.2.3.5 | **Wavefront Sensors** | 145d? | 2007-04-16 | 2007-11-02 |  | 66d |  |
| 227 |  | High Order LGS Wavefront Sensors | 45d? | 2007-04-16 | 2007-06-15 | 189, 190 | 166d | start no earlier than 2007-04-16 |
| 228 |  | High Order NGS Wavefront Sensor | 45d? | 2007-04-16 | 2007-06-15 |  | 166d | start no earlier than 2007-04-16 |
| 229 |  | Low Order NGS Wavefront Sensors | 45d? | 2007-04-16 | 2007-06-15 | 192, 193 | 166d | start no earlier than 2007-04-16 |
| 230 |  | Calibration Wavefront Sensor | 115d? | 2007-05-28 | 2007-11-02 | 191 | 66d | start no earlier than 2007-04-16 |
| 231 | 3.2.3.6 | **Wavefront Correctors** | 85d? | 2007-03-05 | 2007-06-29 |  | 156d |  |
| 232 |  | Tip/Tilt Corrector | 85d? | 2007-03-05 | 2007-06-29 |  | 156d | start no earlier than 2007-03-05 |
| 233 |  | Deformable Mirror | 85d? | 2007-03-05 | 2007-06-29 |  | 156d | start no earlier than 2007-03-05 |
| 234 | 3.2.3.7 | **Acquisition Cameras** | 85d? | 2007-03-05 | 2007-06-29 |  | 156d |  |
| 235 |  | NGS Acquisition Camera | 85d? | 2007-03-05 | 2007-06-29 |  | 156d | start no earlier than 2007-03-05 |
| 236 |  | LGS Acquisition Camera | 85d? | 2007-03-05 | 2007-06-29 |  | 156d | start no earlier than 2007-03-05 |
| 237 |  | Atmospheric Dispersion Correction | 85d? | 2007-03-05 | 2007-06-29 |  | 156d | start no earlier than 2007-03-05 |
| 238 |  | Alignment, Calibration, Diagnostics, Metrology and Monitoring | 85d? | 2007-03-05 | 2007-06-29 |  | 156d | start no earlier than 2007-03-05 |
| 239 | 3.2.4 | **Non-real-time Control** | 64d? | 2007-05-01 | 2007-07-27 |  | 136d |  |
| 240 |  | Non-RTC Software Design | 64d? | 2007-05-01 | 2007-07-27 |  | 136d | finish no earlier than 2007-07-27 |
| 241 |  | Non-RTC Electrical Design | 64d? | 2007-05-01 | 2007-07-27 |  | 136d | start no earlier than 2007-05-01 |
| 242 | 3.2.5 | **Real-time Control** | 119d? | 2007-01-02 | 2007-06-15 |  | 166d |  |
| 243 |  | RTC Architecture Analysis and Design Study | 64d? | 2007-01-02 | 2007-03-30 |  | 221d | finish no earlier than 2007-03-30 |
| 244 |  | RTC Software Module Definition | 75d? | 2007-03-05 | 2007-06-15 |  | 166d | finish no earlier than 2007-06-15 |
| 245 |  | RTC Hardware Module Definition | 75d? | 2007-03-05 | 2007-06-15 |  | 166d | finish no earlier than 2007-06-15 |
| 246 | 3.3 | **Laser Facility** | 154d? | 2007-01-02 | 2007-08-03 |  | 131d |  |
| 247 |  | Laser System Architecture | 85d? | 2007-01-02 | 2007-04-30 |  | 200d | start no earlier than 2007-01-02 |
| 248 |  | Laser Enclosure | 43d? | 2007-05-01 | 2007-06-28 |  | 157d | start no earlier than 2007-05-01 |
| 249 |  | Laser | 35d? | 2007-01-15 | 2007-03-02 |  | 241d | start no earlier than 2007-01-15 |
| 250 | 3.3.4 | **Laser Launch Facility** | 87d? | 2007-01-30 | 2007-05-30 |  | 178d |  |
| 251 |  | Laser Beam Transport | 60d? | 2007-02-05 | 2007-04-27 |  | 201d | finish no earlier than 2007-04-27 |
| 252 |  | Laser Pointing & Diagnostics | 43d? | 2007-04-02 | 2007-05-30 |  | 178d | finish no earlier than 2007-05-30 |
| 253 |  | Laser Launch Telescope | 65d? | 2007-01-30 | 2007-04-30 |  | 200d | finish no earlier than 2007-04-30 |
| 254 | 3.3.5 | **Laser Safety Systems** | 20d? | 2007-07-09 | 2007-08-03 |  | 131d |  |
| 255 |  | Personnel and Equipment Safety Systems | 20d? | 2007-07-09 | 2007-08-03 |  | 131d | start no earlier than 2007-07-09 |
| 256 |  | Aircraft and Satellite Safety Systems | 20d? | 2007-07-09 | 2007-08-03 |  | 131d | start no earlier than 2007-07-09 |
| 257 |  | Laser Traffic Control System | 20d? | 2007-07-09 | 2007-08-03 |  | 131d | start no earlier than 2007-07-09 |
| 258 | 3.3.7 | **Laser System Control** | 85d? | 2007-02-01 | 2007-05-30 |  | 178d |  |
| 259 |  | Laser System Software | 85d? | 2007-02-01 | 2007-05-30 |  | 178d | finish no earlier than 2007-05-30 |
| 260 |  | Laser System Electronics | 85d? | 2007-02-01 | 2007-05-30 |  | 178d | finish no earlier than 2007-05-30 |
| 261 | 3.4 | **Science Operations** | 173d? | 2006-10-02 | 2007-05-30 |  | 178d |  |
| 262 |  | Operations Architecture | 151d? | 2006-10-02 | 2007-04-30 |  | 200d | start no earlier than 2006-10-02 |
| 263 |  | Observing Setup | 63d? | 2007-02-01 | 2007-04-30 |  | 200d | finish no earlier than 2007-04-30 |
| 264 |  | User Interface | 85d? | 2007-02-01 | 2007-05-30 |  | 178d | finish no earlier than 2007-05-30 |
| 265 |  | Astronomer Planning | 65d? | 2007-03-01 | 2007-05-30 |  | 178d | finish no earlier than 2007-05-30 |
| 266 |  | Science Instruments & Telescope Interface | 42d? | 2007-01-02 | 2007-02-28 |  | 243d | finish no earlier than 2007-02-28 |
| 267 |  | Performance Monitoring | 65d? | 2006-11-01 | 2007-01-30 |  | 264d | finish no earlier than 2007-01-30 |
| 268 |  | Automation & Optimization | 65d? | 2006-11-01 | 2007-01-30 |  | 264d | finish no earlier than 2007-01-30 |
| 269 | 3.5 | **Science Instruments** | 173d? | 2006-10-02 | 2007-05-30 |  | 178d |  |
| 270 |  | OSIRIS | 43d? | 2006-12-01 | 2007-01-30 |  | 264d | start no earlier than 2006-12-01 |
| 271 |  | Interferometer | 130d? | 2006-10-02 | 2007-03-30 |  | 221d | start no earlier than 2006-10-02 |
| 272 |  | OHANA | 20d? | 2007-02-01 | 2007-02-28 |  | 243d | start no earlier than 2007-02-01 |
| 273 |  | Near-IR Imager | 87d? | 2006-10-02 | 2007-01-30 |  | 264d | start no earlier than 2006-10-02 |
| 274 |  | Visible Imager | 87d? | 2006-10-02 | 2007-01-30 |  | 264d | start no earlier than 2006-10-02 |
| 275 |  | Visible IFU | 64d? | 2007-01-02 | 2007-03-30 |  | 221d | start no earlier than 2007-01-02 |
| 276 |  | Deployable Near-IR IFU | 63d? | 2007-02-01 | 2007-04-30 |  | 200d | start no earlier than 2007-02-01 |
| 277 |  | Mid-IR IFU | 22d? | 2007-05-01 | 2007-05-30 |  | 178d | start no earlier than 2007-05-01 |
| 278 |  | System Design Manual | 35d? | 2008-01-01 | 2008-02-19 | 207, 217, 269, 163, 261, 216, 246, 218 | 25d | finish no earlier than 2007-11-16 |
| 279 | 4 | **Systems Engineering Management Plan (SEMP)** | 253d? | 2007-01-15 | 2008-01-02 |  | 59d |  |
| 280 | 4.1 | **Project Plan** | 59.25d? | 2007-09-17 | 2007-12-07 |  | 64d |  |

| ID | WBS | Task | Duration | Start | Finish | Predecessors | Total float | Constraint |
| --- | --- | --- | --- | --- | --- | --- | --- | --- |
| 281 |  | Task Definition | 4.25d? | 2007-09-17 | 2007-09-21 |  | 119d | finish no earlier than 2007-09-21 |
| 282 |  | Cost Estimation | 9d? | 2007-10-23 | 2007-11-02 |  | 89d | finish no earlier than 2007-11-02 |
| 283 |  | Major Project Milestones | 2.5d? | 2007-11-09 | 2007-11-13 |  | 82d | finish no earlier than 2007-11-13 |
| 284 |  | MS Project Plan | 4.5d? | 2007-12-03 | 2007-12-07 |  | 64d | finish no earlier than 2007-12-07 |
| 285 |  | Risk Assessment & Management Plan | 23d? | 2007-11-14 | 2007-12-14 |  | 59d | finish no earlier than 2007-12-14 |
| 286 | 4.3 | **Preliminary Design Phase Plan** | 140d? | 2007-02-05 | 2007-08-17 |  | 144d |  |
| 287 |  | Version 1 to Support Observatory FY08 Planning | 20d? | 2007-02-05 | 2007-03-02 |  | 264d | start no earlier than 2007-02-05 |
| 288 |  | Intermediate Versions | 30d? | 2007-04-09 | 2007-05-18 |  | 209d | start no earlier than 2007-04-09 |
| 289 |  | Final Version | 15d? | 2007-07-30 | 2007-08-17 |  | 144d | start no earlier than 2007-07-30 |
| 290 | 4.4 | **Integration and Test Plans** | 187d? | 2007-03-12 | 2007-11-27 |  | 72d |  |
| 291 | 4.4.1 | **Subsystem Testing Plans** | 22d? | 2007-10-29 | 2007-11-27 |  | 72d |  |
| 292 |  | AO System Test Plan | 22d? | 2007-10-29 | 2007-11-27 |  | 72d | start no earlier than 2007-10-29 |
| 293 |  | Laser System Test Plan | 22d? | 2007-10-29 | 2007-11-27 |  | 72d | start no earlier than 2007-10-29 |
| 294 |  | Science Operations Test Plan | 22d? | 2007-10-29 | 2007-11-27 |  | 72d | start no earlier than 2007-10-29 |
| 295 |  | Science Instruments Test Plan | 22d? | 2007-10-29 | 2007-11-27 |  | 72d | start no earlier than 2007-10-29 |
| 296 |  | System Integration & Test Plans | 30d? | 2007-03-12 | 2007-04-20 |  | 229d | finish no earlier than 2007-04-20 |
| 297 |  | Configuration Management Plan | 25d? | 2007-01-15 | 2007-02-16 |  | 274d | start no earlier than 2007-01-15 |
| 298 |  | Project Management Plan | 20d? | 2007-02-12 | 2007-03-09 |  | 259d | start no earlier than 2007-02-12 |
| 299 |  | SEMP Document | 13d? | 2007-12-17 | 2008-01-02 | 280, 286, 291, 296, 297, 298, 285 | 59d | finish no earlier than 2008-01-02 |

## Version 2 (saved 2006-09-26, file NGAO_SD_schedule_v10.mpp)

Last finish stays 2008-04-04.

Added:

| ID | Task | Duration | Start | Finish | Constraint | Resources |
| --- | --- | --- | --- | --- | --- | --- |
| 183 | Observing Model TS | 1d? | 2005-11-16 | 2005-11-16 |  |  |
| 262 | **Astronomical Observations Operations** | 108d? | 2007-03-01 | 2007-07-30 |  |  |
| 263 | **Pre-Observing Interfaces** | 22d? | 2007-05-01 | 2007-05-30 |  |  |
| 264 | AO Guide Star Interface | 22d? | 2007-05-01 | 2007-05-30 | finish no earlier than 2007-05-30 |  |
| 265 | Science Observations Simulation Tools | 22d? | 2007-05-01 | 2007-05-30 | start no earlier than 2007-05-01 |  |
| 266 | **Observing Interfaces** | 43d? | 2007-03-01 | 2007-04-30 |  |  |
| 267 | Acquisition | 43d? | 2007-03-01 | 2007-04-30 | finish no earlier than 2007-04-30 |  |
| 268 | Observing Sequences | 43d? | 2007-03-01 | 2007-04-30 | start no earlier than 2007-03-01 |  |
| 269 | Instrument, AO & Telescope Observer Interfaces | 43d? | 2007-03-01 | 2007-04-30 | start no earlier than 2007-03-01 |  |
| 270 | Science Data Quality Monitoring | 43d? | 2007-03-01 | 2007-04-30 | start no earlier than 2007-03-01 |  |
| 271 | **Post-Observing Interfaces** | 42d? | 2007-06-01 | 2007-07-30 |  |  |
| 272 | Generic Data Products | 42d? | 2007-06-01 | 2007-07-30 | finish no earlier than 2007-07-30 |  |
| 273 | Science Data Quality Assessment | 42d? | 2007-06-01 | 2007-07-30 | start no earlier than 2007-06-01 |  |
| 274 | Science Data Archiving | 42d? | 2007-06-01 | 2007-07-30 | start no earlier than 2007-06-01 |  |
| 275 | **AO-Instrument Operations** | 154d? | 2007-01-02 | 2007-08-03 |  |  |
| 276 | **AO-Instrument Operations Architecture** | 154d? | 2007-01-02 | 2007-08-03 |  |  |
| 277 | AO-Instrument Observing Modes | 24d? | 2007-01-02 | 2007-02-02 | start no earlier than 2007-01-02 | Le Mignant [20.8%]; Other [20.8%] |
| 278 | AO-Instrument Operations Support | 83d? | 2007-02-05 | 2007-05-30 | finish no earlier than 2007-05-30 |  |
| 279 | AO-Instrument Configuration & Setup | 83d? | 2007-02-05 | 2007-05-30 | start no earlier than 2007-02-05 |  |
| 280 | AO-Instrument Calibrations | 83d? | 2007-02-05 | 2007-05-30 | start no earlier than 2007-02-05 |  |
| 281 | AO-Instrument Nighttime Operation Modes | 83d? | 2007-02-05 | 2007-05-30 | start no earlier than 2007-02-05 |  |
| 282 | AO-Instrument Science Acquisition & Control | 83d? | 2007-02-05 | 2007-05-30 | start no earlier than 2007-02-05 |  |
| 283 | AO-Instrument Health Monitoring & Automated Recovery | 83d? | 2007-02-05 | 2007-05-30 | start no earlier than 2007-02-05 |  |
| 284 | AO-Instrument Laser Traffic Control | 20d? | 2007-07-09 | 2007-08-03 | start no earlier than 2007-07-09 | Summers [6.2%] |
| 285 | AO-Instrument User Interfaces | 20d? | 2007-06-04 | 2007-06-29 | finish no earlier than 2007-06-29 |  |
| 286 | AO-Instrument Maintenance Plan | 20d? | 2007-07-02 | 2007-07-27 | finish no earlier than 2007-07-27 |  |
| 287 | **AO-Instrument Operations Optimization** | 45d? | 2007-03-05 | 2007-05-04 |  |  |
| 288 | AO-Instrument Performance Prediction | 30d? | 2007-03-05 | 2007-04-13 | start no earlier than 2007-03-05 | Flicker [25%]; Other [8.3%] |
| 289 | AO-Instrument Real-Time Optimization | 30d? | 2007-03-05 | 2007-04-13 | start no earlier than 2007-03-05 | Flicker [25%]; Other [8.3%] |
| 290 | AO-Instrument Environment Monitoring | 15d? | 2007-04-16 | 2007-05-04 | finish no earlier than 2007-05-04 |  |

Removed: 257 Laser Traffic Control System; 262 Operations Architecture; 263 Observing Setup; 264 User Interface; 265 Astronomer Planning; 266 Science Instruments & Telescope Interface; 267 Performance Monitoring; 268 Automation & Optimization

Changed:

| ID | Task | Start | Finish | Duration | Total float | Other |
| --- | --- | --- | --- | --- | --- | --- |
| 24 | Team Meeting (CIT) | 2007-09-13 → 2007-09-11 (-2d) | 2007-09-13 → 2007-09-11 (-2d) |  | 146d → 148d | constraint start no earlier than 2007-09-13 → start no earlier than 2007-09-11 |
| 135 | **Performance Budgets** | 2005-11-16 → 2006-08-01 (+258d) |  | 423d? → 239d? |  |  |
| 163 | **Performance Budgets Summary** | 2005-11-16 → 2007-01-15 (+425d) |  | 413d? → 110d? |  |  |
| 164 | Performance Budgets Version 1 | 2005-11-16 → 2007-01-15 (+425d) |  |  |  | constraint none → start no earlier than 2007-01-15 |
| 172 | **Trade Studies** | 2006-10-16 → 2005-11-16 (-334d) |  | 160d? → 398d? | 157d → 225d |  |
| 173 | **System Architecture Trade Studies** | 2006-10-16 → 2005-11-16 (-334d) |  | 100d? → 338d? |  |  |
| 205 | **System Architecture** | 2005-11-16 → 2006-11-01 (+350d) |  | 554d? → 304d? | 41d → 69d |  |
| 208 | **Functional Requirements** | 2005-11-16 → 2007-01-02 (+412d) |  | 538d? → 244d? |  |  |
| 210 | AO System Functional Requirements Version 2 | 2005-11-16 → 2007-10-29 (+712d) |  |  |  | constraint none → start no earlier than 2007-10-29 |
| 212 | Laser System Functional Requirements Version 2 | 2005-11-16 → 2007-11-05 (+719d) |  |  |  | constraint none → start no earlier than 2007-11-05 |
| 214 | Science Operations Functional Requirements Version 2 | 2005-11-16 → 2007-10-29 (+712d) |  |  |  | constraint none → start no earlier than 2007-10-29 |
| 216 | Science Instruments Functional Requirements Version 2 | 2005-11-16 → 2007-10-29 (+712d) |  |  |  | constraint none → start no earlier than 2007-10-29 |
| 220 | AO System Architecture | 2007-01-02 → 2007-02-05 (+34d) |  | 84d? → 60d? |  | constraint finish no earlier than 2007-04-27 → start no earlier than 2007-02-05; resources none → Neyman [67.7%]; Other [67.7%] |
| 231 | Calibration Wavefront Sensor |  |  |  |  | resources none → Kellner [2.2%] |
| 233 | Tip/Tilt Corrector |  |  |  |  | resources none → Flicker [2.9%] |
| 234 | Deformable Mirror |  |  |  |  | resources none → Flicker [2.9%] |
| 238 | Atmospheric Dispersion Correction |  |  |  |  | resources none → Kellner [2.9%] |
| 239 | Alignment, Calibration, Diagnostics, Metrology and Monitoring |  |  |  |  | constraint start no earlier than 2007-03-05 → finish no earlier than 2007-06-29; resources none → Neyman [4.4%]; Flicker [4.4%] |
| 244 | RTC Architecture Analysis and Design Study |  |  |  |  | resources Gavel [19.5%]; Johansson [15.6%]; Other [13.7%] → Gavel [19.5%]; Johansson [15.6%]; Flicker [13.7%] |
| 251 | **Laser Launch Facility** | 2007-01-30 → 2007-02-05 (+6d) |  | 87d? → 83d? |  |  |
| 252 | Laser Beam Transport |  |  |  |  | constraint finish no earlier than 2007-04-27 → start no earlier than 2007-02-05; resources none → Neyman [7.3%]; Kellner [4.2%]; Chin [1%] |
| 253 | Laser Pointing & Diagnostics |  |  |  |  | constraint finish no earlier than 2007-05-30 → start no earlier than 2007-04-02; resources none → Neyman [20.3%]; Kellner [20.3%]; Chin [5.8%] |
| 254 | Laser Launch Telescope | 2007-01-30 → 2007-02-05 (+6d) |  | 65d? → 61d? |  | constraint finish no earlier than 2007-04-30 → start no earlier than 2007-02-05; resources none → Neyman [16.4%]; Kellner [16.4%]; Chin [8.2%] |
| 256 | Personnel and Equipment Safety Systems |  |  |  |  | resources none → Chin [12.5%] |
| 257 | Aircraft, Satellite & Laser Traffic Control Safety Systems |  |  |  |  | was named Aircraft and Satellite Safety Systems; resources none → Chin [12.5%] |
| 258 | **Laser System Control** | 2007-02-01 → 2007-02-05 (+4d) |  | 85d? → 83d? |  |  |
| 259 | Laser System Software | 2007-02-01 → 2007-02-05 (+4d) |  | 85d? → 83d? |  | constraint finish no earlier than 2007-05-30 → start no earlier than 2007-02-05; resources none → Johansson [6%]; Stomski [6%] |
| 260 | Laser System Electronics | 2007-02-01 → 2007-02-05 (+4d) |  | 85d? → 83d? |  | constraint finish no earlier than 2007-05-30 → start no earlier than 2007-02-05; resources none → Chin [10.5%] |
| 261 | **Science Operations** | 2006-10-02 → 2007-01-02 (+92d) | 2007-05-30 → 2007-08-03 (+65d) | 173d? → 154d? | 178d → 131d |  |
| 298 | Deployable Near-IR IFU |  |  |  |  | resources Adkins [7.9%]; Other [51.6%] → Adkins [7.9%]; Other [35.7%]; Neyman [15.9%] |

## Version 3 (saved 2006-09-26, file NGAO_SD_schedule_v11.mpp)

Last finish stays 2008-04-04.

Added:

| ID | Task | Duration | Start | Finish | Constraint | Resources |
| --- | --- | --- | --- | --- | --- | --- |
| 118 | Development Requirements | 20d? | 2006-10-02 | 2006-10-27 | finish no earlier than 2006-10-27 | Neyman [5%] |
| 119 | Observatory Interface Requirements | 20d? | 2006-10-02 | 2006-10-27 | finish no earlier than 2006-10-27 | Neyman [10%] |
| 120 | Science Operations Requirements | 20d? | 2006-10-02 | 2006-10-27 | finish no earlier than 2006-10-27 | Le Mignant [10%] |
| 220 | Technical Risk Analysis Version 1 | 23d? | 2007-03-19 | 2007-04-18 | start no earlier than 2007-03-19 | Neyman [13%]; Gavel [8.7%] |

Removed: 118 Revision 1

Changed:

| ID | Task | Start | Finish | Duration | Total float | Predecessors | Other |
| --- | --- | --- | --- | --- | --- | --- | --- |
| 43 | **System Design Report & Review** | 2007-01-16 → 2007-11-15 (+303d) | 2008-02-29 → 2008-03-07 (+7d) | 294d? → 82d? | 25d → 20d |  |  |
| 44 | System Design Report | 2008-01-02 → 2008-01-28 (+26d) | 2008-01-11 → 2008-02-06 (+26d) |  | 60d → 20d | none → 324, 303, 134 |  |
| 45 | **System Design Review Activities** | 2007-01-16 → 2007-11-15 (+303d) | 2008-02-29 → 2008-03-07 (+7d) | 294d? → 82d? | 25d → 20d |  |  |
| 47 | Review Package Distributed | 2008-02-19 → 2008-02-06 (-13d) | 2008-02-19 → 2008-02-06 (-13d) |  | 25d → 20d | 324, 303, 134 → 44 |  |
| 48 | Reviewer Comments Received & Addressed | 2008-02-20 → 2008-02-27 (+7d) | 2008-02-26 → 2008-03-04 (+7d) |  | 25d → 20d | 47 → 47FS+14d |  |
| 49 | System Design Review Prep & Attendance | 2007-01-16 → 2008-02-07 (+387d) | 2007-02-06 → 2008-02-28 (+387d) |  | 300d → 23d | none → 44 |  |
| 50 | System Design Review Meeting | 2008-02-26 → 2008-03-04 (+7d) | 2008-02-26 → 2008-03-04 (+7d) |  | 25d → 20d |  |  |
| 51 | Reviewer Report Received | 2008-02-26 → 2008-03-04 (+7d) | 2008-02-26 → 2008-03-04 (+7d) |  | 25d → 20d |  |  |
| 52 | Response to Reviewer Report & Distribution | 2008-02-27 → 2008-03-05 (+7d) | 2008-02-29 → 2008-03-07 (+7d) |  | 25d → 20d |  |  |
| 101 | Encircled Energy (& d-IFU) Performance Requirements |  |  |  |  |  | was named Encircled Energy Performance Requirements |
| 117 | **Observatory Requirements** | 2006-09-12 → 2006-10-02 (+20d) |  | 338.12d? → 325d? |  |  |  |
| 121 | Revision 2 | 2007-02-19 → 2007-02-12 (-7d) |  | 10d? → 15d? |  |  | constraint start no earlier than 2007-02-19 → start no earlier than 2007-02-12; resources Neyman [25%] → Neyman [20%]; Other [41.7%]; Le Mignant [13.3%] |
| 122 | Revision 3 | 2007-06-04 → 2007-05-14 (-21d) |  | 15d? → 30d? |  |  |  |
| 131 | Revision 1 Release |  |  |  |  | 113, 126, Revision 1 → 113, 126, 118, 119, 120 |  |
| 135 | **System Design** | 2005-11-16 → 2006-08-14 (+271d) | 2008-02-19 → 2008-01-25 (-25d) | 590d? → 380d? | 33d → 50d |  |  |
| 136 | **Systems Engineering** | 2005-11-16 → 2006-08-14 (+271d) | 2007-12-31 → 2007-12-14 (-17d) | 554d? → 350d? | 69d → 80d |  |  |
| 137 | **Performance Budgets** | 2006-08-01 → 2006-08-14 (+13d) | 2007-06-29 → 2007-09-25 (+88d) | 239d? → 292d? | 200d → 138d |  |  |
| 155 | **Wavefront Error vs Sky Coverage** | 2006-08-01 → 2006-10-02 (+62d) |  | 131d? → 87d? |  |  |  |
| 156 | Document & release version 1 | 2006-08-01 → 2006-10-02 (+62d) | 2006-09-01 → 2006-11-02 (+62d) |  | 415d → 371d |  | constraint finish no earlier than 2006-09-01 → start no earlier than 2006-10-02 |
| 163 | Observing Efficiency |  |  |  |  |  | resources none → Le Mignant [8.3%]; Other [58.3%] |
| 168 | **Science Products** | 2007-02-12 → 2007-07-16 (+154d) | 2007-03-02 → 2007-09-25 (+207d) | 15d? → 52d? | 285d → 138d |  |  |
| 169 | All-In Science Simulations | 2007-02-12 → 2007-07-16 (+154d) | 2007-03-02 → 2007-08-10 (+161d) | 15d? → 20d? | 285d → 170d | 166 → 167 | constraint none → start no earlier than 2007-07-16; resources Neyman [66.7%]; Flicker [66.7%] → Neyman [50%]; Flicker [50%] |
| 170 | **Additional Science Characterization Results** | 2007-02-12 → 2007-08-13 (+182d) | 2007-03-02 → 2007-09-25 (+207d) | 15d? → 32d? | 285d → 138d | 166 → none |  |
| 171 | Point Source Sensitivities | 2007-02-12 → 2007-08-13 (+182d) | 2007-03-02 → 2007-08-31 (+182d) |  | 285d → 155d | none → 169 | constraint start no earlier than 2007-01-08 → start no earlier than 2007-04-02 |
| 172 | PSF Uniformity & Stability | 2007-02-12 → 2007-08-13 (+182d) | 2007-03-02 → 2007-08-31 (+182d) |  | 285d → 155d | none → 169 | constraint finish no earlier than 2007-01-26 → start no earlier than 2007-04-02 |
| 173 | Other | 2007-02-12 → 2007-09-05 (+205d) | 2007-02-12 → 2007-09-25 (+225d) | 1d? → 15d? | 299d → 138d | none → 169 | constraint none → start no earlier than 2007-09-05 |
| 174 | **Trade Studies** | 2005-11-16 → 2006-10-16 (+334d) |  | 398d? → 160d? | 225d → 133d |  |  |
| 175 | **System Architecture Trade Studies** | 2005-11-16 → 2006-10-16 (+334d) |  | 338d? → 100d? |  |  |  |
| 185 | Observing Model TS | 2005-11-16 → 2006-11-13 (+362d) | 2005-11-16 → 2007-01-12 (+422d) | 1d? → 45d? | 622d → 320d |  | constraint none → finish no earlier than 2007-01-12; resources none → Le Mignant [22.2%] |
| 201 | Focus Compensation TS (m6) | 2007-01-02 → 2007-01-22 (+20d) | 2007-04-13 → 2007-05-03 (+20d) |  | 255d → 241d |  | constraint start no earlier than 2007-01-02 → start no earlier than 2007-01-22 |
| 207 | **System Architecture** |  | 2007-12-31 → 2007-12-14 (-17d) | 304d? → 293d? | 69d → 80d |  |  |
| 219 | Technology Drivers Summary | 2007-06-14 → 2007-12-03 (+172d) | 2007-12-31 → 2007-12-06 (-25d) | 21d? → 3.63d? | 25d → 42.37d |  | constraint finish no earlier than 2007-12-31 → start no earlier than 2007-12-03; resources Neyman [14.3%]; Gavel [9.5%] → Neyman [82.7%]; Gavel [55.1%] |
| 221 | Technical Risk Analysis Version 2 | 2007-06-01 → 2007-11-12 (+164d) |  |  |  |  | was named Technical Risk Analysis; constraint start no earlier than 2007-06-01 → start no earlier than 2007-11-12; resources Neyman [30%]; Gavel [10%] → Neyman [12%]; Gavel [8%] |
| 222 | **AO System** |  | 2007-11-02 → 2007-12-12 (+40d) | 219d? → 247d? | 66d → 38d |  |  |
| 223 | AO System Architecture |  |  |  |  |  | resources Neyman [67.7%]; Other [67.7%] → Neyman [33.3%]; Other [35.4%] |
| 225 | **Opto-mechanical** |  | 2007-11-02 → 2007-12-12 (+40d) | 175d? → 203d? | 66d → 38d |  |  |
| 229 | Optical Support Structure |  |  |  |  |  | resources Meguro [3.4%]; Bauman [1.1%] → Meguro [9.1%]; Bauman [4.5%] |
| 230 | **Wavefront Sensors** |  | 2007-11-02 → 2007-12-12 (+40d) | 145d? → 173d? | 66d → 38d |  |  |
| 231 | High Order LGS Wavefront Sensors |  | 2007-06-15 → 2007-12-12 (+180d) | 45d? → 173d? | 166d → 38d |  | resources Velur [8.3%]; Meguro [2.8%] → Velur [4.3%]; Meguro [1.4%] |
| 232 | High Order NGS Wavefront Sensor |  | 2007-06-15 → 2007-12-12 (+180d) | 45d? → 173d? | 166d → 38d |  | resources Velur [4.2%]; Meguro [1.4%] → Velur [2.2%]; Meguro [0.7%] |
| 233 | Low Order NGS Wavefront Sensors |  | 2007-06-15 → 2007-12-12 (+180d) | 45d? → 173d? | 166d → 38d |  | constraint start no earlier than 2007-04-16 → finish no earlier than 2007-12-12; resources Kellner [5.6%]; Meguro [5.6%] → Kellner [2.9%]; Meguro [2.9%] |
| 234 | Calibration Wavefront Sensor |  | 2007-11-02 → 2007-12-12 (+40d) | 115d? → 143d? | 66d → 38d |  | resources Kellner [2.2%] → Kellner [3.5%] |
| 237 | Deformable Mirror |  |  |  |  |  | resources Flicker [2.9%] → Flicker [5.9%]; Bauman [11.8%] |
| 303 | System Design Manual | 2008-01-01 → 2007-12-17 (-15d) | 2008-02-19 → 2008-01-25 (-25d) | 35d? → 29d? | 25d → 20d |  | resources Wizinowich [14.3%]; Dekany [7.1%]; Gavel [7.1%] → Wizinowich [17.2%]; Dekany [8.6%]; Gavel [8.6%] |
| 307 | Cost Estimation | 2007-10-23 → 2007-10-22 (-1d) |  | 9d? → 10d? |  |  | resources Wizinowich [92.6%]; Dekany [92.6%]; Gavel [92.6%] → Wizinowich [62.5%]; Dekany [62.5%]; Gavel [62.5%]; Other [62.5%] |

## Version 4 (saved 2006-09-27, file NGAO_SD_schedule_v12.mpp)

Last finish stays 2008-04-04.

Changed:

| ID | Task | Start | Finish | Duration | Total float | Predecessors | Other |
| --- | --- | --- | --- | --- | --- | --- | --- |
| 43 | **System Design Report & Review** |  | 2008-03-07 → 2008-03-11 (+4d) | 82d? → 84d? | 20d → 18d |  |  |
| 44 | System Design Report | 2008-01-28 → 2008-01-21 (-7d) | 2008-02-06 → 2008-01-30 (-7d) |  | 20d → 18d |  |  |
| 45 | **System Design Review Activities** |  | 2008-03-07 → 2008-03-11 (+4d) | 82d? → 84d? | 20d → 18d |  |  |
| 47 | Review Package Distributed | 2008-02-06 → 2008-01-30 (-7d) | 2008-02-06 → 2008-01-30 (-7d) |  | 20d → 19d | 44 → 44, 46 |  |
| 48 | Reviewer Comments Received & Addressed | 2008-02-27 → 2008-02-14 (-13d) | 2008-03-04 → 2008-02-20 (-13d) |  | 20d → 19d | 47FS+14d → 47FS+10d |  |
| 49 | System Design Review Prep & Attendance | 2008-02-07 → 2008-01-31 (-7d) | 2008-02-28 → 2008-02-21 (-7d) |  | 23d → 18d |  |  |
| 50 | System Design Review Meeting | 2008-03-04 → 2008-02-21 (-12d) | 2008-03-04 → 2008-02-21 (-12d) |  | 20d → 18d |  |  |
| 51 | Reviewer Report Received | 2008-03-04 → 2008-03-06 (+2d) | 2008-03-04 → 2008-03-06 (+2d) |  | 20d → 18d | 50 → 50FS+10d |  |
| 52 | Response to Reviewer Report & Distribution | 2008-03-05 → 2008-03-07 (+2d) | 2008-03-07 → 2008-03-11 (+4d) |  | 20d → 18d |  |  |
| 53 | **System Requirements** | 2006-09-05 → 2006-09-18 (+13d) |  | 355d? → 346d? |  |  |  |
| 54 | **Science Requirements** | 2006-09-05 → 2006-09-18 (+13d) |  | 344d? → 335d? |  |  |  |
| 112 | **Science Requirements Summary** | 2006-09-05 → 2007-02-02 (+150d) |  | 344d? → 236d? |  |  |  |
| 113 | Revision 1 | 2006-09-05 → 2007-10-02 (+392d) | 2006-10-13 → 2007-10-19 (+371d) | 29d? → 14d? | 385d → 120d |  | constraint finish no earlier than 2006-10-13 → finish no earlier than 2007-10-19; resources none → Max [17.9%]; Wizinowich [17.9%] |
| 118 | Development Requirements |  |  |  |  |  | constraint finish no earlier than 2006-10-27 → start no earlier than 2006-10-02; resources Neyman [5%] → Neyman [2.5%]; Wizinowich [2.5%] |
| 119 | Observatory Interface Requirements |  |  |  |  |  | constraint finish no earlier than 2006-10-27 → start no earlier than 2006-10-02; resources Neyman [10%] → Neyman [5%]; Wizinowich [5%] |
| 120 | Science Operations Requirements |  |  |  |  |  | constraint finish no earlier than 2006-10-27 → start no earlier than 2006-10-02; resources Le Mignant [10%] → Le Mignant [5%]; Wizinowich [5%] |
| 127 | Revision 2 |  |  |  |  |  | resources Neyman [4.5%]; Wizinowich [2.2%]; Adkins [1.1%]; Flicker [3.4%] → Neyman [3.4%]; Wizinowich [3.4%]; Adkins [1.1%]; Flicker [3.4%] |
| 130 | **System Requirements Document** | 2006-10-27 → 2007-03-09 (+133d) |  | 316d → 222d |  |  |  |
| 131 | Revision 1 Release | 2006-10-27 → 2007-10-19 (+357d) | 2006-10-27 → 2007-10-19 (+357d) |  | 375d → 120d |  |  |
| 135 | **System Design** |  | 2008-01-25 → 2008-01-18 (-7d) | 380d? → 375d? | 50d → 55d |  |  |
| 160 | Astrometric Accuracy |  |  |  |  |  | resources Neyman [18.2%]; Britton [9.1%]; Flicker [9.1%]; Cameron [18.2%] → Neyman [9.1%]; Britton [13.6%]; Flicker [9.1%]; Cameron [13.6%]; Wizinowich [9.1%] |
| 222 | **AO System** | 2007-01-02 → 2007-02-05 (+34d) |  | 247d? → 223d? | 38d → 20d |  |  |
| 246 | **Real-time Control** | 2007-01-02 → 2007-02-05 (+34d) |  | 119d? → 95d? | 166d → 148d |  |  |
| 247 | RTC Architecture Analysis and Design Study | 2007-01-02 → 2007-02-05 (+34d) | 2007-03-30 → 2007-04-13 (+14d) | 64d? → 50d? | 221d → 193d |  | constraint finish no earlier than 2007-03-30 → start no earlier than 2007-02-05; resources Gavel [19.5%]; Johansson [15.6%]; Flicker [13.7%] → Gavel [25%]; Johansson [20%]; Flicker [17.5%] |
| 250 | **Laser Facility** | 2007-01-02 → 2007-02-12 (+41d) | 2007-08-03 → 2007-10-03 (+61d) | 154d? → 168d? | 131d → 70d |  |  |
| 251 | Laser System Architecture | 2007-01-02 → 2007-02-12 (+41d) |  | 85d? → 56d? | 200d → 182d |  | constraint start no earlier than 2007-01-02 → start no earlier than 2007-02-12 |
| 252 | Laser Enclosure | 2007-05-01 → 2007-08-06 (+97d) | 2007-06-28 → 2007-10-03 (+97d) |  | 157d → 70d |  | constraint start no earlier than 2007-05-01 → start no earlier than 2007-08-06 |
| 253 | Laser | 2007-01-15 → 2007-03-05 (+49d) | 2007-03-02 → 2007-04-20 (+49d) |  | 241d → 188d |  | constraint start no earlier than 2007-01-15 → start no earlier than 2007-03-05 |
| 254 | **Laser Launch Facility** | 2007-02-05 → 2007-04-02 (+56d) | 2007-05-30 → 2007-07-27 (+58d) | 83d? → 85d? | 178d → 118d |  |  |
| 255 | Laser Beam Transport | 2007-02-05 → 2007-04-02 (+56d) | 2007-04-27 → 2007-05-25 (+28d) | 60d? → 40d? | 201d → 163d |  | constraint start no earlier than 2007-02-05 → start no earlier than 2007-04-02; resources Neyman [7.3%]; Kellner [4.2%]; Chin [1%] → Neyman [10.9%]; Kellner [6.2%]; Chin [1.6%] |
| 256 | Laser Pointing & Diagnostics | 2007-04-02 → 2007-06-04 (+63d) | 2007-05-30 → 2007-07-27 (+58d) | 43d? → 40d? | 178d → 118d |  | constraint start no earlier than 2007-04-02 → start no earlier than 2007-06-04; resources Neyman [20.3%]; Kellner [20.3%]; Chin [5.8%] → Neyman [21.9%]; Kellner [21.9%]; Chin [6.2%] |
| 257 | Laser Launch Telescope | 2007-02-05 → 2007-04-16 (+70d) | 2007-04-30 → 2007-06-15 (+46d) | 61d? → 45d? | 200d → 148d |  | constraint start no earlier than 2007-02-05 → start no earlier than 2007-04-16; resources Neyman [16.4%]; Kellner [16.4%]; Chin [8.2%] → Neyman [22.2%]; Kellner [22.2%]; Chin [11.1%] |
| 261 | **Laser System Control** | 2007-02-05 → 2007-04-09 (+63d) | 2007-05-30 → 2007-08-03 (+65d) | 83d? → 85d? | 178d → 113d |  |  |
| 262 | Laser System Software | 2007-02-05 → 2007-04-09 (+63d) | 2007-05-30 → 2007-08-03 (+65d) | 83d? → 85d? | 178d → 113d |  | constraint start no earlier than 2007-02-05 → start no earlier than 2007-04-09; resources Johansson [6%]; Stomski [6%] → Johansson [5.9%]; Stomski [5.9%] |
| 263 | Laser System Electronics | 2007-02-05 → 2007-04-09 (+63d) | 2007-05-30 → 2007-08-03 (+65d) | 83d? → 85d? | 178d → 113d |  | constraint start no earlier than 2007-02-05 → start no earlier than 2007-04-09; resources Chin [10.5%] → Chin [10.3%] |
| 303 | System Design Manual |  | 2008-01-25 → 2008-01-18 (-7d) | 29d? → 24d? | 20d → 18d |  | constraint finish no earlier than 2007-11-16 → finish no earlier than 2008-01-18; resources Wizinowich [17.2%]; Dekany [8.6%]; Gavel [8.6%] → Wizinowich [20.8%]; Dekany [10.4%]; Gavel [10.4%] |

## Version 5 (saved 2006-09-27, file NGAO_SD_schedule_v13.mpp)

Last finish 2008-04-04 → 2008-05-20 (+46d).

Changed:

| ID | Task | Start | Finish | Duration | Total float | Predecessors | Other |
| --- | --- | --- | --- | --- | --- | --- | --- |
| 1 | **SD Phase Management** |  | 2008-04-04 → 2008-05-20 (+46d) | 468d? → 500d? |  |  |  |
| 2 | **Planning and Contracting** |  | 2007-03-16 → 2007-09-14 (+182d) | 193d? → 323d? | 275d → 177d |  |  |
| 10 | FY08 Replan | 2006-09-05 → 2007-09-05 (+365d) | 2006-09-15 → 2007-09-14 (+364d) |  | 405.2d → 177d |  | constraint start no earlier than 2006-09-05 → start no earlier than 2007-09-05 |
| 11 | **Project Meetings** | 2006-09-14 → 2006-06-21 (-85d) | 2008-04-04 → 2008-05-20 (+46d) | 407d? → 500d? |  |  |  |
| 12 | Executive Committee Telecons | 2007-10-29 → 2006-06-21 (-495d) | 2008-03-28 → 2008-05-20 (+53d) | 109.5d? → 500d | 5d → 0d |  | constraint finish no earlier than 2008-03-28 → none; resources Wizinowich [8.6%]; Dekany [8.6%]; Gavel [8.6%]; Max [8.6%] → Wizinowich [2.5%]; Dekany [2.5%]; Gavel [2.5%]; Max [2.5%] |
| 15 | Team Meeting #1 (mgmt, science & technical - Irvine) |  |  |  | 406d → 438d |  | was named Team Meeting (mgmt, science & technical - Irvine); resources Wizinowich [125%]; Dekany [125%]; Gavel [125%]; Max [125%] → Wizinowich; Dekany; Gavel; Max; Bauman; Bouchez; Velur; Flicker; Neyman; Britton; Le Mignant |
| 16 | Team Meeting #2 (CIT) |  |  |  | 368d → 400d |  | was named Team Meeting (CIT); resources Wizinowich [125%]; Dekany [125%]; Gavel [125%]; Max [125%] → Wizinowich; Dekany; Gavel; Max; Bauman; Bouchez; Velur; Flicker; Neyman; Britton; Le Mignant |
| 17 | Team Videocon #3 |  |  | 0.5d → 1d | 342.5d → 374d |  | was named Team Videocon; resources Wizinowich [62.5%]; Dekany [62.5%]; Gavel [62.5%]; Max [62.5%] → Wizinowich; Dekany; Gavel; Max; Bauman; Bouchez; Velur; Flicker; Neyman; Britton; Le Mignant |
| 18 | Team Meeting #4 (Keck) |  |  |  | 314d → 346d |  | was named Team Meeting (Keck); resources Wizinowich [125%]; Dekany [125%]; Gavel [125%]; Max [125%] → Wizinowich; Dekany; Gavel; Max; Bauman; Bouchez; Velur; Flicker; Neyman; Britton; Le Mignant |
| 19 | Team Videocon #5 |  |  | 0.5d → 1d | 282.5d → 314d |  | was named Team Videocon; resources Wizinowich [62.5%]; Dekany [62.5%]; Gavel [62.5%]; Max [62.5%] → Wizinowich; Dekany; Gavel; Max; Bauman; Bouchez; Velur; Flicker; Neyman; Britton; Le Mignant |
| 20 | Team Meeting #6 (UCSC) |  |  |  | 252d → 284d |  | was named Team Meeting; resources Wizinowich [31.2%]; Dekany [31.2%]; Gavel [31.2%]; Max [31.2%] → Wizinowich; Dekany; Gavel; Max; Bauman; Bouchez; Velur; Flicker; Neyman; Britton; Le Mignant |
| 21 | Team Videocon #7 |  |  | 0.5d → 1d | 222d → 254d |  | was named Team Videocon; resources Wizinowich [62.5%]; Dekany [62.5%]; Gavel [62.5%]; Max [62.5%] → Wizinowich; Dekany; Gavel; Max; Bauman; Bouchez; Velur; Flicker; Neyman; Britton; Le Mignant |
| 22 | Team Retreat #8 (UCSC) |  |  |  | 190d → 222d |  | was named Team Retreat (UCSC); resources Wizinowich [87.5%]; Dekany [87.5%]; Gavel [87.5%]; Max [87.5%] → Wizinowich; Dekany; Gavel; Max; Bauman; Bouchez; Velur; Flicker; Neyman; Britton; Le Mignant |
| 23 | Team Videocon #9 |  |  | 0.5d → 1d | 162.5d → 194d |  | was named Team Videocon; resources Wizinowich [62.5%]; Dekany [62.5%]; Gavel [62.5%]; Max [62.5%] → Wizinowich; Dekany; Gavel; Max; Bauman; Bouchez; Velur; Flicker; Neyman; Britton; Le Mignant |
| 24 | Team Meeting #10 (CIT) |  |  |  | 148d → 180d |  | was named Team Meeting (CIT); resources Wizinowich [125%]; Dekany [125%]; Gavel [125%]; Max [125%] → Wizinowich; Dekany; Gavel; Max; Bauman; Bouchez; Velur; Flicker; Neyman; Britton; Le Mignant |
| 25 | Team Videocon #11 |  |  | 0.5d → 1d | 109.5d → 141d |  | was named Team Videocon; resources Wizinowich [62.5%]; Dekany [62.5%]; Gavel [62.5%]; Max [62.5%] → Wizinowich; Dekany; Gavel; Max; Bauman; Bouchez; Velur; Flicker; Neyman; Britton; Le Mignant |
| 26 | Team Meeting #12 (Keck) |  | 2007-12-14 → 2007-12-12 (-2d) | 3d → 1d | 80d → 114d |  | was named Team Meeting (Keck); resources Wizinowich [62.5%]; Dekany [62.5%]; Gavel [62.5%]; Max [62.5%] → Wizinowich; Dekany; Gavel; Max; Bauman; Bouchez; Velur; Flicker; Neyman; Britton; Le Mignant |
| 27 | Team Videocon #13 |  |  | 0.5d → 1d | 62.5d → 94d |  | was named Team Videocon; resources Wizinowich [62.5%]; Dekany [62.5%]; Gavel [62.5%]; Max [62.5%] → Wizinowich; Dekany; Gavel; Max; Bauman; Bouchez; Velur; Flicker; Neyman; Britton; Le Mignant |
| 28 | Team Meeting #14 (Keck) - SDR |  |  |  | 0d → 32d | 39 → none | was named Team Meeting (CA); resources Wizinowich [31.2%]; Dekany [31.2%]; Gavel [31.2%]; Max [31.2%] → Wizinowich; Dekany; Gavel; Max; Bauman; Bouchez; Velur; Flicker; Neyman; Britton; Le Mignant |
| 29 | **Tracking and Reporting** | 2006-09-29 → 2006-09-16 (-13d) |  | 394d? → 404d? | 1d → 33d |  |  |
| 30 | Report Preparation/Presentation |  | 2007-05-16 → 2007-12-12 (+210d) | 162.5d? → 312.5d? | 232.5d → 114.5d |  | resources Wizinowich [3.8%]; Dekany [35%]; Gavel [35%]; Max [35%] → Wizinowich [2%]; Dekany [2%]; Gavel [2%]; Max [2%] |
| 31 | Keck Science Meeting 06 (UCI) | 2006-09-29 → 2006-09-16 (-13d) | 2006-09-29 → 2006-09-16 (-13d) |  | 395d → 437d | 5 → none |  |
| 40 | **Proposals and Fundraising** | 2006-10-02 → 2006-10-27 (+25d) |  | 326d? → 306d? | 69d → 101d |  | was named Proposal & Fundraising Activities |
| 41 | Dates & deliverables identified by Directors | 2006-10-02 → 2006-10-27 (+25d) | 2006-10-02 → 2006-10-27 (+25d) |  | 134d → 146d | none → 7FS+3w | constraint start no earlier than 2006-10-02 → none |
| 42 | Support Advancement Office |  |  |  | 69d → 101d |  | was named Activities |
| 43 | **System Design Report & Review** | 2007-11-15 → 2007-09-17 (-59d) | 2008-03-11 → 2008-04-01 (+21d) | 84d? → 142d? | 18d → 35d |  |  |
| 44 | System Design Report | 2008-01-21 → 2008-02-11 (+21d) | 2008-01-30 → 2008-02-20 (+21d) |  | 18d → 35d |  | constraint start no earlier than 2008-01-02 → none |
| 45 | **System Design Review** | 2007-11-15 → 2007-09-17 (-59d) | 2008-03-11 → 2008-04-01 (+21d) | 84d? → 142d? | 18d → 35d |  | was named System Design Review Activities |
| 46 | Identify Reviewers | 2007-11-15 → 2007-09-17 (-59d) |  | 22d? → 65d? | 52d → 83d |  | was named Reviewers Identified; constraint start no earlier than 2007-11-15 → start no earlier than 2007-09-17; resources Adkins [5.7%]; Wizinowich [1.1%]; Max [0.6%]; Gavel [0.6%]; Dekany [0.6%] → Adkins [1.9%]; Wizinowich [0.4%]; Max [0.2%]; Gavel [0.2%]; Dekany [0.2%] |
| 47 | Review Package Distributed | 2008-01-30 → 2008-02-21 (+22d) | 2008-01-30 → 2008-02-21 (+22d) | 0d → 1d | 19d → 35d |  | resources none → Adkins |
| 48 | Reviewer Comments Addressed | 2008-02-14 → 2008-03-07 (+22d) | 2008-02-20 → 2008-03-13 (+22d) |  | 19d → 35d |  | was named Reviewer Comments Received & Addressed |
| 49 | System Design Review Prep | 2008-01-31 → 2008-02-21 (+21d) | 2008-02-21 → 2008-03-04 (+12d) | 16d? → 8.41d? | 18d → 42.59d |  | was named System Design Review Prep & Attendance; resources Wizinowich [48.8%]; Dekany [48.8%]; Gavel [48.8%]; Max [48.8%]; Adkins [6.2%] → Wizinowich [34%]; Dekany [35%]; Gavel [35%]; Max [35%]; Bauman [35%]; Bouchez [12.5%]; Velur [60%]; Flicker; Neyman [83%]; Britton [40%]; Le Mignant [10%] |
| 50 | System Design Review Meeting | 2008-02-21 → 2008-03-13 (+21d) | 2008-02-21 → 2008-03-13 (+21d) |  | 18d → 35d |  |  |
| 51 | Reviewer Report Received | 2008-03-06 → 2008-03-27 (+21d) | 2008-03-06 → 2008-03-27 (+21d) |  | 18d → 35d |  |  |
| 52 | Response to Reviewer Report & Distribution | 2008-03-07 → 2008-03-28 (+21d) | 2008-03-11 → 2008-04-01 (+21d) |  | 18d → 35d |  |  |
| 53 | **System Requirements** |  | 2008-01-15 → 2007-11-16 (-60d) | 346d? → 305d? | 59d → 105d |  |  |
| 54 | **Science Requirements** |  | 2007-12-28 → 2007-10-15 (-74d) | 335d? → 281d? | 70d → 156d |  |  |
| 55 | **Solar System Science Requirements** |  |  |  | 260d → 292d |  | was named Solar System |
| 70 | **Galactic Science Requirements** |  |  |  | 260d → 292d |  | was named Galactic |
| 95 | **Extragalactic Science Requirements** |  |  |  | 245d → 277d |  | was named Extragalactic |
| 112 | **Science Requirements Summary** | 2007-02-02 → 2006-10-02 (-123d) | 2007-12-28 → 2007-10-15 (-74d) | 236d? → 271d? | 70d → 146d |  |  |
| 113 | Science Requirements Summary Rev 1 | 2007-10-02 → 2006-10-02 (-365d) | 2007-10-19 → 2006-10-19 (-365d) |  | 120d → 403d |  | was named Revision 1; constraint finish no earlier than 2007-10-19 → finish no earlier than 2006-10-19 |
| 114 | Science Requirements Summary Rev 2 | 2007-02-02 → 2007-02-13 (+11d) |  | 21d? → 13.89d? | 285d → 307d |  | was named Revision 2; resources none → Max [18%]; Wizinowich [18%]; Other |
| 115 | Science Requirements Summary Rev 3 | 2007-06-04 → 2007-06-05 (+1d) |  | 15d? → 13.89d? | 205d → 227d |  | was named Revision 3; resources none → Max [18%]; Wizinowich [18%] |
| 116 | Science Requirements Summary Final | 2007-12-03 → 2007-09-26 (-68d) | 2007-12-28 → 2007-10-15 (-74d) | 20d? → 13.89d? | 33d → 109d |  | was named Final SD Version; constraint finish no earlier than 2007-12-28 → finish no earlier than 2007-10-15; resources none → Max [18%]; Wizinowich [18%] |
| 117 | **Observatory Requirements** |  | 2007-12-28 → 2007-11-02 (-56d) | 325d? → 285d? | 70d → 95d |  |  |
| 118 | Development Requirements |  | 2006-10-27 → 2006-11-24 (+28d) | 20d? → 40d? | 375d → 135d |  |  |
| 119 | Observatory Interface Requirements |  |  |  | 375d → 155d |  | resources Neyman [5%]; Wizinowich [5%] → Neyman [5%]; Wizinowich [5%]; Adkins [5%] |
| 120 | Science Operations Requirements |  | 2006-10-27 → 2007-01-19 (+84d) | 20d? → 80d? | 375d → 95d |  | resources Le Mignant [5%]; Wizinowich [5%] → Le Mignant [5%]; Wizinowich [5%]; Bouchez [5%] |
| 121 | Observatory Requirements Rev 2 | 2007-02-12 → 2007-03-19 (+35d) | 2007-03-02 → 2007-04-06 (+35d) |  | 285d → 95d | none → 118FS+8w, 119FS+8w, 120FS+8w | was named Revision 2; constraint start no earlier than 2007-02-12 → none |
| 122 | Observatory Requirements Rev 3 | 2007-05-14 → 2007-06-04 (+21d) | 2007-06-22 → 2007-07-13 (+21d) |  | 205d → 95d | none → 121FS+8w | was named Revision 3; constraint finish no earlier than 2007-06-22 → none |
| 123 | Observatory Requirements Rev 4 | 2007-12-03 → 2007-09-10 (-84d) | 2007-12-28 → 2007-11-02 (-56d) | 20d? → 40d? | 33d → 95d | none → 122FS+8w | was named Revision 4; constraint finish no earlier than 2007-12-28 → none |
| 124 | **System Requirements Document** |  | 2008-01-15 → 2007-11-16 (-60d) | 331d? → 290d? | 59d → 132d |  |  |
| 125 | **Tracability Matrix** |  | 2008-01-14 → 2007-10-20 (-86d) | 331d? → 270d? | 59d → 142d |  | was named Technical Requirements Flow Down |
| 126 | Tracability Matrix Rev 1 |  |  |  | 380d → 402d |  | was named Revision 1 |
| 127 | Tracability Matrix Rev 2 | 2006-11-01 → 2007-02-12 (+103d) | 2007-03-05 → 2007-02-27 (-6d) | 89d? → 12d? | 284d → 310d |  | was named Revision 2; constraint start no earlier than 2006-11-01 → start no earlier than 2007-02-12; resources Neyman [3.4%]; Wizinowich [3.4%]; Adkins [1.1%]; Flicker [3.4%] → Neyman [25%]; Wizinowich [25%]; Adkins [25%]; Flicker [25%] |
| 128 | Tracability Matrix Rev 3 |  |  |  | 201d → 223d |  | was named Revision 3 |
| 129 | Tracability Matrix Rev 4 | 2008-01-02 → 2007-10-09 (-85d) | 2008-01-14 → 2007-10-20 (-86d) |  | 22d → 105d |  | was named Revision 4; constraint finish no earlier than 2008-01-14 → finish no earlier than 2007-10-20 |
| 130 | **System Requirements Document** | 2007-03-09 → 2007-01-22 (-46d) | 2008-01-15 → 2007-11-16 (-60d) | 222d → 215d | 59d → 132d |  |  |
| 131 | SRD Rev 1 | 2007-10-19 → 2007-01-22 (-270d) | 2007-10-19 → 2007-02-02 (-259d) | 0d → 10d | 120d → 337d |  | was named Revision 1 Release; resources none → Neyman [25%] |
| 132 | SRD Rev 2 | 2007-03-09 → 2007-04-09 (+31d) | 2007-03-09 → 2007-04-20 (+42d) | 0d → 10d | 281d → 282d |  | was named Revision 2 Release; resources none → Neyman [25%] |
| 133 | SRD Rev 3 | 2007-06-29 → 2007-07-16 (+17d) | 2007-06-29 → 2007-07-27 (+28d) | 0d → 10d | 201d → 212d |  | was named Revision 3 Release; resources none → Neyman [25%] |
| 134 | SRD Final SD Phase Version | 2008-01-15 → 2007-11-05 (-71d) | 2008-01-15 → 2007-11-16 (-60d) | 0d → 10d | 22d → 95d |  | was named Final SD Version Release; constraint start no earlier than 2008-01-15 → none; resources none → Neyman [25%] |
| 135 | **System Design** |  | 2008-01-18 → 2008-02-08 (+21d) | 375d? → 390d? | 55d → 72d |  |  |
| 136 | **Systems Engineering** |  | 2007-12-14 → 2008-01-04 (+21d) | 350d? → 365d? | 80d → 97d |  |  |
| 151 | Throughput | 2006-10-02 → 2006-09-11 (-21d) |  | 65d? → 80d? | 330d → 205d |  | resources Bouchez [7.7%] → Bouchez [5%] |
| 152 | **Background** |  | 2006-12-29 → 2007-01-09 (+11d) | 65d? → 71.5d? | 330d → 198.5d |  |  |
| 154 | Develop Background Performance Budget |  | 2006-12-29 → 2007-01-09 (+11d) | 56d? → 62.5d? | 330d → 198.5d |  | resources Bouchez [17.9%] → Bouchez [8%] |
| 156 | Document WFE Budget Rev 1 |  | 2006-11-02 → 2006-12-08 (+36d) | 24d? → 50d? | 371d → 214d |  | was named Document & release version 1; resources Dekany [20.8%] → Dekany [10%] |
| 157 | Document WFE Budget Rev 2 | 2007-01-01 → 2006-12-27 (-5d) |  | 22d? → 25d? | 308d → 177d |  | was named Develop version 2, document & release; resources Dekany [22.7%]; Flicker [17%] → Dekany [20%]; Flicker [17%] |

| ID | Task | Start | Finish | Duration | Total float | Predecessors | Other |
| --- | --- | --- | --- | --- | --- | --- | --- |
| 165 | **Performance Budgets Summary** | 2007-01-15 → 2007-01-31 (+16d) | 2007-06-15 → 2007-04-20 (-56d) | 110d? → 58d? | 148d → 150d |  |  |
| 166 | Performance Budgets Summary Ver 1 | 2007-01-15 → 2007-01-31 (+16d) | 2007-02-09 → 2007-02-27 (+18d) |  | 238d → 177d | none → 155, 158, 159, 162 | was named Performance Budgets Version 1 |
| 167 | Performance Budgets Summary Ver 2 | 2007-05-14 → 2007-03-19 (-56d) | 2007-06-15 → 2007-04-20 (-56d) |  | 148d → 150d | none → 155, 158, 159, 160, 161, 162, 163, 164, 151, 152 | was named Performance Budgets Version 2; constraint start no earlier than 2007-05-14 → none |
| 171 | Point Source Sensitivities |  | 2007-08-31 → 2007-09-06 (+6d) | 15d? → 18.75d? | 155d → 183.25d |  | resources Bouchez [33.3%] → Bouchez [20%] |
| 178 | Adaptive Secondary Mirror option TS (m5) |  |  |  | 285d → 185d |  | resources Bouchez [15%]; Wizinowich [10%] → Other [15%]; Wizinowich [10%] |
| 179 | K & L-band Science TS (m5) |  |  |  | 285d → 185d |  | resources Bouchez [25%] → Other [25%] |
| 195 | LOWFS Architecture TS |  | 2007-01-19 → 2007-02-28 (+40d) | 35d? → 62.5d? | 80d → 84.5d |  | resources Kellner [71.4%] → Kellner [71.4%]; Velur [20%] |
| 196 | Number & Type of LOWFS TS (m4) |  | 2007-01-19 → 2007-01-26 (+7d) | 35d? → 40d? | 80d → 107d |  | resources Kellner [21.4%] → Kellner [21.4%]; Velur [9.4%] |
| 202 | **Laser Facility Trade Studies** | 2006-10-23 → 2006-10-16 (-7d) | 2007-05-25 → 2007-03-05 (-81d) | 155d? → 101d? | 225d → 161d |  |  |
| 203 | Laser Pulse Format TS (m6) |  | 2007-04-13 → 2007-01-29 (-74d) | 74d? → 20d? | 255d → 161d |  | resources Velur [16.9%] → Velur [50%] |
| 204 | Free Space vs Fiber TS (m7) | 2007-04-23 → 2007-01-30 (-83d) | 2007-05-25 → 2007-03-05 (-81d) |  | 225d → 161d | none → 203 | constraint start no earlier than 2007-04-23 → none |
| 206 | Variable vs fixed LGS Asterism Cost/Benefit TS (m2) | 2006-10-23 → 2006-10-16 (-7d) |  | 5d? → 10d? | 375d → 252d |  |  |
| 207 | **System Architecture** | 2006-11-01 → 2007-02-28 (+119d) | 2007-12-14 → 2008-01-04 (+21d) | 293d? → 223d? | 80d → 97d |  |  |
| 208 | System Architecture Ver 1 | 2006-11-01 → 2007-02-28 (+119d) | 2006-12-20 → 2007-04-18 (+119d) |  | 251d → 177d | none → 166 | was named System Architecture Version 1 |
| 209 | System Architecture Ver 2 | 2007-10-01 → 2007-05-28 (-126d) | 2007-10-26 → 2007-06-22 (-126d) |  | 115d → 125d | none → 167, 175, 186, 202 | was named System Architecture Version 2; constraint start no earlier than 2007-10-01 → none |
| 210 | **Functional Requirements** | 2007-01-02 → 2007-04-19 (+107d) |  | 244d? → 167d? | 23d → 55d |  |  |
| 211 | AO System Functional Requirements Ver 1 | 2007-01-10 → 2007-04-19 (+99d) | 2007-02-02 → 2007-05-14 (+101d) |  | 243d → 204.75d |  | was named AO System Functional Requirements Version 1 |
| 212 | AO System Functional Requirements Ver 2 |  |  |  | 28d → 35d | none → 209 | was named AO System Functional Requirements Version 2 |
| 213 | Laser System Functional Requirements Ver 1 | 2007-02-05 → 2007-04-19 (+73d) | 2007-03-02 → 2007-05-16 (+75d) |  | 223d → 202d |  | was named Laser System Functional Requirements Version 1 |
| 214 | Laser System Functional Requirements Ver 2 |  |  |  | 23d → 55d | none → 209 | was named Laser System Functional Requirements Version 2 |
| 215 | Science Operations Functional Requirements Ver 1 | 2007-01-02 → 2007-04-19 (+107d) | 2007-02-02 → 2007-05-22 (+109d) |  | 243d → 198d |  | was named Science Operations Functional Requirements Version 1 |
| 216 | Science Operations Functional Requirements Ver 2 |  |  |  | 28d → 60d | none → 209 | was named Science Operations Functional Requirements Version 2 |
| 217 | Science Instruments Functional Requirements Ver 1 | 2007-01-02 → 2007-04-19 (+107d) | 2007-02-02 → 2007-05-22 (+109d) |  | 243d → 198d | none → 208 | was named Science Instruments Functional Requirements Version 1 |
| 218 | Science Instruments Functional Requirements Ver 2 |  |  |  | 28d → 60d | none → 209 | was named Science Instruments Functional Requirements Version 2 |
| 219 | Technology Drivers Summary | 2007-12-03 → 2007-05-28 (-189d) | 2007-12-06 → 2007-05-31 (-189d) |  | 24.37d → 191.37d | none → 208, 167, 175, 186, 202 | constraint start no earlier than 2007-12-03 → none |
| 220 | Technical Risk Analysis Ver 1 | 2007-03-19 → 2007-05-31 (+73d) | 2007-04-18 → 2007-07-03 (+76d) |  | 252d → 230.37d | none → 219 | was named Technical Risk Analysis Version 1 |
| 221 | Technical Risk Analysis Ver 2 | 2007-11-12 → 2007-12-03 (+21d) | 2007-12-14 → 2008-01-04 (+21d) |  | 18d → 35d | none → 212 | was named Technical Risk Analysis Version 2; constraint start no earlier than 2007-11-12 → none |
| 223 | AO System Architecture | 2007-02-05 → 2007-04-19 (+73d) | 2007-04-27 → 2007-06-20 (+54d) | 60d? → 45d? | 183d → 177d | none → 208 |  |
| 224 | AO Enclosure | 2007-04-16 → 2007-05-14 (+28d) | 2007-07-20 → 2007-08-17 (+28d) |  | 123d → 135d | 187 → 227SS+4w | constraint start no earlier than 2007-01-22 → none |
| 226 | Field Rotation |  | 2007-06-29 → 2007-08-08 (+40d) | 55d? → 82.5d? | 83d → 101.25d |  |  |
| 227 | Optical Relay |  | 2007-06-29 → 2007-08-15 (+47d) | 55d? → 88d? | 83d → 95.75d |  | resources Bauman [5.7%]; Meguro [3.4%] → Bauman [5.7%]; Meguro [3.4%]; Dekany [2%] |
| 229 | Optical Support Structure | 2007-07-02 → 2007-08-16 (+45d) | 2007-09-14 → 2007-10-12 (+28d) | 55d? → 41.25d? | 83d → 95.75d |  |  |
| 237 | Deformable Mirror |  |  |  | 138d → 170d |  | resources Flicker [5.9%]; Bauman [11.8%] → Flicker [5.9%]; Bauman [11.8%]; Dekany [15%] |
| 238 | **Acquisition Cameras** |  | 2007-06-29 → 2007-08-24 (+56d) | 85d? → 125d? | 138d → 130d |  |  |
| 239 | NGS Acquisition Camera |  | 2007-06-29 → 2007-08-24 (+56d) | 85d? → 125d? | 138d → 130d |  | resources Bouchez [1.5%] → Bouchez [2%] |
| 240 | LGS Acquisition Camera |  | 2007-06-29 → 2007-08-24 (+56d) | 85d? → 125d? | 138d → 130d |  | resources Bouchez [1.5%] → Bouchez [2%] |
| 243 | **Non-real-time Control** |  | 2007-07-27 → 2007-10-22 (+87d) | 64d? → 125d? | 118d → 89d |  |  |
| 244 | Non-RTC Software | 2007-05-01 → 2007-05-17 (+16d) |  | 64d? → 51.2d? | 118d → 150d |  | was named Non-RTC Software Design |
| 245 | Non-RTC Electronics |  | 2007-07-27 → 2007-10-22 (+87d) | 64d? → 125d? | 118d → 89d |  | was named Non-RTC Electrical Design; resources Chin [24.4%]; Other [24.4%] → Chin [10%]; Other [10%] |
| 246 | **Real-time Control** |  | 2007-06-15 → 2007-07-06 (+21d) | 95d? → 109.52d? | 148d → 165.48d |  |  |
| 247 | RTC Architecture Analysis and Design Study |  | 2007-04-13 → 2007-04-04 (-9d) | 50d? → 42.86d? | 193d → 165.48d |  |  |
| 248 | RTC Software Module Definition | 2007-03-05 → 2007-04-04 (+30d) | 2007-06-15 → 2007-07-06 (+21d) | 75d? → 66.67d? | 148d → 165.48d | none → 247 | constraint finish no earlier than 2007-06-15 → none; resources none → Johansson [15%] |
| 249 | RTC Hardware Module Definition | 2007-03-05 → 2007-04-04 (+30d) | 2007-06-15 → 2007-07-06 (+21d) | 75d? → 66.67d? | 148d → 165.48d | none → 247 | constraint finish no earlier than 2007-06-15 → none; resources none → Johansson [15%] |
| 250 | **Laser Facility** | 2007-02-12 → 2007-03-06 (+22d) | 2007-10-03 → 2007-08-03 (-61d) | 168d? → 109d? | 70d → 145d |  |  |
| 251 | Laser System Architecture | 2007-02-12 → 2007-03-06 (+22d) | 2007-04-30 → 2007-05-14 (+14d) | 56d? → 50d? | 182d → 161d | none → 155, 158, 202 | constraint start no earlier than 2007-02-12 → none; resources none → Velur [20%] |
| 252 | Laser Enclosure | 2007-08-06 → 2007-05-15 (-83d) | 2007-10-03 → 2007-07-12 (-83d) |  | 70d → 161d | none → 251 | constraint start no earlier than 2007-08-06 → none |
| 253 | Laser | 2007-03-05 → 2007-05-15 (+71d) | 2007-04-20 → 2007-07-02 (+73d) |  | 188d → 169d | none → 251 |  |
| 254 | **Laser Launch Facility** | 2007-04-02 → 2007-03-06 (-27d) | 2007-07-27 → 2007-04-30 (-88d) | 85d? → 40d? | 118d → 214d |  |  |
| 255 | Laser Beam Transport | 2007-04-02 → 2007-03-06 (-27d) | 2007-05-25 → 2007-04-30 (-25d) |  | 163d → 214d | none → 203, 204 | constraint start no earlier than 2007-04-02 → none |
| 256 | Laser Pointing & Diagnostics | 2007-06-04 → 2007-03-06 (-90d) | 2007-07-27 → 2007-04-30 (-88d) |  | 118d → 214d | none → 203, 204 | constraint start no earlier than 2007-06-04 → none |
| 257 | Laser Launch Telescope | 2007-04-16 → 2007-03-06 (-41d) | 2007-06-15 → 2007-04-13 (-63d) | 45d? → 28.12d? | 148d → 225.88d | none → 205, 203, 204 | constraint start no earlier than 2007-04-16 → none |
| 294 | **Science Instruments** |  | 2007-05-30 → 2007-11-20 (+174d) | 173d? → 296.33d? | 160d → 68.67d |  |  |
| 295 | OSIRIS |  | 2007-01-30 → 2007-03-05 (+34d) | 43d? → 66.67d? | 246d → 254.33d |  | resources Adkins [4.7%]; Other [24.4%] → Adkins [3%]; Other [24.4%] |
| 297 | OHANA |  | 2007-02-28 → 2007-04-11 (+42d) | 20d? → 50d? | 225d → 227d |  | resources Adkins [5%]; Other [11.2%]; Woillez [15%] → Adkins [2%]; Other [11.2%]; Woillez [15%] |
| 298 | Near-IR Imager |  | 2007-01-30 → 2007-04-27 (+87d) | 87d? → 150d? | 246d → 215d |  | resources Adkins [4.3%]; Other [31.6%] → Adkins [2%]; Other [31.6%] |
| 299 | Visible Imager |  | 2007-01-30 → 2007-04-27 (+87d) | 87d? → 150d? | 246d → 215d |  | resources Adkins [4.3%]; Other [31.6%] → Adkins [2%]; Other [31.6%] |
| 300 | Visible IFU |  | 2007-03-30 → 2007-05-21 (+52d) | 64d? → 100d? | 203d → 199d |  | resources Adkins [3.1%]; Other [16.4%] → Adkins [2%]; Other [16.4%] |
| 301 | Deployable Near-IR IFU |  | 2007-04-30 → 2007-11-20 (+204d) | 63d? → 208.33d? | 182d → 68.67d |  | resources Adkins [7.9%]; Other [35.7%]; Neyman [15.9%] → Adkins [4%]; Other [35.7%]; Neyman [15.9%] |
| 302 | Mid-IR IFU |  | 2007-05-30 → 2007-09-17 (+110d) | 22d? → 100d? | 160d → 114d |  | resources Adkins [4.5%]; Other [23.9%] → Adkins [1%]; Other [23.9%] |
| 303 | System Design Manual | 2007-12-17 → 2008-01-07 (+21d) | 2008-01-18 → 2008-02-08 (+21d) |  | 18d → 35d |  |  |
| 322 | Configuration Management Plan |  | 2007-02-16 → 2007-04-11 (+54d) | 25d? → 62.5d? | 245d → 239.5d |  | resources Johnson [25%]; Other [10%]; Chin [5%] → Johnson [10%]; Other [10%]; Chin [5%] |

## Version 6 (saved 2006-09-28, file NGAO_SD_schedule_v15.mpp)

Last finish stays 2008-05-20.

Removed: 28 Team Meeting #14 (Keck) - SDR

Changed:

| ID | Task | Start | Finish | Duration | Total float | Predecessors | Other |
| --- | --- | --- | --- | --- | --- | --- | --- |
| 2 | **Planning and Contracting** |  | 2007-09-14 → 2007-11-16 (+63d) | 323d? → 367.76d? | 177d → 132.24d |  |  |
| 10 | FY08 Replan | 2007-09-05 → 2007-10-30 (+55d) | 2007-09-14 → 2007-11-16 (+63d) | 8d → 13.33d | 177d → 132.24d | none → 305 | constraint start no earlier than 2007-09-05 → none |
| 14 | **Team Meetings** |  | 2008-04-04 → 2008-01-09 (-86d) | 407d → 344.5d | 32d → 94.5d |  |  |
| 17 | Team Videocon #3 |  |  | 1d → 0.5d | 374d → 374.5d |  |  |
| 19 | Team Videocon #5 |  |  | 1d → 0.5d | 314d → 314.5d |  |  |
| 21 | Team Videocon #7 |  |  | 1d → 0.5d |  |  |  |
| 22 | Team Retreat #8 (UCSC) |  | 2007-07-13 → 2007-07-11 (-2d) | 5d → 2.5d | 222d → 78.67d |  |  |
| 23 | Team Videocon #9 |  |  | 1d → 0.5d | 194d → 194.5d |  |  |
| 25 | Team Videocon #11 |  |  | 1d → 0.5d | 141d → 141.5d |  |  |
| 27 | Team Videocon #13 |  |  | 1d → 0.5d | 94d → 94.5d |  |  |
| 39 | **Proposals & Fundraising** |  | 2007-12-31 → 2007-01-01 (-364d) | 306d? → 45d? | 101d → 362d |  | was named Proposals and Fundraising |
| 41 | Support Advancement Office |  | 2007-12-31 → 2007-01-01 (-364d) | 261d? → 0d? | 101d → 362d |  |  |
| 42 | **System Design Report & Review** |  | 2008-04-01 → 2008-04-21 (+20d) | 142d? → 155.83d? | 35d → 21.17d |  |  |
| 43 | System Design Report | 2008-02-11 → 2008-02-22 (+11d) | 2008-02-20 → 2008-03-05 (+14d) |  | 35d → 21.17d |  |  |
| 44 | **System Design Review** |  | 2008-04-01 → 2008-04-21 (+20d) | 142d? → 155.83d? | 35d → 21.17d |  |  |
| 46 | Review Package Distributed | 2008-02-21 → 2008-03-05 (+13d) | 2008-02-21 → 2008-03-06 (+14d) |  | 35d → 25.17d |  |  |
| 47 | Reviewer Comments Addressed | 2008-03-07 → 2008-03-20 (+13d) | 2008-03-13 → 2008-03-27 (+14d) |  | 35d → 25.17d |  |  |
| 48 | System Design Review Support | 2008-02-21 → 2008-03-05 (+13d) | 2008-03-04 → 2008-04-02 (+29d) | 8.41d? → 20d? | 42.59d → 21.17d |  | was named System Design Review Prep; resources Wizinowich [34%]; Dekany [35%]; Gavel [35%]; Max [35%]; Bauman [35%]; Bouchez [12.5%]; Velur [60%]; Flicker; Neyman [83%]; Britton [40%]; Le Mignant [10%] → Wizinowich [15%]; Dekany [15%]; Gavel [15%]; Max [15%]; Bauman [7.5%]; Bouchez [2.5%]; Velur [10%]; Flicker [10%]; Neyman [16.2%]; Le Mignant [10%]; Johansson [10%]; Adkins [10%]; Chin [5%]; Kellner [5%]; Moore [10%] |
| 49 | System Design Review Meeting | 2008-03-13 → 2008-04-02 (+20d) | 2008-03-13 → 2008-04-02 (+20d) |  | 35d → 21.17d |  |  |
| 50 | Reviewer Report Received | 2008-03-27 → 2008-04-16 (+20d) | 2008-03-27 → 2008-04-16 (+20d) |  | 35d → 21.17d |  |  |
| 51 | Response to Reviewer Report & Distribution | 2008-03-28 → 2008-04-16 (+19d) | 2008-04-01 → 2008-04-21 (+20d) |  | 35d → 21.17d |  |  |
| 52 | **System Requirements** |  | 2007-11-16 → 2007-11-02 (-14d) | 305d? → 295d? | 105d → 141d |  |  |
| 56 | Point Source Companion Sensitivity Requirements |  |  |  |  |  | resources none → Student1 [27.8%] |
| 57 | Spectral Sensitivity & Spectral Resolution Requirements |  |  |  |  |  | resources none → Student1 [27.8%] |
| 58 | Observing Scenarios |  |  |  |  |  | resources none → Student1 [10.4%] |
| 59 | Science Instrument Requirements |  |  |  |  |  | resources none → Student1 [10.4%] |
| 61 | Performance Requirements |  |  |  |  |  | resources none → Student1 [31.2%] |
| 62 | Observing Scenarios |  |  |  |  |  | resources none → Student1 [10.4%] |
| 63 | Science Instrument Requirements |  |  |  |  |  | resources none → Student1 [10.4%] |
| 65 | Spatial Resolution Requirements |  |  |  |  |  | resources none → Student1 [50%] |
| 66 | Spectral Sensitivity & Spectral Resolution Requirements |  |  |  |  |  | resources none → Student1 [50%] |
| 67 | Observing Scenarios |  |  |  |  |  | resources none → Student1 [12.5%] |
| 68 | Science Instrument Requirements |  |  |  |  |  | resources none → Student1 [12.5%] |
| 71 | Astrometry requirements |  |  |  |  |  | resources none → Student2 [37.5%] |
| 72 | Observing Scenarios |  |  |  |  |  | resources none → Student2 [8.9%] |
| 73 | Science Instrument Requirements |  |  |  |  |  | resources none → Student2 [8.9%] |
| 75 | Performance Requirements |  |  |  |  |  | resources none → Student2 [41.7%] |
| 76 | Observing Scenarios |  |  |  |  |  | resources none → Student2 [10.4%] |
| 77 | Science Instrument Requirements |  |  |  |  |  | resources none → Student2 [10.4%] |
| 79 | Performance Requirements |  |  |  |  |  | resources none → Student2 [75%] |
| 80 | Observing Scenarios |  |  |  |  |  | resources none → Student2 [12.5%] |
| 81 | Science Instrument Requirements |  |  |  |  |  | resources none → Student2 [12.5%] |
| 83 | Companion Sensitivity Performance Requirements |  |  |  |  |  | resources none → Student2 [37.5%] |
| 84 | Observing Scenarios |  |  |  |  |  | resources none → Student2 [8.9%] |
| 85 | Science Instrument Requirements |  |  |  |  |  | resources none → Student2 [8.9%] |
| 87 | Contrast Performance Requirements |  |  |  |  |  | resources none → Student2 [75%] |
| 88 | Observing Scenarios |  |  |  |  |  | resources none → Student2 [12.5%] |
| 89 | Science Instrument Requirements |  |  |  |  |  | resources none → Student2 [12.5%] |
| 91 | Polarimetry Performance Requirements |  |  |  |  |  | resources none → Student2 [41.7%] |
| 92 | Observing Scenarios |  |  |  |  |  | resources none → Student2 [10.4%] |
| 93 | Science Instrument Requirements |  |  |  |  |  | resources none → Student2 [10.4%] |
| 96 | Performance Requirements |  |  |  |  |  | resources none → Postdoc [52.1%] |
| 97 | Observing Scenarios |  |  |  |  |  | resources none → Postdoc [7.8%] |
| 98 | Science Instrument Requirements |  |  |  |  |  | resources none → Postdoc [7.8%] |
| 100 | Encircled Energy (& d-IFU) Performance Requirements |  |  |  |  |  | resources none → Postdoc [41.7%] |
| 101 | Observing Scenarios |  |  |  |  |  | resources none → Postdoc [15.6%] |
| 102 | Science Instrument Requirements |  |  |  |  |  | resources none → Postdoc [15.6%] |
| 104 | Encircled Energy & PSF Performance Requirements |  |  |  |  |  | resources none → Postdoc [31.2%] |
| 105 | Observing Scenarios |  |  |  |  |  | resources none → Postdoc [7.8%] |
| 106 | Science Instrument Requirements |  |  |  |  |  | resources none → Postdoc [7.8%] |
| 108 | Encircled Energy & PSF Performance Requirements |  |  |  |  |  | resources none → Postdoc [31.2%] |
| 109 | Observing Scenarios |  |  |  |  |  | resources none → Postdoc [7.8%] |
| 110 | Science Instrument Requirements |  |  |  |  |  | resources none → Postdoc [7.8%] |
| 116 | **Observatory Requirements** |  | 2007-11-02 → 2007-09-07 (-56d) | 285d? → 245d? | 95d → 131d |  |  |
| 119 | Science Operations Requirements |  | 2007-01-19 → 2006-11-24 (-56d) | 80d? → 40d? | 95d → 131d |  | constraint start no earlier than 2006-10-02 → finish no earlier than 2006-11-24; resources Le Mignant [5%]; Wizinowich [5%]; Bouchez [5%] → Le Mignant [10%]; Wizinowich [5%]; Bouchez [5%] |
| 120 | Observatory Requirements Rev 2 | 2007-03-19 → 2007-01-22 (-56d) | 2007-04-06 → 2007-02-09 (-56d) |  | 95d → 131d |  |  |
| 121 | Observatory Requirements Rev 3 | 2007-06-04 → 2007-04-09 (-56d) | 2007-07-13 → 2007-05-18 (-56d) |  | 95d → 131d |  |  |
| 122 | Observatory Requirements Rev 4 | 2007-09-10 → 2007-07-16 (-56d) | 2007-11-02 → 2007-09-07 (-56d) |  | 95d → 131d |  |  |
| 123 | **System Requirements Document** |  | 2007-11-16 → 2007-11-02 (-14d) | 290d? → 280d? | 132d → 142d |  |  |
| 129 | **System Requirements Document** | 2007-01-22 → 2006-11-27 (-56d) | 2007-11-16 → 2007-11-02 (-14d) | 215d → 245d | 132d → 142d |  |  |

| ID | Task | Start | Finish | Duration | Total float | Predecessors | Other |
| --- | --- | --- | --- | --- | --- | --- | --- |
| 130 | SRD Rev 1 | 2007-01-22 → 2006-11-27 (-56d) | 2007-02-02 → 2006-12-08 (-56d) |  | 337d → 377d |  | constraint start no earlier than 2006-10-27 → start no earlier than 2006-11-27; resources Neyman [25%] → Wizinowich [25%] |
| 131 | SRD Rev 2 | 2007-04-09 → 2007-03-09 (-31d) | 2007-04-20 → 2007-03-22 (-29d) |  | 282d → 303d |  |  |
| 132 | SRD Rev 3 | 2007-07-16 → 2007-06-29 (-17d) | 2007-07-27 → 2007-07-12 (-15d) |  | 212d → 223d |  |  |
| 133 | SRD Final SD Phase Version | 2007-11-05 → 2007-10-22 (-14d) | 2007-11-16 → 2007-11-02 (-14d) |  | 95d → 101d |  |  |
| 134 | **System Design** |  | 2008-02-08 → 2008-01-18 (-21d) | 390d? → 375d? | 72d → 86.17d |  |  |
| 135 | **Systems Engineering** |  | 2008-01-04 → 2007-12-28 (-7d) | 365d? → 360d? | 97d → 86.17d |  |  |
| 136 | **Performance Budgets** |  | 2007-09-25 → 2007-09-27 (+2d) | 292d? → 293.75d? | 170d → 86.17d |  |  |
| 159 | Astrometric Accuracy |  | 2007-01-26 → 2007-06-29 (+154d) | 55d? → 165d? | 185d → 21.17d |  | resources Neyman [9.1%]; Britton [13.6%]; Flicker [9.1%]; Cameron [13.6%]; Wizinowich [9.1%] → Britton [13.6%]; Cameron [13.6%] |
| 161 | Companion Sensitivity |  | 2007-01-26 → 2007-01-09 (-17d) | 55d? → 41.25d? | 179d → 144.92d |  |  |
| 164 | **Performance Budgets Summary** |  | 2007-04-20 → 2007-08-03 (+105d) | 58d? → 133d? | 150d → 71.5d |  |  |
| 166 | Performance Budgets Summary Ver 2 | 2007-03-19 → 2007-07-02 (+105d) | 2007-04-20 → 2007-08-03 (+105d) |  | 150d → 21.17d |  |  |
| 167 | **Science Products** | 2007-07-16 → 2007-08-06 (+21d) | 2007-09-25 → 2007-09-27 (+2d) | 52d? → 38.75d? | 170d → 168.25d |  |  |
| 168 | All-In Science Simulations | 2007-07-16 → 2007-08-06 (+21d) | 2007-08-10 → 2007-08-31 (+21d) |  | 187d → 168.25d |  |  |
| 169 | **Additional Science Characterization Results** | 2007-08-13 → 2007-09-03 (+21d) | 2007-09-25 → 2007-09-27 (+2d) | 32d? → 18.75d? | 170d → 168.25d |  |  |
| 170 | Point Source Sensitivities | 2007-08-13 → 2007-09-03 (+21d) | 2007-09-06 → 2007-09-27 (+21d) |  | 183.25d → 168.25d |  |  |
| 171 | PSF Uniformity & Stability | 2007-08-13 → 2007-09-03 (+21d) | 2007-08-31 → 2007-09-21 (+21d) |  | 187d → 172d |  |  |
| 172 | Other |  |  |  |  |  | resources none → Other [66.7%] |
| 174 | **System Architecture Trade Studies** |  | 2007-03-02 → 2007-03-30 (+28d) | 100d? → 120d? | 185d → 111.17d |  |  |
| 177 | Adaptive Secondary Mirror option TS (m5) | 2007-02-05 → 2007-03-05 (+28d) | 2007-03-02 → 2007-03-30 (+28d) |  | 185d → 111.17d |  | constraint start no earlier than 2007-02-05 → start no earlier than 2007-03-05 |
| 178 | K & L-band Science TS (m5) |  |  |  | 185d → 131.17d |  | resources Other [25%] → Bouchez [25%] |
| 194 | LOWFS Architecture TS |  | 2007-02-28 → 2007-02-09 (-19d) | 62.5d? → 50d? | 84.5d → 104.5d |  |  |
| 200 | Focus Compensation TS (m6) |  |  |  | 141d → 87.17d |  | resources Bouchez [5.1%] → Kellner [2.5%]; Velur [2.5%] |
| 206 | **System Architecture** |  | 2008-01-04 → 2007-12-28 (-7d) | 223d? → 218d? | 97d → 102d |  |  |
| 208 | System Architecture Ver 2 | 2007-05-28 → 2007-08-06 (+70d) | 2007-06-22 → 2007-08-31 (+70d) |  | 125d → 21.17d |  |  |
| 209 | **Functional Requirements** |  | 2007-12-07 → 2007-11-30 (-7d) | 167d? → 162d? | 55d → 47.5d |  |  |
| 213 | Laser System Functional Requirements Ver 2 | 2007-11-05 → 2007-10-29 (-7d) | 2007-12-07 → 2007-11-30 (-7d) |  | 55d → 47.5d |  | constraint start no earlier than 2007-11-05 → start no earlier than 2007-10-29 |
| 218 | Technology Drivers Summary | 2007-05-28 → 2007-08-06 (+70d) | 2007-05-31 → 2007-08-09 (+70d) |  | 191.37d → 148.87d |  |  |
| 219 | Technical Risk Analysis Ver 1 | 2007-05-31 → 2007-08-09 (+70d) | 2007-07-03 → 2007-09-11 (+70d) |  | 230.37d → 180.37d |  |  |
| 220 | Technical Risk Analysis Ver 2 |  | 2008-01-04 → 2007-12-28 (-7d) | 25d? → 20d? | 35d → 47.5d | 211 → 209 | constraint none → finish no earlier than 2007-12-28; resources Neyman [12%]; Gavel [8%] → Neyman [15%]; Gavel [10%] |
| 223 | AO Enclosure |  |  |  | 135d → 142.5d |  | resources none → Meguro [17.9%] |
| 225 | Field Rotation |  |  |  | 101.25d → 108.75d |  | resources Bauman [4.5%]; Meguro [2.3%] → Bauman [4.5%]; Lockwood [2.3%] |
| 226 | Optical Relay |  |  |  | 95.75d → 103.25d |  | resources Bauman [5.7%]; Meguro [3.4%]; Dekany [2%] → Bauman [5.7%]; Lockwood [3.4%]; Dekany [2%] |
| 227 | Optical Switchyard |  |  |  | 128.75d → 136.25d |  | resources Bauman [5.7%]; Meguro [5.7%] → Bauman [5.7%]; Lockwood [5.7%] |
| 228 | Optical Support Structure |  |  |  | 95.75d → 103.25d |  | resources Meguro [9.1%]; Bauman [4.5%] → Lockwood [9.1%]; Bauman [4.5%] |
| 232 | Low Order NGS Wavefront Sensors |  |  |  | 52d → 59.5d |  | resources Kellner [2.9%]; Meguro [2.9%] → Kellner [2.9%]; Meguro [1.4%]; Velur [1.4%] |
| 235 | Tip/Tilt Corrector |  |  |  | 170d → 177.5d |  | resources Flicker [2.9%] → Flicker [1.5%]; Bauman [1.5%] |
| 244 | Non-RTC Electronics |  |  |  | 89d → 96.5d |  | resources Chin [10%]; Other [10%] → Chin [10%]; Reinig [10%] |
| 245 | **Real-time Control** |  |  | 109.52d? → 110d? | 165.48d → 172.5d |  |  |
| 246 | RTC Architecture Analysis and Design Study |  |  | 42.86d? → 43d? | 165.48d → 172.5d |  | resources Gavel [25%]; Johansson [20%]; Flicker [17.5%] → Gavel [5.8%]; Johansson [11.6%]; Flicker [11.6%]; Reinig [23.3%] |
| 247 | RTC Software Module Definition | 2007-04-04 → 2007-04-05 (+1d) |  | 66.67d? → 67d? | 165.48d → 172.5d |  | resources Johansson [15%] → Johansson [11.2%]; Reinig [3.7%] |
| 248 | RTC Hardware Module Definition | 2007-04-04 → 2007-04-05 (+1d) |  | 66.67d? → 67d? | 165.48d → 172.5d |  | resources Johansson [15%] → Johansson [3.7%]; Reinig [11.2%] |
| 251 | Laser Enclosure |  |  |  | 161d → 168.5d |  | resources none → Meguro [23.3%] |
| 252 | Laser |  |  |  | 169d → 176.5d |  | resources none → Velur [35.7%] |
| 253 | **Laser Delivery Facility** |  |  |  | 214d → 221.5d |  | was named Laser Launch Facility |
| 255 | Laser Pointing & Diagnostics |  |  |  | 214d → 221.5d |  | resources Neyman [21.9%]; Kellner [21.9%]; Chin [6.2%] → Velur [21.9%]; Kellner [21.9%]; Chin [6.2%]; Moore [22%] |
| 256 | Laser Launch Telescope |  |  |  | 225.88d → 233.38d |  | resources Neyman [22.2%]; Kellner [22.2%]; Chin [11.1%] → Velur [22.2%]; Kellner [22.2%]; Chin [11.1%] |
| 266 | AO Guide Star Interface |  |  |  | 192d → 199.5d |  | resources none → Other [11.4%] |
| 267 | Science Observations Simulation Tools |  |  |  | 192d → 199.5d |  | resources none → Other [22.7%] |
| 269 | Acquisition |  |  |  | 214d → 221.5d |  | resources none → Other [5.8%] |
| 270 | Observing Sequences |  |  |  | 214d → 221.5d |  | resources none → Other [5.8%] |
| 271 | Instrument, AO & Telescope Observer Interfaces |  |  |  | 214d → 221.5d |  | resources none → Other [5.8%] |
| 272 | Science Data Quality Monitoring |  |  |  | 214d → 221.5d |  | resources none → Other [5.8%] |
| 274 | Generic Data Products |  |  |  | 149d → 156.5d |  | resources none → Other [6%] |
| 275 | Science Data Quality Assessment |  |  |  | 149d → 156.5d |  | resources none → Other [6%] |
| 276 | Science Data Archiving |  |  |  | 149d → 156.5d |  | resources none → Other [11.9%] |
| 280 | AO-Instrument Operations Support |  |  |  | 192d → 199.5d |  | resources none → Other [3%] |
| 281 | AO-Instrument Configuration & Setup |  |  |  | 192d → 199.5d |  | resources none → Other [3%] |
| 282 | AO-Instrument Calibrations |  |  |  | 192d → 199.5d |  | resources none → Other [3%] |
| 283 | AO-Instrument Nighttime Operation Modes |  |  |  | 192d → 199.5d |  | resources none → Other [3%] |
| 284 | AO-Instrument Science Acquisition & Control |  |  |  | 192d → 199.5d |  | resources none → Other [3%] |
| 285 | AO-Instrument Health Monitoring & Automated Recovery |  |  |  | 192d → 199.5d |  | resources none → Other [3%] |
| 287 | AO-Instrument User Interfaces |  |  |  | 170d → 177.5d |  | resources none → Other [25%] |
| 288 | AO-Instrument Maintenance Plan |  |  |  | 150d → 157.5d |  | resources none → Other [12.5%] |
| 292 | AO-Instrument Environment Monitoring |  |  |  | 210d → 217.5d |  | resources none → Other [16.7%] |
| 293 | **Science Instruments** |  | 2007-11-20 → 2007-09-17 (-64d) | 296.33d? → 251d? | 68.67d → 121.5d |  |  |
| 300 | Deployable Near-IR IFU |  | 2007-11-20 → 2007-06-27 (-146d) | 208.33d? → 105d? | 68.67d → 179.5d |  | resources Adkins [4%]; Other [35.7%]; Neyman [15.9%] → Adkins [7.1%]; Other [35.7%]; Neyman [16.7%] |
| 302 | System Design Manual | 2008-01-07 → 2008-01-01 (-6d) | 2008-02-08 → 2008-01-18 (-21d) | 24d? → 12.5d? | 35d → 46d |  | resources Wizinowich [20.8%]; Dekany [10.4%]; Gavel [10.4%] → Wizinowich [42%]; Dekany [20%]; Gavel [20%] |
| 303 | **Systems Engineering Management Plan (SEMP)** | 2007-01-15 → 2007-02-05 (+21d) | 2008-01-02 → 2008-02-22 (+51d) | 253d? → 274.83d? | 62d → 21.17d |  |  |
| 304 | **Project Plan** | 2007-09-17 → 2007-10-01 (+14d) | 2007-12-07 → 2007-12-28 (+21d) | 59.25d? → 64.43d? | 67d → 21.17d |  |  |
| 305 | WBS and Task Definition | 2007-09-17 → 2007-10-01 (+14d) | 2007-09-21 → 2007-10-30 (+39d) | 4.25d? → 21.43d? | 122d → 21.17d | none → 22, 208FS+4w | was named Task Definition; constraint finish no earlier than 2007-09-21 → none; resources Wizinowich [58.8%]; Dekany [58.8%]; Gavel [58.8%]; Max [58.8%] → Wizinowich [35%]; Dekany [35%]; Gavel [35%]; Max [35%] |

| ID | Task | Start | Finish | Duration | Total float | Predecessors | Other |
| --- | --- | --- | --- | --- | --- | --- | --- |
| 306 | Cost Estimation | 2007-10-22 → 2007-10-30 (+8d) | 2007-11-02 → 2007-12-04 (+32d) | 10d? → 25d? | 92d → 23.57d | none → 305 | constraint finish no earlier than 2007-11-02 → none; resources Wizinowich [62.5%]; Dekany [62.5%]; Gavel [62.5%]; Other [62.5%] → Wizinowich [10%]; Dekany [10%]; Gavel [10%]; Other [200%] |
| 307 | Major Project Milestones | 2007-11-09 → 2007-10-30 (-10d) | 2007-11-13 → 2007-11-05 (-8d) | 2.5d? → 3.75d? | 85d → 87.82d | none → 305 | constraint finish no earlier than 2007-11-13 → none |
| 308 | Develop Full Schedule (MS Project Plan) | 2007-12-03 → 2007-12-04 (+1d) | 2007-12-07 → 2007-12-28 (+21d) | 4.5d? → 18d? | 67d → 23.57d | none → 306 | was named MS Project Plan; constraint finish no earlier than 2007-12-07 → none |
| 309 | Risk Assessment & Management Plan | 2007-11-14 → 2007-10-01 (-44d) | 2007-12-14 → 2007-11-15 (-29d) | 23d? → 33.33d? | 62d → 79.67d | none → 305SS | constraint finish no earlier than 2007-12-14 → none; resources none → Other [15%] |
| 310 | **Preliminary Design Phase Plan** |  | 2007-08-17 → 2008-02-01 (+168d) | 140d? → 259.43d? | 147d → 23.57d |  |  |
| 312 | Version 2 | 2007-04-09 → 2007-10-30 (+204d) | 2007-05-18 → 2007-11-26 (+192d) | 30d? → 18.75d? | 212d → 72.82d | none → 305 | was named Intermediate Versions; resources Wizinowich [7.5%]; Dekany [3.3%]; Gavel [3.3%]; Max [2.5%] → Wizinowich [20%]; Dekany [20%]; Gavel [20%]; Max [20%] |
| 313 | Final Version | 2007-07-30 → 2008-01-11 (+165d) | 2007-08-17 → 2008-02-01 (+168d) |  | 147d → 23.57d | none → 308FS+2w | constraint start no earlier than 2007-07-30 → none |
| 314 | **Integration and Test Plans** | 2007-03-12 → 2007-10-30 (+232d) | 2007-11-27 → 2008-02-05 (+70d) | 187d? → 70.4d? | 75d → 21.17d |  |  |
| 315 | **Subsystem Testing Plans** | 2007-10-29 → 2007-10-30 (+1d) | 2007-11-27 → 2008-02-05 (+70d) | 22d? → 70.4d? | 75d → 21.17d |  |  |
| 316 | AO System Test Plan | 2007-10-29 → 2007-10-30 (+1d) | 2007-11-27 → 2007-11-23 (-4d) | 22d? → 17.6d? | 75d → 21.17d | none → 305 | constraint start no earlier than 2007-10-29 → none |
| 317 | Laser System Test Plan | 2007-10-29 → 2007-11-23 (+25d) | 2007-11-27 → 2007-12-18 (+21d) | 22d? → 17.6d? | 75d → 21.17d | none → 316 | constraint start no earlier than 2007-10-29 → none |
| 318 | Science Operations Test Plan | 2007-10-29 → 2007-12-18 (+50d) | 2007-11-27 → 2008-01-11 (+45d) | 22d? → 17.6d? | 75d → 21.17d | none → 317 | constraint start no earlier than 2007-10-29 → none |
| 319 | Science Instruments Test Plan | 2007-10-29 → 2008-01-11 (+74d) | 2007-11-27 → 2008-02-05 (+70d) | 22d? → 17.6d? | 75d → 21.17d | none → 318 | constraint start no earlier than 2007-10-29 → none |
| 320 | System Integration & Test Plans | 2007-03-12 → 2007-10-30 (+232d) | 2007-04-20 → 2007-12-11 (+235d) |  | 232d → 61.57d | none → 305 | constraint finish no earlier than 2007-04-20 → none; resources Neyman [41.7%] → Other [41.7%] |
| 321 | Configuration Management Plan | 2007-01-15 → 2007-10-30 (+288d) | 2007-04-11 → 2008-01-24 (+288d) |  | 239.5d → 29.07d | none → 305 |  |
| 322 | Project Management Plan | 2007-02-12 → 2007-12-28 (+319d) | 2007-03-09 → 2008-01-25 (+322d) |  | 262d → 28.57d | none → 308 |  |
| 323 | SEMP Document | 2007-12-17 → 2008-02-05 (+50d) | 2008-01-02 → 2008-02-22 (+51d) |  | 62d → 21.17d |  | constraint finish no earlier than 2008-01-02 → none |

## Version 7 (saved 2006-09-28, file NGAO_SD_schedule_v14.mpp)

Last finish stays 2008-05-20.

Changed:

| ID | Task | Start | Finish | Duration | Total float | Predecessors | Other |
| --- | --- | --- | --- | --- | --- | --- | --- |
| 2 | **Planning and Contracting** |  | 2007-11-16 → 2007-09-14 (-63d) | 367.76d? → 323d? | 132.24d → 177d |  |  |
| 10 | FY08 Replan | 2007-10-30 → 2007-09-05 (-55d) | 2007-11-16 → 2007-09-14 (-63d) | 13.33d → 8d | 132.24d → 177d | 305 → none | constraint none → start no earlier than 2007-09-05 |
| 14 | **Team Meetings** |  |  | 344.5d → 345d | 94.5d → 94d |  |  |
| 17 | Team Videocon #3 |  |  | 0.5d → 1d | 374.5d → 374d |  |  |
| 19 | Team Videocon #5 |  |  | 0.5d → 1d | 314.5d → 314d |  |  |
| 21 | Team Videocon #7 |  |  | 0.5d → 1d |  |  |  |
| 22 | Team Retreat #8 (UCSC) |  | 2007-07-11 → 2007-07-13 (+2d) | 2.5d → 5d | 78.67d → 222d |  |  |
| 23 | Team Videocon #9 |  |  | 0.5d → 1d | 194.5d → 194d |  |  |
| 25 | Team Videocon #11 |  |  | 0.5d → 1d | 141.5d → 141d |  |  |
| 27 | Team Videocon #13 |  |  | 0.5d → 1d | 94.5d → 94d |  |  |
| 39 | **Proposals & Fundraising** |  | 2007-01-01 → 2007-12-31 (+364d) | 45d? → 306d? | 362d → 101d |  |  |
| 41 | Support Advancement Office |  | 2007-01-01 → 2007-12-31 (+364d) | 0d? → 261d? | 362d → 101d |  |  |
| 42 | **System Design Report & Review** |  | 2008-04-21 → 2008-03-31 (-21d) | 155.83d? → 141d? | 21.17d → 36d |  |  |
| 43 | System Design Report | 2008-02-22 → 2008-02-04 (-18d) | 2008-03-05 → 2008-02-13 (-21d) |  | 21.17d → 36d |  |  |
| 44 | **System Design Review** |  | 2008-04-21 → 2008-03-31 (-21d) | 155.83d? → 141d? | 21.17d → 36d |  |  |
| 46 | Review Package Distributed | 2008-03-05 → 2008-02-14 (-20d) | 2008-03-06 → 2008-02-14 (-21d) |  | 25.17d → 40d |  |  |
| 47 | Reviewer Comments Addressed | 2008-03-20 → 2008-02-29 (-20d) | 2008-03-27 → 2008-03-06 (-21d) |  | 25.17d → 40d |  |  |
| 48 | System Design Review Support | 2008-03-05 → 2008-02-14 (-20d) | 2008-04-02 → 2008-03-12 (-21d) |  | 21.17d → 36d |  |  |
| 49 | System Design Review Meeting | 2008-04-02 → 2008-03-12 (-21d) | 2008-04-02 → 2008-03-12 (-21d) |  | 21.17d → 36d |  |  |
| 50 | Reviewer Report Received | 2008-04-16 → 2008-03-26 (-21d) | 2008-04-16 → 2008-03-26 (-21d) |  | 21.17d → 36d |  |  |
| 51 | Response to Reviewer Report & Distribution | 2008-04-16 → 2008-03-27 (-20d) | 2008-04-21 → 2008-03-31 (-21d) |  | 21.17d → 36d |  |  |
| 134 | **System Design** |  | 2008-01-18 → 2008-02-01 (+14d) | 375d? → 385d? | 86.17d → 77d |  |  |
| 136 | **Performance Budgets** |  | 2007-09-27 → 2007-09-25 (-2d) | 293.75d? → 292d? | 86.17d → 170d |  |  |
| 159 | Astrometric Accuracy |  | 2007-06-29 → 2007-01-26 (-154d) | 165d? → 55d? | 21.17d → 186d |  | resources Britton [13.6%]; Cameron [13.6%] → Neyman [9.1%]; Britton [13.6%]; Flicker [9.1%]; Cameron [13.6%]; Wizinowich [9.1%] |
| 161 | Companion Sensitivity |  | 2007-01-09 → 2007-01-26 (+17d) | 41.25d? → 55d? | 144.92d → 175d |  |  |
| 164 | **Performance Budgets Summary** |  | 2007-08-03 → 2007-04-20 (-105d) | 133d? → 58d? | 71.5d → 151d |  |  |
| 166 | Performance Budgets Summary Ver 2 | 2007-07-02 → 2007-03-19 (-105d) | 2007-08-03 → 2007-04-20 (-105d) |  | 21.17d → 151d |  |  |
| 167 | **Science Products** | 2007-08-06 → 2007-07-16 (-21d) | 2007-09-27 → 2007-09-25 (-2d) | 38.75d? → 52d? | 168.25d → 170d |  |  |
| 168 | All-In Science Simulations | 2007-08-06 → 2007-07-16 (-21d) | 2007-08-31 → 2007-08-10 (-21d) |  | 168.25d → 183.25d |  |  |
| 169 | **Additional Science Characterization Results** | 2007-09-03 → 2007-08-13 (-21d) | 2007-09-27 → 2007-09-25 (-2d) | 18.75d? → 32d? | 168.25d → 170d |  |  |
| 170 | Point Source Sensitivities | 2007-09-03 → 2007-08-13 (-21d) | 2007-09-27 → 2007-09-06 (-21d) |  | 168.25d → 183.25d |  |  |
| 171 | PSF Uniformity & Stability | 2007-09-03 → 2007-08-13 (-21d) | 2007-09-21 → 2007-08-31 (-21d) |  | 172d → 187d |  |  |
| 194 | LOWFS Architecture TS |  | 2007-02-09 → 2007-02-28 (+19d) | 50d? → 62.5d? | 104.5d → 80.5d |  |  |
| 208 | System Architecture Ver 2 | 2007-08-06 → 2007-05-28 (-70d) | 2007-08-31 → 2007-06-22 (-70d) |  | 21.17d → 126d |  |  |
| 218 | Technology Drivers Summary | 2007-08-06 → 2007-05-28 (-70d) | 2007-08-09 → 2007-05-31 (-70d) |  | 148.87d → 187.37d |  |  |
| 219 | Technical Risk Analysis Ver 1 | 2007-08-09 → 2007-05-31 (-70d) | 2007-09-11 → 2007-07-03 (-70d) |  | 180.37d → 230.37d |  |  |
| 253 | **Laser Launch Facility** |  |  |  | 221.5d → 210d |  | was named Laser Delivery Facility |
| 255 | Laser Pointing & Diagnostics |  |  |  | 221.5d → 210d |  | resources Velur [21.9%]; Kellner [21.9%]; Chin [6.2%]; Moore [22%] → Velur [21.9%]; Kellner [21.9%]; Chin [6.2%] |
| 302 | System Design Manual | 2008-01-01 → 2007-12-31 (-1d) | 2008-01-18 → 2008-02-01 (+14d) | 12.5d? → 24d? | 46d → 36d |  | resources Wizinowich [42%]; Dekany [20%]; Gavel [20%] → Wizinowich [20.8%]; Dekany [10.4%]; Gavel [10.4%] |
| 303 | **Systems Engineering Management Plan (SEMP)** | 2007-02-05 → 2007-01-15 (-21d) | 2008-02-22 → 2008-01-02 (-51d) | 274.83d? → 253d? | 21.17d → 58d |  |  |
| 304 | **Project Plan** | 2007-10-01 → 2007-09-17 (-14d) | 2007-12-28 → 2007-12-07 (-21d) | 64.43d? → 59.25d? | 21.17d → 63d |  |  |
| 305 | Task Definition | 2007-10-01 → 2007-09-17 (-14d) | 2007-10-30 → 2007-09-21 (-39d) | 21.43d? → 4.25d? | 21.17d → 118d | 22, 208FS+4w → none | was named WBS and Task Definition; constraint none → finish no earlier than 2007-09-21; resources Wizinowich [35%]; Dekany [35%]; Gavel [35%]; Max [35%] → Wizinowich [58.8%]; Dekany [58.8%]; Gavel [58.8%]; Max [58.8%] |
| 306 | Cost Estimation | 2007-10-30 → 2007-10-22 (-8d) | 2007-12-04 → 2007-11-02 (-32d) | 25d? → 10d? | 23.57d → 88d | 305 → none | constraint none → finish no earlier than 2007-11-02; resources Wizinowich [10%]; Dekany [10%]; Gavel [10%]; Other [200%] → Wizinowich [62.5%]; Dekany [62.5%]; Gavel [62.5%]; Other [62.5%] |
| 307 | Major Project Milestones | 2007-10-30 → 2007-11-09 (+10d) | 2007-11-05 → 2007-11-13 (+8d) | 3.75d? → 2.5d? | 87.82d → 81d | 305 → none | constraint none → finish no earlier than 2007-11-13 |
| 308 | MS Project Plan | 2007-12-04 → 2007-12-03 (-1d) | 2007-12-28 → 2007-12-07 (-21d) | 18d? → 4.5d? | 23.57d → 63d | 306 → none | was named Develop Full Schedule (MS Project Plan); constraint none → finish no earlier than 2007-12-07 |
| 309 | Risk Assessment & Management Plan | 2007-10-01 → 2007-11-14 (+44d) | 2007-11-15 → 2007-12-14 (+29d) | 33.33d? → 23d? | 79.67d → 58d | 305SS → none | constraint none → finish no earlier than 2007-12-14; resources Other [15%] → Other [21.7%] |
| 310 | **Preliminary Design Phase Plan** |  | 2008-02-01 → 2007-08-17 (-168d) | 259.43d? → 140d? | 23.57d → 143d |  |  |
| 312 | Intermediate Versions | 2007-10-30 → 2007-04-09 (-204d) | 2007-11-26 → 2007-05-18 (-192d) | 18.75d? → 30d? | 72.82d → 208d | 305 → none | was named Version 2; resources Wizinowich [20%]; Dekany [20%]; Gavel [20%]; Max [20%] → Wizinowich [7.5%]; Dekany [3.3%]; Gavel [3.3%]; Max [2.5%] |
| 313 | Final Version | 2008-01-11 → 2007-07-30 (-165d) | 2008-02-01 → 2007-08-17 (-168d) |  | 23.57d → 143d | 308FS+2w → none | constraint none → start no earlier than 2007-07-30 |
| 314 | **Integration and Test Plans** | 2007-10-30 → 2007-03-12 (-232d) | 2008-02-05 → 2007-11-27 (-70d) | 70.4d? → 187d? | 21.17d → 71d |  |  |
| 315 | **Subsystem Testing Plans** | 2007-10-30 → 2007-10-29 (-1d) | 2008-02-05 → 2007-11-27 (-70d) | 70.4d? → 22d? | 21.17d → 71d |  |  |
| 316 | AO System Test Plan | 2007-10-30 → 2007-10-29 (-1d) | 2007-11-23 → 2007-11-27 (+4d) | 17.6d? → 22d? | 21.17d → 71d | 305 → none | constraint none → start no earlier than 2007-10-29 |
| 317 | Laser System Test Plan | 2007-11-23 → 2007-10-29 (-25d) | 2007-12-18 → 2007-11-27 (-21d) | 17.6d? → 22d? | 21.17d → 71d | 316 → none | constraint none → start no earlier than 2007-10-29 |
| 318 | Science Operations Test Plan | 2007-12-18 → 2007-10-29 (-50d) | 2008-01-11 → 2007-11-27 (-45d) | 17.6d? → 22d? | 21.17d → 71d | 317 → none | constraint none → start no earlier than 2007-10-29 |
| 319 | Science Instruments Test Plan | 2008-01-11 → 2007-10-29 (-74d) | 2008-02-05 → 2007-11-27 (-70d) | 17.6d? → 22d? | 21.17d → 71d | 318 → none | constraint none → start no earlier than 2007-10-29 |
| 320 | System Integration & Test Plans | 2007-10-30 → 2007-03-12 (-232d) | 2007-12-11 → 2007-04-20 (-235d) |  | 61.57d → 228d | 305 → none | constraint none → finish no earlier than 2007-04-20; resources Other [41.7%] → Neyman [41.7%] |
| 321 | Configuration Management Plan | 2007-10-30 → 2007-01-15 (-288d) | 2008-01-24 → 2007-04-11 (-288d) |  | 29.07d → 235.5d | 305 → none |  |
| 322 | Project Management Plan | 2007-12-28 → 2007-02-12 (-319d) | 2008-01-25 → 2007-03-09 (-322d) |  | 28.57d → 258d | 308 → none |  |
| 323 | SEMP Document | 2008-02-05 → 2007-12-17 (-50d) | 2008-02-22 → 2008-01-02 (-51d) |  | 21.17d → 58d |  | constraint none → finish no earlier than 2008-01-02 |

## Version 8 (saved 2006-09-28, file NGAO_SD_schedule_v16.mpp)

Last finish 2008-05-20 → 2008-04-03 (-47d).

Changed:

| ID | Task | Start | Finish | Duration | Total float | Predecessors | Other |
| --- | --- | --- | --- | --- | --- | --- | --- |
| 1 | **SD Phase Management** |  | 2008-05-20 → 2008-04-03 (-47d) | 500d? → 467d? |  |  |  |
| 2 | **Planning and Contracting** |  | 2007-09-14 → 2007-09-05 (-9d) | 323d? → 315.26d? | 177d → 151.74d |  |  |
| 6 | SD Phase Contracts Generated |  |  |  |  |  | resources Adkins [16.7%]; Gavel [8.3%]; Dekany [8.3%] → Adkins(IPM) [16.7%]; Gavel [8.3%]; Dekany [8.3%] |
| 10 | FY08 Replan | 2007-09-05 → 2007-08-16 (-20d) | 2007-09-14 → 2007-09-05 (-9d) | 8d → 13.33d | 177d → 184.74d | none → 305 | constraint start no earlier than 2007-09-05 → none |
| 11 | **Project Meetings** |  | 2008-05-20 → 2008-04-03 (-47d) | 500d? → 467d? |  |  |  |
| 12 | Executive Committee Telecons |  | 2008-05-20 → 2008-04-03 (-47d) | 500d → 467d |  |  | resources Wizinowich [2.5%]; Dekany [2.5%]; Gavel [2.5%]; Max [2.5%] → Wizinowich [2.4%]; Dekany [2.4%]; Gavel [2.4%]; Max [2.4%] |
| 14 | **Team Meetings** |  |  | 345d → 344.5d | 94d → 61.5d |  |  |
| 17 | Team Videocon #3 |  |  | 1d → 0.5d | 374d → 341.5d |  |  |
| 19 | Team Videocon #5 |  |  | 1d → 0.5d | 314d → 281.5d |  |  |
| 21 | Team Videocon #7 |  |  | 1d → 0.5d | 254d → 221d |  |  |
| 22 | Team Retreat #8 (UCSC) |  | 2007-07-13 → 2007-07-11 (-2d) | 5d → 2.5d | 222d → 40.67d |  |  |
| 23 | Team Videocon #9 |  |  | 1d → 0.5d | 194d → 161.5d |  |  |
| 25 | Team Videocon #11 |  |  | 1d → 0.5d | 141d → 108.5d |  |  |
| 27 | Team Videocon #13 |  |  | 1d → 0.5d | 94d → 61.5d |  |  |
| 39 | **Proposals & Fundraising** |  | 2007-12-31 → 2007-01-01 (-364d) | 306d? → 45d? | 101d → 329d |  |  |
| 41 | Support Advancement Office |  | 2007-12-31 → 2007-01-01 (-364d) | 261d? → 0d? | 101d → 362d |  |  |
| 42 | **System Design Report & Review** |  | 2008-03-31 → 2008-03-17 (-14d) | 141d? → 131d? | 36d → 13d |  |  |
| 43 | System Design Report | 2008-02-04 → 2008-01-21 (-14d) | 2008-02-13 → 2008-01-30 (-14d) |  | 36d → 46d |  |  |
| 44 | **System Design Review** |  | 2008-03-31 → 2008-03-17 (-14d) | 141d? → 131d? | 36d → 13d |  |  |
| 45 | Identify Reviewers |  |  |  |  |  | resources Adkins [1.9%]; Wizinowich [0.4%]; Max [0.2%]; Gavel [0.2%]; Dekany [0.2%] → Adkins(IPM) [1.9%]; Wizinowich [0.4%]; Max [0.2%]; Gavel [0.2%]; Dekany [0.2%] |
| 46 | Review Package Distributed | 2008-02-14 → 2008-01-31 (-14d) | 2008-02-14 → 2008-01-31 (-14d) |  | 40d → 50d |  | resources Adkins → Adkins(IPM) |
| 47 | Reviewer Comments Addressed | 2008-02-29 → 2008-02-15 (-14d) | 2008-03-06 → 2008-02-21 (-14d) |  | 40d → 50d |  | resources Wizinowich [75%]; Dekany [60%]; Gavel [60%]; Max [65%]; Adkins [40%] → Wizinowich [75%]; Dekany [60%]; Gavel [60%]; Max [65%]; Adkins(IPM) [40%] |
| 48 | System Design Review Support | 2008-02-14 → 2008-01-31 (-14d) | 2008-03-12 → 2008-02-27 (-14d) |  | 36d → 13d |  | resources Wizinowich [15%]; Dekany [15%]; Gavel [15%]; Max [15%]; Bauman [7.5%]; Bouchez [2.5%]; Velur [10%]; Flicker [10%]; Neyman [16.2%]; Le Mignant [10%]; Johansson [10%]; Adkins [10%]; Chin [5%]; Kellner [5%]; Moore [10%] → Wizinowich [15%]; Dekany [15%]; Gavel [15%]; Max [15%]; Bauman [7.5%]; Bouchez [2.5%]; Velur [10%]; Flicker [10%]; Neyman [16.2%]; Le Mignant [10%]; Johansson [10%]; Adkins(IPM) [10%]; Chin [5%]; Kellner [5%]; Moore [10%] |
| 49 | System Design Review Meeting | 2008-03-12 → 2008-02-27 (-14d) | 2008-03-12 → 2008-02-27 (-14d) |  | 36d → 46d |  |  |
| 50 | Reviewer Report Received | 2008-03-26 → 2008-03-12 (-14d) | 2008-03-26 → 2008-03-12 (-14d) |  | 36d → 46d |  |  |
| 51 | Response to Reviewer Report & Distribution | 2008-03-27 → 2008-03-13 (-14d) | 2008-03-31 → 2008-03-17 (-14d) |  | 36d → 46d |  | resources Wizinowich [41.7%]; Dekany [33.3%]; Gavel [33.3%]; Max [41.7%]; Adkins [16.7%] → Wizinowich [41.7%]; Dekany [33.3%]; Gavel [33.3%]; Max [41.7%]; Adkins(IPM) [16.7%] |
| 52 | **System Requirements** | 2006-09-18 → 2006-10-02 (+14d) |  | 295d? → 285d? | 141d → 98d |  |  |
| 53 | **Science Requirements** | 2006-09-18 → 2006-10-02 (+14d) |  | 281d? → 271d? | 156d → 123d |  |  |
| 69 | **Galactic Science Requirements** | 2006-09-18 → 2006-10-02 (+14d) |  | 145d? → 135d? | 292d → 259d |  |  |
| 70 | **Galactic Center Proper Motions: Astrometry** | 2006-09-18 → 2006-10-02 (+14d) |  | 85d? → 75d? | 352d → 319d |  |  |
| 71 | Astrometry requirements | 2006-09-18 → 2006-10-02 (+14d) | 2006-11-24 → 2006-12-08 (+14d) |  | 387d → 344d |  | constraint finish no earlier than 2006-11-24 → start no earlier than 2006-10-02 |
| 82 | **Planets around Low Mass Stars & Brown Dwarfs: Companion Sensitivity** | 2006-09-18 → 2006-10-02 (+14d) |  | 85d? → 75d? | 352d → 319d |  |  |
| 83 | Companion Sensitivity Performance Requirements | 2006-09-18 → 2006-10-02 (+14d) | 2006-11-24 → 2006-12-08 (+14d) |  | 387d → 344d |  | constraint finish no earlier than 2006-11-24 → start no earlier than 2006-10-02 |
| 94 | **Extragalactic Science Requirements** | 2006-09-18 → 2006-10-02 (+14d) |  | 160d? → 150d? | 277d → 244d |  |  |
| 95 | **Resolved Stellar Populations in Crowded Fields** | 2006-09-18 → 2006-10-02 (+14d) |  | 100d? → 90d? | 337d → 304d |  |  |
| 96 | Performance Requirements | 2006-09-18 → 2006-10-02 (+14d) | 2006-12-08 → 2006-12-22 (+14d) |  | 377d → 334d |  | constraint finish no earlier than 2006-12-08 → start no earlier than 2006-10-02 |
| 99 | **High Redshift Galaxies** | 2006-09-18 → 2006-10-02 (+14d) |  | 100d? → 90d? | 337d → 304d |  |  |
| 100 | Encircled Energy (& d-IFU) Performance Requirements | 2006-09-18 → 2006-10-02 (+14d) | 2006-12-08 → 2006-12-22 (+14d) |  | 377d → 334d |  | constraint finish no earlier than 2006-12-08 → start no earlier than 2006-10-02 |
| 113 | Science Requirements Summary Rev 2 |  |  | 13.89d? → 14d? |  |  | constraint finish no earlier than 2007-03-02 → start no earlier than 2007-02-13; resources Max [18%]; Wizinowich [18%]; Other → Max [89.3%]; Wizinowich [17.9%] |
| 120 | Observatory Requirements Rev 2 |  |  |  |  |  | resources Neyman [20%]; Other [41.7%]; Le Mignant [13.3%] → Neyman [20%]; Meguro [8.3%]; Le Mignant [13.3%]; Adkins [8.3%]; Johansson [8.3%]; Chin [8.3%] |
| 134 | **System Design** |  | 2008-02-01 → 2008-01-18 (-14d) | 385d? → 375d? | 77d → 54d |  |  |
| 146 | Agreement between Sky Coverage Codes | 2006-09-18 → 2006-10-16 (+28d) | 2006-10-18 → 2006-11-03 (+16d) | 23d? → 15d? | 222d → 188.5d |  | constraint start no earlier than 2006-09-18 → start no earlier than 2006-10-16; resources Dekany [6.5%]; Gavel [6.5%]; Clare [8.7%] → Dekany [10%]; Gavel [10%]; Clare [13.3%] |
| 150 | Throughput | 2006-09-11 → 2006-10-02 (+21d) |  | 80d? → 65d? | 206d → 194.5d |  | constraint finish no earlier than 2006-12-29 → start no earlier than 2006-10-02; resources Bouchez [5%] → Bouchez [6.2%] |
| 159 | Astrometric Accuracy |  | 2007-01-26 → 2007-06-29 (+154d) | 55d? → 165d? | 186d → 31.17d |  | resources Neyman [9.1%]; Britton [13.6%]; Flicker [9.1%]; Cameron [13.6%]; Wizinowich [9.1%] → Britton [13.6%]; Cameron [13.6%] |
| 161 | Companion Sensitivity |  | 2007-01-26 → 2007-01-09 (-17d) | 55d? → 41.25d? | 175d → 200.25d |  | resources Macintosh [18.2%]; Neyman [18.2%]; Other [18.2%]; Flicker [18.2%] → Macintosh [30.3%]; Neyman [24.2%]; Flicker [18.2%] |
| 162 | Observing Efficiency |  |  |  | 151d → 106.17d |  | resources Le Mignant [8.3%]; Other [58.3%] → Le Mignant [8.3%]; Other [33.3%] |
| 164 | **Performance Budgets Summary** |  | 2007-04-20 → 2007-07-20 (+91d) | 58d? → 123d? | 151d → 64.5d |  |  |
| 166 | Performance Budgets Summary Ver 2 | 2007-03-19 → 2007-07-02 (+105d) | 2007-04-20 → 2007-07-20 (+91d) | 25d? → 15d? | 151d → 97.5d |  | resources Dekany [10%]; Neyman [20%] → Dekany [16.7%]; Neyman [33.3%] |
| 167 | **Science Products** | 2007-07-16 → 2007-07-23 (+7d) |  | 52d? → 47d? | 170d → 137d |  |  |
| 168 | All-In Science Simulations | 2007-07-16 → 2007-07-23 (+7d) | 2007-08-10 → 2007-08-17 (+7d) |  | 183.25d → 178.25d |  |  |
| 169 | **Additional Science Characterization Results** | 2007-08-13 → 2007-08-20 (+7d) |  | 32d? → 27d? | 170d → 137d |  |  |
| 170 | Point Source Sensitivities | 2007-08-13 → 2007-08-20 (+7d) | 2007-09-06 → 2007-09-13 (+7d) |  | 183.25d → 145.25d |  |  |
| 171 | PSF Uniformity & Stability | 2007-08-13 → 2007-08-20 (+7d) | 2007-08-31 → 2007-09-07 (+7d) |  | 187d → 182d |  |  |
| 172 | Other |  |  |  |  |  | resources Other [66.7%] → Flicker [66.7%] |
| 175 | MOAO & MCAO TS |  |  |  | 241d → 252.5d |  | resources none → Gavel [40%] |
| 177 | Adaptive Secondary Mirror option TS (m5) |  |  |  | 166d → 177.5d |  | resources Other [15%]; Wizinowich [10%] → Bauman [15%]; Wizinowich [10%] |
| 186 | AO Enclosure Temperature TS (m6) |  |  |  | 156d → 134.5d |  | resources Bouchez [5.1%]; Meguro [6.8%]; Other [5.1%] → Bouchez [5.1%]; Meguro [6.8%] |
| 194 | LOWFS Architecture TS |  | 2007-02-28 → 2007-02-09 (-19d) | 62.5d? → 50d? | 80.5d → 104.5d |  |  |
| 208 | System Architecture Ver 2 | 2007-05-28 → 2007-07-23 (+56d) | 2007-06-22 → 2007-08-17 (+56d) |  | 126d → 97.5d |  |  |
| 216 | Science Instruments Functional Requirements Ver 1 |  |  |  | 174d → 185.5d |  | resources Adkins [20.8%]; Other [41.7%] → Adkins [20.8%]; Moore [41.7%] |
| 217 | Science Instruments Functional Requirements Ver 2 |  |  |  | 36d → 47.5d |  | resources Adkins [20%]; Other [70%] → Adkins [20%]; Moore [70%] |
| 218 | Technology Drivers Summary | 2007-05-28 → 2007-07-23 (+56d) | 2007-05-31 → 2007-07-26 (+56d) |  | 187.37d → 158.87d |  |  |
| 219 | Technical Risk Analysis Ver 1 | 2007-05-31 → 2007-07-26 (+56d) | 2007-07-03 → 2007-08-28 (+56d) |  | 230.37d → 190.37d |  |  |
| 255 | Laser Pointing & Diagnostics |  |  |  | 210d → 221.5d |  | resources Velur [21.9%]; Kellner [21.9%]; Chin [6.2%] → Velur [21.9%]; Kellner [21.9%]; Chin [6.2%]; Moore [22%] |
| 266 | AO Guide Star Interface |  |  |  | 188d → 166.5d |  | resources Other [11.4%] → Postdoc [11.4%] |
| 267 | Science Observations Simulation Tools |  |  |  | 188d → 166.5d |  | resources Other [22.7%] → Postdoc [22.7%] |
| 269 | Acquisition |  |  |  | 210d → 188.5d |  | resources Other [5.8%] → Postdoc [5.8%] |
| 270 | Observing Sequences |  |  |  | 210d → 188.5d |  | resources Other [5.8%] → Postdoc [5.8%] |
| 271 | Instrument, AO & Telescope Observer Interfaces |  |  |  | 210d → 188.5d |  | resources Other [5.8%] → Johansson [5.8%] |
| 272 | Science Data Quality Monitoring |  |  |  | 210d → 188.5d |  | resources Other [5.8%] → Postdoc [5.8%] |

| ID | Task | Start | Finish | Duration | Total float | Predecessors | Other |
| --- | --- | --- | --- | --- | --- | --- | --- |
| 274 | Generic Data Products |  |  |  | 145d → 123.5d |  | resources Other [6%] → Postdoc [6%] |
| 275 | Science Data Quality Assessment |  |  |  | 145d → 123.5d |  | resources Other [6%] → Postdoc [6%] |
| 276 | Science Data Archiving |  |  |  | 145d → 123.5d |  | resources Other [11.9%] → Postdoc [11.9%] |
| 279 | AO-Instrument Observing Modes |  |  |  | 271d → 249.5d |  | resources Le Mignant [20.8%]; Other [20.8%] → Le Mignant [20.8%]; Postdoc [20.8%] |
| 280 | AO-Instrument Operations Support |  |  |  | 188d → 166.5d |  | resources Other [3%] → Le Mignant [3%] |
| 281 | AO-Instrument Configuration & Setup |  |  |  | 188d → 166.5d |  | resources Other [3%] → Le Mignant [3%] |
| 282 | AO-Instrument Calibrations |  |  |  | 188d → 166.5d |  | resources Other [3%] → van Dam [3%] |
| 283 | AO-Instrument Nighttime Operation Modes |  |  |  | 188d → 166.5d |  | resources Other [3%] → Le Mignant [3%] |
| 284 | AO-Instrument Science Acquisition & Control |  |  |  | 188d → 166.5d |  | resources Other [3%] → Postdoc [3%] |
| 285 | AO-Instrument Health Monitoring & Automated Recovery |  |  |  | 188d → 166.5d |  | resources Other [3%] → Johansson [3%] |
| 287 | AO-Instrument User Interfaces |  |  |  | 166d → 144.5d |  | resources Other [25%] → Johansson [25%] |
| 288 | AO-Instrument Maintenance Plan |  |  |  | 146d → 124.5d |  | resources Other [12.5%] → Chin [12.5%] |
| 290 | AO-Instrument Performance Prediction |  |  |  | 221d → 199.5d |  | resources Flicker [25%]; Other [8.3%] → Flicker [25%]; van Dam [8.3%] |
| 291 | AO-Instrument Real-Time Optimization |  |  |  | 221d → 199.5d |  | resources Flicker [25%]; Other [8.3%] → Flicker [25%]; van Dam [8.3%] |
| 292 | AO-Instrument Environment Monitoring |  |  |  | 206d → 184.5d |  | resources Other [16.7%] → Chin [16.7%] |
| 302 | System Design Manual | 2007-12-31 → 2008-01-01 (+1d) | 2008-02-01 → 2008-01-18 (-14d) | 24d? → 12.5d? | 36d → 13d |  | resources Wizinowich [20.8%]; Dekany [10.4%]; Gavel [10.4%] → Wizinowich [42%]; Dekany [20%]; Gavel [20%] |
| 303 | **Systems Engineering Management Plan (SEMP)** | 2007-01-15 → 2007-03-05 (+49d) | 2008-01-02 → 2007-12-12 (-21d) | 253d? → 202.33d? | 58d → 40.67d |  |  |
| 304 | **Project Plan** | 2007-09-17 → 2007-07-18 (-61d) | 2007-12-07 → 2007-10-11 (-57d) | 59.25d? → 60.57d? | 63d → 40.67d |  |  |
| 305 | WBS and Task Definition | 2007-09-17 → 2007-07-18 (-61d) | 2007-09-21 → 2007-08-16 (-36d) | 4.25d? → 21.43d? | 118d → 73.67d | none → 22FS+5d | was named Task Definition; constraint finish no earlier than 2007-09-21 → none; resources Wizinowich [58.8%]; Dekany [58.8%]; Gavel [58.8%]; Max [58.8%] → Wizinowich [35%]; Dekany [35%]; Gavel [35%]; Max [35%] |
| 306 | Cost Estimation | 2007-10-22 → 2007-08-16 (-67d) | 2007-11-02 → 2007-09-21 (-42d) | 10d? → 25.57d? | 88d → 79.36d | none → 305 | constraint finish no earlier than 2007-11-02 → none; resources Wizinowich [62.5%]; Dekany [62.5%]; Gavel [62.5%]; Other [62.5%] → Wizinowich [4.9%]; Dekany [14.7%]; Gavel [14.7%]; Bauman [14.7%]; Meguro [9.8%]; Johansson [9.8%]; Chin [9.8%]; Velur [14.7%]; Adkins [9.8%]; Le Mignant [4.9%] |
| 307 | Major Project Milestones | 2007-11-09 → 2007-08-16 (-85d) | 2007-11-13 → 2007-08-27 (-78d) | 2.5d? → 6.57d? | 81d → 137.5d | none → 305 | constraint finish no earlier than 2007-11-13 → none; resources Wizinowich [50%]; Dekany [50%] → Wizinowich [19%]; Dekany [38%] |
| 308 | Develop Full Schedule (MS Project Plan) | 2007-12-03 → 2007-09-21 (-73d) | 2007-12-07 → 2007-10-11 (-57d) | 4.5d? → 13.57d? | 63d → 79.36d | none → 306 | was named MS Project Plan; constraint finish no earlier than 2007-12-07 → none; resources Wizinowich [27.8%]; Dekany [27.8%]; Gavel [27.8%]; Max [27.8%] → Wizinowich [36.8%]; Dekany [18.4%]; Gavel [18.4%]; Max [9.2%] |
| 309 | Risk Assessment & Management Plan | 2007-11-14 → 2007-07-18 (-119d) | 2007-12-14 → 2007-09-04 (-101d) | 23d? → 34d? | 58d → 131.5d | none → 305SS | constraint finish no earlier than 2007-12-14 → none; resources Other [21.7%] → Wizinowich [3.7%]; Dekany [5.5%]; Gavel [5.5%] |
| 310 | **Preliminary Design Phase Plan** | 2007-02-05 → 2007-03-05 (+28d) | 2007-08-17 → 2007-11-15 (+90d) | 140d? → 183.64d? | 143d → 46.36d |  |  |
| 311 | Preliminary Design Phase Plan Version 1 (to Support Observatory FY08 Planning) | 2007-02-05 → 2007-03-05 (+28d) | 2007-03-02 → 2007-03-30 (+28d) |  | 263d → 243d |  | was named Version 1 to Support Observatory FY08 Planning; constraint start no earlier than 2007-02-05 → start no earlier than 2007-03-05; resources Wizinowich [10%]; Dekany [6.2%]; Gavel [6.2%]; Max [3.8%] → Wizinowich [9.4%]; Dekany [6.2%]; Gavel [6.2%]; Max [3.1%] |
| 312 | Preliminary Design Phase Plan Version 2 | 2007-04-09 → 2007-08-16 (+129d) | 2007-05-18 → 2007-09-12 (+117d) | 30d? → 18.75d? | 208d → 125.32d | none → 305 | was named Intermediate Versions; resources Wizinowich [7.5%]; Dekany [3.3%]; Gavel [3.3%]; Max [2.5%] → Wizinowich [20%]; Dekany [20%]; Gavel [20%]; Max [20%] |
| 313 | Preliminary Design Phase Plan Final Version | 2007-07-30 → 2007-10-25 (+87d) | 2007-08-17 → 2007-11-15 (+90d) | 15d? → 15.57d? | 143d → 79.36d | none → 308FS+2w | was named Final Version; constraint start no earlier than 2007-07-30 → none; resources Wizinowich [26.7%]; Dekany [16.7%]; Gavel [16.7%]; Max [10%] → Wizinowich [26.7%]; Dekany [14.4%]; Gavel [14.4%]; Max [10%] |
| 314 | **Integration and Test Plans** | 2007-03-12 → 2007-08-16 (+157d) | 2007-11-27 → 2007-11-23 (-4d) | 187d? → 70.4d? | 71d → 40.67d |  |  |
| 315 | **Subsystem Testing Plans** | 2007-10-29 → 2007-08-16 (-74d) | 2007-11-27 → 2007-11-23 (-4d) | 22d? → 70.4d? | 71d → 40.67d |  |  |
| 316 | AO System Test Plan | 2007-10-29 → 2007-08-16 (-74d) | 2007-11-27 → 2007-09-11 (-77d) | 22d? → 17.6d? | 71d → 73.67d | none → 305 | constraint start no earlier than 2007-10-29 → none |
| 317 | Laser System Test Plan | 2007-10-29 → 2007-09-11 (-48d) | 2007-11-27 → 2007-10-05 (-53d) | 22d? → 17.6d? | 71d → 73.67d | none → 316 | constraint start no earlier than 2007-10-29 → none |
| 318 | Science Operations Test Plan | 2007-10-29 → 2007-10-05 (-24d) | 2007-11-27 → 2007-10-30 (-28d) | 22d? → 17.6d? | 71d → 73.67d | none → 317 | constraint start no earlier than 2007-10-29 → none |
| 319 | Science Instruments Test Plan | 2007-10-29 → 2007-10-30 (+1d) | 2007-11-27 → 2007-11-23 (-4d) | 22d? → 17.6d? | 71d → 73.67d | none → 318 | constraint start no earlier than 2007-10-29 → none |
| 320 | System Integration & Test Plans | 2007-03-12 → 2007-08-16 (+157d) | 2007-04-20 → 2007-09-27 (+160d) |  | 228d → 114.07d | none → 305 | constraint finish no earlier than 2007-04-20 → none |
| 321 | Configuration Management Plan | 2007-01-15 → 2007-08-16 (+213d) | 2007-04-11 → 2007-11-13 (+216d) |  | 235.5d → 81.57d | none → 305 | resources Johnson [10%]; Other [10%]; Chin [5%] → Johnson [10%]; Randolph [10%]; Chin [5%] |
| 322 | Project Management Plan | 2007-02-12 → 2007-10-11 (+241d) | 2007-03-09 → 2007-11-08 (+244d) |  | 258d → 84.93d | none → 308 |  |
| 323 | SEMP Document | 2007-12-17 → 2007-11-23 (-24d) | 2008-01-02 → 2007-12-12 (-21d) |  | 58d → 73.67d |  | constraint finish no earlier than 2008-01-02 → none |

## Version 9 (saved 2006-09-29, file NGAO_SD_schedule_v17.mpp)

Last finish 2008-04-03 → 2008-04-17 (+14d).

Changed:

| ID | Task | Start | Finish | Duration | Total float | Predecessors | Other |
| --- | --- | --- | --- | --- | --- | --- | --- |
| 1 | **SD Phase Management** |  | 2008-04-03 → 2008-04-17 (+14d) | 467d? → 476.33d? |  |  |  |
| 2 | **Planning and Contracting** |  | 2007-09-05 → 2007-11-14 (+70d) | 315.26d? → 365.26d? | 151.74d → 111.07d |  |  |
| 10 | FY08 Replan | 2007-08-16 → 2007-10-25 (+70d) | 2007-09-05 → 2007-11-14 (+70d) |  | 184.74d → 111.07d |  |  |
| 42 | **System Design Report & Review** | 2007-09-17 → 2007-10-01 (+14d) | 2008-03-17 → 2008-04-17 (+31d) | 131d? → 143.33d? | 13d → 0d |  |  |
| 43 | System Design Report | 2008-01-21 → 2008-02-20 (+30d) | 2008-01-30 → 2008-03-03 (+33d) |  | 46d → 0d |  |  |
| 44 | **System Design Review** | 2007-09-17 → 2007-10-01 (+14d) | 2008-03-17 → 2008-04-17 (+31d) | 131d? → 143.33d? | 13d → 0d |  |  |
| 45 | Identify Reviewers | 2007-09-17 → 2007-10-01 (+14d) |  | 65d? → 55d? | 83d → 59.33d |  | constraint start no earlier than 2007-09-17 → start no earlier than 2007-10-01; resources Adkins(IPM) [1.9%]; Wizinowich [0.4%]; Max [0.2%]; Gavel [0.2%]; Dekany [0.2%] → Adkins(IPM) [2.3%]; Wizinowich [0.5%]; Max [0.2%]; Gavel [0.2%]; Dekany [0.2%] |
| 46 | Review Package Distributed | 2008-01-31 → 2008-03-03 (+32d) | 2008-01-31 → 2008-03-04 (+33d) |  | 50d → 4d |  |  |
| 47 | Reviewer Comments Addressed | 2008-02-15 → 2008-03-18 (+32d) | 2008-02-21 → 2008-03-25 (+33d) |  | 50d → 4d |  |  |
| 48 | System Design Review Support | 2008-01-31 → 2008-03-03 (+32d) | 2008-02-27 → 2008-03-31 (+33d) |  | 13d → 0d |  |  |
| 49 | System Design Review Meeting | 2008-02-27 → 2008-03-31 (+33d) | 2008-02-27 → 2008-03-31 (+33d) |  | 46d → 0d |  |  |
| 50 | Reviewer Report Received | 2008-03-12 → 2008-04-14 (+33d) | 2008-03-12 → 2008-04-14 (+33d) |  | 46d → 0d |  |  |
| 51 | Response to Reviewer Report & Distribution | 2008-03-13 → 2008-04-14 (+32d) | 2008-03-17 → 2008-04-17 (+31d) |  | 46d → 0d |  |  |
| 124 | **Traceability Matrix** |  |  |  | 109d → 118.33d |  | was named Tracability Matrix |
| 125 | Traceability Matrix Rev 1 |  |  |  | 402d → 378.33d |  | was named Tracability Matrix Rev 1 |
| 126 | Traceability Matrix Rev 2 |  |  |  | 310d → 286.33d |  | was named Tracability Matrix Rev 2 |
| 127 | Traceability Matrix Rev 3 |  |  |  | 223d → 199.33d |  | was named Tracability Matrix Rev 3 |
| 128 | Traceability Matrix Rev 4 |  |  |  | 101d → 77.33d |  | was named Tracability Matrix Rev 4 |
| 136 | **Performance Budgets** |  | 2007-09-25 → 2007-12-12 (+78d) | 292d? → 348d? | 129.5d → 90.33d |  |  |
| 163 | Observing Uptime | 2007-02-05 → 2007-11-05 (+273d) | 2007-03-16 → 2007-12-12 (+271d) | 30d? → 28d? | 106.17d → 90.33d |  | constraint start no earlier than 2007-02-05 → start no earlier than 2007-11-05; resources Chin [16.7%]; Johansson [16.7%] → Chin [17.9%]; Johansson [17.9%] |
| 166 | Performance Budgets Summary Ver 2 |  |  |  | 97.5d → 73.83d | 154, 157, 158, 159, 160, 161, 162, 163, 150, 151 → 154, 157, 158, 159, 160, 161, 162, 150, 151 |  |
| 167 | **Science Products** |  | 2007-09-25 → 2007-10-19 (+24d) | 47d? → 65d? | 137d → 128.33d |  |  |
| 169 | **Additional Science Characterization Results** |  | 2007-09-25 → 2007-10-19 (+24d) | 27d? → 45d? | 137d → 128.33d |  |  |
| 172 | Other | 2007-09-05 → 2007-10-01 (+26d) | 2007-09-25 → 2007-10-19 (+24d) |  | 170d → 128.33d |  | constraint start no earlier than 2007-09-05 → start no earlier than 2007-10-01 |
| 216 | Science Instruments Function Allocation Ver 1 |  | 2007-05-22 → 2007-05-14 (-8d) | 24d? → 18d? | 185.5d → 167.83d |  | was named Science Instruments Functional Requirements Ver 1; resources Adkins [20.8%]; Moore [41.7%] → Adkins [20.8%]; Moore [34.7%] |
| 217 | Science Instruments Function Allocation Ver 2 |  | 2007-11-30 → 2007-11-14 (-16d) | 25d? → 12.5d? | 47.5d → 36.33d |  | was named Science Instruments Functional Requirements Ver 2; resources Adkins [20%]; Moore [70%] → Adkins [20%]; Moore [60%] |
| 221 | **AO System** | 2007-02-05 → 2007-03-05 (+28d) | 2007-12-12 → 2007-12-14 (+2d) | 223d? → 205d? | 26.5d → 33.83d |  |  |
| 222 | AO System Architecture |  |  |  | 184.5d → 160.83d |  | resources Neyman [33.3%]; Other [35.4%] → Neyman [13.9%]; Gavel [8.3%]; Johansson [11.1%]; Bauman [11.1%]; Velur [11.1%]; Wizinowich [5.6%]; Dekany [5.6%] |
| 224 | **Opto-mechanical** | 2007-03-05 → 2007-04-02 (+28d) | 2007-12-12 → 2007-12-14 (+2d) | 203d? → 185d? | 26.5d → 33.83d |  |  |
| 228 | Optical Support Structure | 2007-08-16 → 2007-10-01 (+46d) | 2007-10-12 → 2007-11-16 (+35d) | 41.25d? → 35d? | 103.25d → 53.83d |  | constraint start no earlier than 2007-04-16 → finish no earlier than 2007-11-16; resources Lockwood [9.1%]; Bauman [4.5%] → Lockwood [10.7%]; Bauman [5.4%] |
| 229 | **Wavefront Sensors** | 2007-04-16 → 2007-05-07 (+21d) |  | 173d? → 158d? | 26.5d → 35.83d |  |  |
| 230 | High Order LGS Wavefront Sensors | 2007-04-16 → 2007-05-07 (+21d) |  | 173d? → 158d? | 59.5d → 35.83d |  | constraint start no earlier than 2007-04-16 → start no earlier than 2007-05-07; resources Velur [4.3%]; Meguro [1.4%] → Velur [4.7%]; Meguro [1.6%] |
| 231 | High Order NGS Wavefront Sensor | 2007-04-16 → 2007-05-07 (+21d) |  | 173d? → 158d? | 59.5d → 35.83d |  | constraint start no earlier than 2007-04-16 → start no earlier than 2007-05-07; resources Velur [2.2%]; Meguro [0.7%] → Velur [2.4%]; Meguro [0.8%] |
| 232 | Low Order NGS Wavefront Sensors | 2007-04-16 → 2007-05-07 (+21d) |  | 173d? → 158d? | 26.5d → 35.83d |  | constraint finish no earlier than 2007-12-12 → start no earlier than 2007-05-07; resources Kellner [2.9%]; Meguro [1.4%]; Velur [1.4%] → Kellner [3.2%]; Meguro [1.6%]; Velur [1.6%] |
| 234 | **Wavefront Correctors** | 2007-03-05 → 2007-04-02 (+28d) | 2007-06-29 → 2007-11-30 (+154d) | 85d? → 175d? | 144.5d → 43.83d |  |  |
| 235 | Tip/Tilt Corrector | 2007-03-05 → 2007-10-01 (+210d) | 2007-06-29 → 2007-11-30 (+154d) | 85d? → 45d? | 177.5d → 43.83d |  | constraint start no earlier than 2007-03-05 → start no earlier than 2007-10-01; resources Flicker [1.5%]; Bauman [1.5%] → Flicker [2.8%]; Bauman [2.8%] |
| 236 | Deformable Mirror | 2007-03-05 → 2007-04-02 (+28d) |  | 85d? → 65d? | 177.5d → 153.83d |  | constraint start no earlier than 2007-03-05 → start no earlier than 2007-04-02; resources Flicker [5.9%]; Bauman [11.8%]; Dekany [15%] → Flicker [7.7%]; Bauman [11.8%]; Dekany [15%] |
| 237 | **Acquisition Cameras** | 2007-03-05 → 2007-10-01 (+210d) | 2007-08-24 → 2007-10-26 (+63d) | 125d? → 20d? | 104.5d → 68.83d |  |  |
| 238 | NGS Acquisition Camera | 2007-03-05 → 2007-10-01 (+210d) | 2007-08-24 → 2007-10-26 (+63d) | 125d? → 20d? | 104.5d → 68.83d |  | constraint start no earlier than 2007-03-05 → finish no earlier than 2007-10-26; resources Bouchez [2%] → Bouchez [12.5%] |
| 239 | LGS Acquisition Camera | 2007-03-05 → 2007-10-01 (+210d) | 2007-08-24 → 2007-10-26 (+63d) | 125d? → 20d? | 104.5d → 68.83d |  | constraint start no earlier than 2007-03-05 → finish no earlier than 2007-10-26; resources Bouchez [2%] → Bouchez [12.5%] |
| 240 | Atmospheric Dispersion Correction | 2007-03-05 → 2007-08-20 (+168d) | 2007-06-29 → 2007-12-14 (+168d) |  | 177.5d → 33.83d |  | constraint start no earlier than 2007-03-05 → start no earlier than 2007-08-20 |
| 241 | Alignment, Calibration, Diagnostics, Metrology and Monitoring | 2007-03-05 → 2007-04-02 (+28d) |  | 85d? → 65d? | 177.5d → 153.83d |  | constraint finish no earlier than 2007-06-29 → start no earlier than 2007-04-02; resources Neyman [4.4%]; Flicker [4.4%] → Neyman [5.8%]; Flicker [5.8%] |
| 242 | **Non-real-time Control** | 2007-05-01 → 2007-06-25 (+55d) | 2007-10-22 → 2007-11-23 (+32d) | 125d? → 110d? | 63.5d → 48.83d |  |  |
| 243 | Non-RTC Software | 2007-05-17 → 2007-06-25 (+39d) | 2007-07-27 → 2007-08-31 (+35d) | 51.2d? → 50d? | 157.5d → 108.83d |  | constraint finish no earlier than 2007-07-27 → start no earlier than 2007-06-25; resources Johansson [19.5%]; Stomski [19.5%]; Johnson [9.8%] → Johansson [20%]; Stomski [20%]; Johnson [10%] |
| 244 | Non-RTC Electronics | 2007-05-01 → 2007-07-23 (+83d) | 2007-10-22 → 2007-11-23 (+32d) | 125d? → 90d? | 96.5d → 48.83d |  | constraint start no earlier than 2007-05-01 → start no earlier than 2007-07-23; resources Chin [10%]; Reinig [10%] → Chin [13.9%]; Reinig [13.9%] |
| 245 | **Real-time Control** | 2007-02-05 → 2007-03-05 (+28d) | 2007-07-06 → 2007-08-07 (+32d) | 110d? → 112d? | 139.5d → 126.83d |  |  |
| 246 | RTC Architecture Analysis and Design Study | 2007-02-05 → 2007-03-05 (+28d) | 2007-04-04 → 2007-05-04 (+30d) | 43d? → 45d? | 172.5d → 126.83d |  | constraint start no earlier than 2007-02-05 → finish no earlier than 2007-05-04; resources Gavel [5.8%]; Johansson [11.6%]; Flicker [11.6%]; Reinig [23.3%] → Gavel [5.6%]; Johansson [11.1%]; Flicker [11.1%]; Reinig [22.2%] |
| 247 | RTC Software Module Definition | 2007-04-05 → 2007-05-07 (+32d) | 2007-07-06 → 2007-08-07 (+32d) |  | 172.5d → 126.83d |  |  |
| 248 | RTC Hardware Module Definition | 2007-04-05 → 2007-05-07 (+32d) | 2007-07-06 → 2007-08-07 (+32d) |  | 172.5d → 126.83d |  |  |
| 249 | **Laser Facility** |  | 2007-08-03 → 2007-12-14 (+133d) | 109d? → 204d? | 119.5d → 33.83d |  |  |
| 253 | **Laser Launch Facility** | 2007-03-06 → 2007-04-09 (+34d) | 2007-04-30 → 2007-06-01 (+32d) |  | 188.5d → 173.83d |  |  |
| 254 | Laser Beam Transport | 2007-03-06 → 2007-04-09 (+34d) | 2007-04-30 → 2007-06-01 (+32d) |  | 221.5d → 173.83d |  | constraint none → start no earlier than 2007-04-09 |
| 255 | Laser Pointing & Diagnostics | 2007-03-06 → 2007-04-09 (+34d) | 2007-04-30 → 2007-06-01 (+32d) |  | 221.5d → 173.83d |  | constraint none → start no earlier than 2007-04-09 |
| 256 | Laser Launch Telescope | 2007-03-06 → 2007-04-09 (+34d) | 2007-04-13 → 2007-06-01 (+49d) | 28.12d? → 40d? | 233.38d → 173.83d |  | constraint none → finish no earlier than 2007-06-01; resources Velur [22.2%]; Kellner [22.2%]; Chin [11.1%] → Velur [15.6%]; Kellner [15.6%]; Chin [11.1%] |
| 257 | **Laser Safety Systems** | 2007-07-09 → 2007-10-08 (+91d) | 2007-08-03 → 2007-11-02 (+91d) |  | 119.5d → 63.83d |  |  |
| 258 | Personnel and Equipment Safety Systems | 2007-07-09 → 2007-10-08 (+91d) | 2007-08-03 → 2007-11-02 (+91d) |  | 152.5d → 63.83d |  | constraint start no earlier than 2007-07-09 → start no earlier than 2007-10-08 |
| 259 | Aircraft, Satellite & Laser Traffic Control Safety Systems | 2007-07-09 → 2007-10-08 (+91d) | 2007-08-03 → 2007-11-02 (+91d) |  | 152.5d → 63.83d |  | constraint start no earlier than 2007-07-09 → start no earlier than 2007-10-08 |
| 260 | **Laser System Control** | 2007-04-09 → 2007-10-01 (+175d) | 2007-08-03 → 2007-12-14 (+133d) | 85d? → 55d? | 119.5d → 33.83d |  |  |
| 261 | Laser System Software | 2007-04-09 → 2007-10-01 (+175d) | 2007-08-03 → 2007-12-14 (+133d) | 85d? → 55d? | 152.5d → 33.83d |  | constraint start no earlier than 2007-04-09 → finish no earlier than 2007-12-14; resources Johansson [5.9%]; Stomski [5.9%] → Johansson [9.1%]; Stomski [9.1%] |
| 262 | Laser System Electronics | 2007-04-09 → 2007-10-01 (+175d) | 2007-08-03 → 2007-12-14 (+133d) | 85d? → 55d? | 152.5d → 33.83d |  | constraint start no earlier than 2007-04-09 → finish no earlier than 2007-12-14; resources Chin [10.3%] → Chin [15.9%] |
| 263 | **Science Operations** |  | 2007-08-03 → 2007-12-14 (+133d) | 154d? → 249d? | 119.5d → 33.83d |  |  |
| 264 | **Astronomical Observations Operations** |  | 2007-07-30 → 2007-12-14 (+137d) | 108d? → 207d? | 123.5d → 33.83d |  |  |
| 268 | **Observing Interfaces** |  | 2007-04-30 → 2007-12-14 (+228d) | 43d? → 207d? | 188.5d → 33.83d |  |  |
| 272 | Science Data Quality Monitoring | 2007-03-01 → 2007-10-17 (+230d) | 2007-04-30 → 2007-12-14 (+228d) |  | 188.5d → 33.83d |  | constraint start no earlier than 2007-03-01 → finish no earlier than 2007-12-14 |
| 273 | **Post-Observing Interfaces** | 2007-06-01 → 2007-10-01 (+122d) | 2007-07-30 → 2007-11-27 (+120d) |  | 123.5d → 46.83d |  |  |
| 274 | Generic Data Products | 2007-06-01 → 2007-10-01 (+122d) | 2007-07-30 → 2007-11-27 (+120d) |  | 123.5d → 46.83d |  | constraint finish no earlier than 2007-07-30 → start no earlier than 2007-10-01 |
| 275 | Science Data Quality Assessment | 2007-06-01 → 2007-10-01 (+122d) | 2007-07-30 → 2007-11-27 (+120d) |  | 123.5d → 46.83d |  | constraint start no earlier than 2007-06-01 → start no earlier than 2007-10-01 |
| 276 | Science Data Archiving | 2007-06-01 → 2007-10-01 (+122d) | 2007-07-30 → 2007-11-27 (+120d) |  | 123.5d → 46.83d |  | constraint start no earlier than 2007-06-01 → start no earlier than 2007-10-01 |
| 277 | **AO-Instrument Operations** |  | 2007-08-03 → 2007-10-26 (+84d) | 154d? → 214d? | 119.5d → 68.83d |  |  |
| 278 | **AO-Instrument Operations Architecture** |  | 2007-08-03 → 2007-10-26 (+84d) | 154d? → 214d? | 119.5d → 68.83d |  |  |

| ID | Task | Start | Finish | Duration | Total float | Predecessors | Other |
| --- | --- | --- | --- | --- | --- | --- | --- |
| 281 | AO-Instrument Configuration & Setup | 2007-02-05 → 2007-07-04 (+149d) | 2007-05-30 → 2007-10-26 (+149d) |  | 166.5d → 68.83d |  | constraint start no earlier than 2007-02-05 → finish no earlier than 2007-10-26 |
| 282 | AO-Instrument Calibrations | 2007-02-05 → 2007-06-04 (+119d) | 2007-05-30 → 2007-09-26 (+119d) |  | 166.5d → 90.83d |  | constraint start no earlier than 2007-02-05 → start no earlier than 2007-06-04 |
| 283 | AO-Instrument Nighttime Operation Modes | 2007-02-05 → 2007-06-04 (+119d) | 2007-05-30 → 2007-09-26 (+119d) |  | 166.5d → 90.83d |  | constraint start no earlier than 2007-02-05 → start no earlier than 2007-06-04 |
| 284 | AO-Instrument Science Acquisition & Control | 2007-02-05 → 2007-07-02 (+147d) | 2007-05-30 → 2007-10-24 (+147d) |  | 166.5d → 70.83d |  | constraint start no earlier than 2007-02-05 → start no earlier than 2007-07-02 |
| 285 | AO-Instrument Health Monitoring & Automated Recovery | 2007-02-05 → 2007-06-11 (+126d) | 2007-05-30 → 2007-10-03 (+126d) |  | 166.5d → 85.83d |  | constraint start no earlier than 2007-02-05 → start no earlier than 2007-06-11 |
| 286 | AO-Instrument Laser Traffic Control | 2007-07-09 → 2007-10-01 (+84d) | 2007-08-03 → 2007-10-26 (+84d) |  | 152.5d → 68.83d |  | constraint start no earlier than 2007-07-09 → start no earlier than 2007-10-01 |
| 287 | AO-Instrument User Interfaces | 2007-06-04 → 2007-10-01 (+119d) | 2007-06-29 → 2007-10-26 (+119d) |  | 144.5d → 68.83d |  | constraint finish no earlier than 2007-06-29 → start no earlier than 2007-10-01 |
| 288 | AO-Instrument Maintenance Plan | 2007-07-02 → 2007-10-01 (+91d) | 2007-07-27 → 2007-10-26 (+91d) |  | 124.5d → 68.83d |  | constraint finish no earlier than 2007-07-27 → start no earlier than 2007-10-01 |
| 293 | **Science Instruments** |  | 2007-09-17 → 2007-11-16 (+60d) | 251d? → 295d? | 88.5d → 53.83d |  |  |
| 294 | OSIRIS |  |  |  | 261.83d → 238.16d |  | resources Adkins [3%]; Other [24.4%] → Adkins [3%]; Other [15.8%] |
| 295 | Interferometer |  |  |  | 242.5d → 218.83d |  | resources Adkins [1.5%]; Neyman [7.7%]; Other [10%] → Adkins [1.5%]; Neyman [3.8%]; Other [3.3%]; Wizinowich [1%] |
| 296 | OHANA |  |  |  | 234.5d → 210.83d |  | resources Adkins [2%]; Other [11.2%]; Woillez [15%] → Adkins [2%]; Neyman [2%]; Woillez [6%] |
| 297 | Near-IR Imager | 2006-10-02 → 2006-11-06 (+35d) | 2007-04-27 → 2007-05-25 (+28d) | 150d? → 145d? | 222.5d → 178.83d |  | constraint start no earlier than 2006-10-02 → start no earlier than 2006-11-06; resources Adkins [2%]; Other [31.6%] → Adkins [2.1%]; Moore [15.2%] |
| 298 | Visible Imager | 2006-10-02 → 2007-05-14 (+224d) | 2007-04-27 → 2007-11-09 (+196d) | 150d? → 130d? | 222.5d → 58.83d |  | constraint start no earlier than 2006-10-02 → start no earlier than 2007-05-14; resources Adkins [2%]; Other [31.6%] → Adkins [2.3%]; Moore [16.9%] |
| 299 | Visible IFU | 2007-01-02 → 2007-07-02 (+181d) | 2007-05-21 → 2007-11-16 (+179d) |  | 206.5d → 53.83d |  | constraint start no earlier than 2007-01-02 → start no earlier than 2007-07-02; resources Adkins [2%]; Other [16.4%] → Adkins [2%]; Moore [10.5%] |
| 300 | Deployable Near-IR IFU |  |  |  | 179.5d → 155.83d |  | resources Adkins [7.1%]; Other [35.7%]; Neyman [16.7%] → Adkins [7.1%]; Moore [16.7%]; Neyman [16.7%]; Other [19%] |
| 301 | Thermal Near-IR Imager | 2007-05-01 → 2007-07-09 (+69d) | 2007-09-17 → 2007-11-16 (+60d) | 100d? → 95d? | 121.5d → 53.83d |  | was named Mid-IR IFU; constraint start no earlier than 2007-05-01 → start no earlier than 2007-07-09; resources Adkins [1%]; Other [23.9%] → Adkins [1.1%]; Moore [5.5%] |
| 303 | **Systems Engineering Management Plan (SEMP)** |  | 2007-12-12 → 2008-02-20 (+70d) | 202.33d? → 252.33d? | 40.67d → 0d |  |  |
| 304 | **Project Plan** | 2007-07-18 → 2007-09-26 (+70d) | 2007-10-11 → 2007-12-20 (+70d) |  | 40.67d → 0d |  |  |
| 305 | WBS and Task Definition | 2007-07-18 → 2007-09-26 (+70d) | 2007-08-16 → 2007-10-25 (+70d) |  | 73.67d → 0d | 22FS+5d → 22FS+55d |  |
| 306 | Cost Estimation | 2007-08-16 → 2007-10-25 (+70d) | 2007-09-21 → 2007-11-30 (+70d) |  | 79.36d → 5.69d |  |  |
| 307 | Major Project Milestones | 2007-08-16 → 2007-10-25 (+70d) | 2007-08-27 → 2007-11-05 (+70d) |  | 137.5d → 63.83d |  |  |
| 308 | Develop Full Schedule (MS Project Plan) | 2007-09-21 → 2007-11-30 (+70d) | 2007-10-11 → 2007-12-20 (+70d) |  | 79.36d → 5.69d |  |  |
| 309 | Risk Assessment & Management Plan | 2007-07-18 → 2007-09-26 (+70d) | 2007-09-04 → 2007-11-13 (+70d) |  | 131.5d → 57.83d |  |  |
| 310 | **Preliminary Design Phase Plan** |  | 2007-11-15 → 2008-01-24 (+70d) | 183.64d? → 233.64d? | 46.36d → 5.69d |  |  |
| 312 | Preliminary Design Phase Plan Version 2 | 2007-08-16 → 2007-10-25 (+70d) | 2007-09-12 → 2007-11-21 (+70d) |  | 125.32d → 51.65d |  |  |
| 313 | Preliminary Design Phase Plan Final Version | 2007-10-25 → 2008-01-03 (+70d) | 2007-11-15 → 2008-01-24 (+70d) |  | 79.36d → 5.69d |  |  |
| 314 | **Integration and Test Plans** | 2007-08-16 → 2007-10-25 (+70d) | 2007-11-23 → 2008-02-01 (+70d) |  | 40.67d → 0d |  |  |
| 315 | **Subsystem Testing Plans** | 2007-08-16 → 2007-10-25 (+70d) | 2007-11-23 → 2008-02-01 (+70d) |  | 40.67d → 0d |  |  |
| 316 | AO System Test Plan | 2007-08-16 → 2007-10-25 (+70d) | 2007-09-11 → 2007-11-20 (+70d) |  | 73.67d → 0d |  |  |
| 317 | Laser System Test Plan | 2007-09-11 → 2007-11-20 (+70d) | 2007-10-05 → 2007-12-14 (+70d) |  | 73.67d → 0d |  |  |
| 318 | Science Operations Test Plan | 2007-10-05 → 2007-12-14 (+70d) | 2007-10-30 → 2008-01-08 (+70d) |  | 73.67d → 0d |  |  |
| 319 | Science Instruments Test Plan | 2007-10-30 → 2008-01-08 (+70d) | 2007-11-23 → 2008-02-01 (+70d) |  | 73.67d → 0d |  |  |
| 320 | System Integration & Test Plans | 2007-08-16 → 2007-10-25 (+70d) | 2007-09-27 → 2007-12-06 (+70d) |  | 114.07d → 40.4d |  |  |
| 321 | Configuration Management Plan | 2007-08-16 → 2007-10-25 (+70d) | 2007-11-13 → 2008-01-22 (+70d) |  | 81.57d → 7.9d |  |  |
| 322 | Project Management Plan | 2007-10-11 → 2007-12-20 (+70d) | 2007-11-08 → 2008-01-17 (+70d) |  | 84.93d → 11.26d |  |  |
| 323 | SEMP Document | 2007-11-23 → 2008-02-01 (+70d) | 2007-12-12 → 2008-02-20 (+70d) |  | 73.67d → 0d |  |  |

## Version 10 (saved 2007-03-30, file NGAO_SD_schedule_v20_tracked.mpp)

Last finish stays 2008-04-17. Complete tasks 0 → 26.

Changed:

| ID | Task | Start | Finish | Complete | Total float | Other |
| --- | --- | --- | --- | --- | --- | --- |
| 1 | **SD Phase Management** | 2006-06-21 A |  | 0% → 28% |  |  |
| 2 | **Planning and Contracting** | 2006-06-21 A |  | 0% → 69% |  |  |
| 3 | NGAO Proposal to SSC | 2006-06-21 A | 2006-06-21 A | 0% → 100% | 455.33d → none |  |
| 4 | Management Structure Decision by Directors | 2006-07-14 A | 2006-07-14 A | 0% → 100% | 438.33d → none |  |
| 5 | SD Phase System Engineering Management Plan | 2006-09-01 A | 2006-09-29 A | 0% → 100% | 403.33d → none |  |
| 6 | SD Phase Contracts Generated | 2006-09-27 A | 2006-10-27 A | 0% → 100% | 383.33d → none |  |
| 7 | Director Approval | 2006-10-09 A |  | 0% → 75% |  |  |
| 8 | SD Partner Contracts Issued | 2006-10-27 A | 2006-10-27 A | 0% → 100% | 383.33d → none |  |
| 9 | Mid-year Replan | 2007-03-05 A |  | 0% → 25% |  |  |
| 11 | **Project Meetings** | 2006-06-21 A |  | 0% → 24% |  |  |
| 12 | Executive Committee Telecons | 2006-06-21 A |  | 0% → 43% |  |  |
| 14 | **Team Meetings** | 2006-09-14 A |  | 0% → 35% |  |  |
| 15 | Team Meeting #1 (mgmt, science & technical - Irvine) | 2006-09-14 A | 2006-09-14 A | 0% → 100% | 414.33d → none |  |
| 16 | Team Meeting #2 (CIT) | 2006-11-07 → 2006-11-14 A (+7d) | 2006-11-07 → 2006-11-14 A (+7d) | 0% → 100% | 376.33d → none | constraint start no earlier than 2006-11-07 → start no earlier than 2006-11-14 |
| 17 | Team Videocon #3 | 2006-12-13 A | 2006-12-13 A | 0% → 100% | 350.83d → none |  |
| 18 | Team Meeting #4 (Keck) | 2007-01-22 A | 2007-01-22 A | 0% → 100% | 322.33d → none |  |
| 19 | Team Videocon #5 | 2007-03-07 A | 2007-03-07 A | 0% → 100% | 290.83d → none |  |
| 28 | **Tracking and Reporting** | 2006-09-16 A |  | 0% → 40% |  |  |
| 29 | Report Preparation/Presentation | 2006-10-02 A |  | 0% → 40% | 90.83d → 0d |  |
| 30 | Keck Science Meeting 06 (UCI) | 2006-09-16 A | 2006-09-16 A | 0% → 100% | 413.33d → none |  |
| 31 | SSC meeting (UCLA) | 2006-11-06 A | 2006-11-06 A | 0% → 100% | 378.33d → none |  |
| 32 | SSC meeting (Keck) | 2007-01-24 A | 2007-01-24 A | 0% → 100% | 321.33d → none |  |
| 33 | SSC meeting (CA) | 2007-04-03 A |  | 0% → 25% |  |  |
| 52 | **System Requirements** | 2006-10-02 A |  | 0% → 35% | 107.33d → 118.33d |  |
| 53 | **Science Requirements** | 2006-10-02 A |  | 0% → 34% |  |  |
| 54 | **Solar System Science Requirements** | 2006-10-02 A |  | 0% → 44% |  |  |
| 55 | **Companions & Multiplicity of Small Solar System Bodies** | 2006-10-02 A |  | 0% → 49% |  |  |
| 56 | Point Source Companion Sensitivity Requirements | 2006-10-02 A |  | 0% → 40% |  |  |
| 57 | Spectral Sensitivity & Spectral Resolution Requirements | 2006-10-02 A |  | 0% → 60% |  |  |
| 58 | Observing Scenarios | 2006-12-04 A |  | 0% → 25% |  |  |
| 59 | Science Instrument Requirements | 2006-12-04 A |  | 0% → 70% |  |  |
| 60 | **Moons of the Giant Planets** | 2006-12-04 A |  | 0% → 31% |  |  |
| 61 | Performance Requirements | 2006-12-04 A |  | 0% → 10% |  |  |
| 62 | Observing Scenarios | 2007-01-29 A |  | 0% → 50% |  |  |
| 63 | Science Instrument Requirements | 2007-01-29 A |  | 0% → 40% |  |  |
| 64 | **Shape & Size of Asteroids** | 2007-01-29 A |  | 0% → 49% |  |  |
| 65 | Spatial Resolution Requirements | 2007-01-29 A |  | 0% → 45% |  |  |
| 66 | Spectral Sensitivity & Spectral Resolution Requirements | 2007-01-29 A |  | 0% → 60% |  |  |
| 67 | Observing Scenarios | 2007-03-05 A |  | 0% → 20% |  |  |
| 68 | Science Instrument Requirements | 2007-03-05 A |  | 0% → 70% |  |  |
| 69 | **Galactic Science Requirements** | 2006-10-02 A |  | 0% → 27% |  |  |
| 70 | **Galactic Center Proper Motions: Astrometry** | 2006-10-02 A |  | 0% → 46% |  |  |
| 71 | Astrometry requirements | 2006-10-02 A |  | 0% → 40% |  |  |
| 72 | Observing Scenarios | 2006-11-27 A |  | 0% → 50% |  |  |
| 73 | Science Instrument Requirements | 2006-11-27 A |  | 0% → 50% |  |  |
| 74 | **Galactic Center Radial Velocities & Stellar Populations: Integral Field Spectroscopy** | 2006-11-27 A |  | 0% → 53% |  |  |
| 75 | Performance Requirements | 2006-11-27 A |  | 0% → 50% |  |  |
| 76 | Observing Scenarios | 2007-01-29 A |  | 0% → 50% |  |  |
| 77 | Science Instrument Requirements | 2007-01-29 A |  | 0% → 60% |  |  |
| 78 | **Galactic Center Nature of Sgr A*: 3-5 um Color & 2 um Polarimetry Variability** | 2007-01-29 A |  | 0% → 10% |  |  |
| 79 | Performance Requirements | 2007-01-29 A |  | 0% → 10% |  |  |
| 80 | Observing Scenarios | 2007-03-05 A |  | 0% → 10% |  |  |
| 81 | Science Instrument Requirements | 2007-03-05 A |  | 0% → 10% |  |  |
| 82 | **Planets around Low Mass Stars & Brown Dwarfs: Companion Sensitivity** | 2006-10-02 A |  | 0% → 32% |  |  |
| 83 | Companion Sensitivity Performance Requirements | 2006-10-02 A |  | 0% → 35% |  |  |
| 84 | Observing Scenarios | 2006-11-27 A |  | 0% → 40% |  |  |
| 85 | Science Instrument Requirements | 2006-11-27 A |  | 0% → 20% |  |  |
| 86 | **Debris Disks, Protostellar Envelopes & Outflows: Contrast** | 2007-01-29 A |  | 0% → 10% |  |  |
| 87 | Contrast Performance Requirements | 2007-01-29 A |  | 0% → 10% |  |  |
| 88 | Observing Scenarios | 2007-03-05 A |  | 0% → 10% |  |  |
| 89 | Science Instrument Requirements | 2007-03-05 A |  | 0% → 10% |  |  |
| 94 | **Extragalactic Science Requirements** | 2006-10-02 A |  | 0% → 37% |  |  |
| 95 | **Resolved Stellar Populations in Crowded Fields** | 2006-10-02 A |  | 0% → 47% |  |  |
| 96 | Performance Requirements | 2006-10-02 A |  | 0% → 50% |  |  |
| 97 | Observing Scenarios | 2006-12-11 A |  | 0% → 40% |  |  |
| 98 | Science Instrument Requirements | 2006-12-11 A |  | 0% → 50% |  |  |
| 99 | **High Redshift Galaxies** | 2006-10-02 A |  | 0% → 41% |  |  |
| 100 | Encircled Energy (& d-IFU) Performance Requirements | 2006-10-02 A |  | 0% → 40% |  |  |
| 101 | Observing Scenarios | 2006-12-11 A |  | 0% → 35% |  |  |
| 102 | Science Instrument Requirements | 2006-12-11 A |  | 0% → 50% |  |  |

| ID | Task | Start | Finish | Complete | Total float |
| --- | --- | --- | --- | --- | --- |
| 103 | **Nearby Galaxies** | 2006-12-11 A |  | 0% → 40% |  |
| 104 | Encircled Energy & PSF Performance Requirements | 2006-12-11 A |  | 0% → 40% |  |
| 105 | Observing Scenarios | 2007-03-05 A |  | 0% → 20% |  |
| 106 | Science Instrument Requirements | 2007-03-05 A |  | 0% → 60% |  |
| 107 | **Gravitational Lensing** | 2006-12-11 A |  | 0% → 19% |  |
| 108 | Encircled Energy & PSF Performance Requirements | 2006-12-11 A |  | 0% → 10% |  |
| 109 | Observing Scenarios | 2007-03-05 A |  | 0% → 10% |  |
| 110 | Science Instrument Requirements | 2007-03-05 A |  | 0% → 40% |  |
| 111 | **Science Requirements Summary** | 2006-10-02 A |  | 0% → 25% | 122.33d → 122.83d |
| 112 | Science Requirements Summary Rev 1 | 2006-10-02 A | 2006-10-19 A | 0% → 100% | 379.33d → none |
| 116 | **Observatory Requirements** | 2006-10-02 A |  | 0% → 43% |  |
| 117 | Development Requirements | 2006-10-02 A | 2006-11-24 A | 0% → 100% | 107.33d → none |
| 118 | Observatory Interface Requirements | 2006-10-02 A | 2006-10-27 A | 0% → 100% | 127.33d → none |
| 119 | Science Operations Requirements | 2006-10-02 A |  | 0% → 50% |  |
| 123 | **System Requirements Document** | 2006-10-09 A |  | 0% → 19% |  |
| 124 | **Traceability Matrix** | 2006-10-09 A |  | 0% → 12% | 118.33d → 128.33d |
| 125 | Traceability Matrix Rev 1 | 2006-10-09 A |  | 0% → 50% | 378.33d → 388.33d |
| 129 | **System Requirements Document** | 2006-11-27 A |  | 0% → 26% |  |
| 130 | SRD Rev 1 | 2006-11-27 A | 2006-12-08 A | 0% → 100% | 353.33d → none |
| 131 | SRD Rev 2 | 2007-03-09 A |  | 0% → 5% |  |
| 134 | **System Design** | 2006-08-14 A |  | 0% → 16% |  |
| 135 | **Systems Engineering** | 2006-08-14 A |  | 0% → 40% |  |
| 136 | **Performance Budgets** | 2006-08-14 A |  | 0% → 52% |  |
| 137 | **Model Assumptions** | 2006-08-14 A |  | 0% → 63% | 200.83d → 208.33d |
| 138 | **TMT site monitoring data mining** | 2006-08-14 A |  | 0% → 55% |  |
| 139 | Tools in place & 1st release | 2006-08-14 A | 2006-09-14 A | 0% → 100% | 209.33d → none |
| 140 | Release updated data (every two months) | 2006-09-18 A |  | 0% → 50% |  |
| 141 | Telescope dynamic performance data | 2006-10-02 A |  | 0% → 75% | 165.83d → 177.53d |
| 142 | Telescope static wavefront errors | 2006-10-02 A |  | 0% → 75% | 165.83d → 177.53d |
| 143 | Sodium return vs laser format | 2006-11-01 A | 2006-11-30 A | 0% → 100% | 178.83d → none |
| 144 | **Model/Tool Validation** | 2006-08-14 A |  | 0% → 68% |  |
| 145 | Agreement between Tomography Codes | 2006-08-14 A |  | 0% → 75% |  |
| 146 | Agreement between Sky Coverage Codes | 2006-10-16 A | 2006-11-03 A | 0% → 100% | 197.83d → none |
| 147 | Anchor to Keck II LGS AO PSFs | 2006-10-02 A |  | 0% → 25% |  |
| 148 | Anchor to On-sky MGSU Experiments | 2006-11-10 A | 2006-11-15 A | 0% → 100% | 189.83d → none |
| 149 | Anchor to LAO Lab Experiments | 2006-11-06 A |  | 0% → 70% |  |
| 150 | Throughput | 2006-10-02 A |  | 0% → 50% |  |
| 151 | **Background** | 2006-10-02 A |  | 0% → 47% |  |
| 152 | Document Proposal Analysis | 2006-10-02 A |  | 0% → 25% |  |
| 153 | Develop Background Performance Budget | 2006-10-02 A |  | 0% → 50% |  |
| 154 | **Wavefront Error vs Sky Coverage** | 2006-10-02 A |  | 0% → 33% |  |
| 155 | Document WFE Budget Rev 1 | 2006-10-02 A |  | 0% → 50% |  |
| 157 | Encircled Energy vs Sky Coverage | 2006-10-23 A |  | 0% → 75% | 182.83d → 0d |
| 158 | Photometric Accuracy | 2006-10-16 A |  | 0% → 50% |  |
| 159 | Astrometric Accuracy | 2006-11-13 A |  | 0% → 50% | 73.83d → 0d |
| 160 | Polarimetric Accuracy | 2007-02-05 A |  | 0% → 75% |  |
| 161 | Companion Sensitivity | 2006-11-13 A |  | 0% → 75% |  |
| 162 | Observing Efficiency | 2007-02-05 A |  | 0% → 50% |  |
| 163 | Observing Uptime | 2007-11-05 A |  | 0% → 25% |  |
| 173 | **Trade Studies** | 2006-10-16 A |  | 0% → 37% |  |
| 174 | **System Architecture Trade Studies** | 2006-10-16 A |  | 0% → 62% |  |
| 175 | MOAO & MCAO TS | 2006-11-13 A |  | 0% → 95% |  |
| 176 | NGAO versus Keck AO upgrades TS (meeting 5) | 2007-02-05 A | 2007-03-02 A | 0% → 100% | 173.83d → none |
| 179 | Keck Interferometer Support TS (m5) | 2006-10-16 A |  | 0% → 75% | 173.83d → 0d |
| 181 | GLAO for non-NGAO Instruments TS (m5) | 2007-02-05 A | 2007-03-02 A | 0% → 100% | 173.83d → none |
| 182 | Science Instrument Re-use Cost/Benefit TS (m3) | 2006-11-13 A |  | 0% → 50% |  |
| 183 | Telescope Wavefront Errors TS | 2006-12-04 A |  | 0% → 90% |  |
| 184 | Observing Model TS | 2006-11-13 A |  | 0% → 60% |  |
| 185 | **Adaptive Optics System Trade Studies** | 2006-10-30 A |  | 0% → 27% |  |
| 186 | AO Enclosure Temperature TS (m6) | 2007-01-02 A |  | 0% → 25% |  |
| 187 | Optical Relay TS (m6) | 2007-01-02 A |  | 0% → 25% |  |
| 188 | Field Rotation Strategy TS (m6) | 2007-01-02 A |  | 0% → 25% |  |
| 190 | Rayleigh Rejection TS (m3) | 2006-10-30 A |  | 0% → 75% |  |
| 191 | LGS WFS Type TS (m4) | 2006-12-04 A |  | 0% → 75% |  |
| 192 | LGS WFS number of subapertures TS (m4) | 2006-12-04 A |  | 0% → 75% |  |
| 194 | LOWFS Architecture TS | 2006-12-04 A |  | 0% → 35% | 95.83d → 0d |
| 195 | Number & Type of LOWFS TS (m4) | 2006-12-04 A | 2007-01-26 A | 0% → 100% | 105.83d → none |
| 198 | Stand-alone vs DM on T/T Stage TS (m3) | 2006-10-30 A |  | 0% → 50% |  |
| 201 | **Laser Facility Trade Studies** | 2006-10-16 A |  | 0% → 35% |  |
| 203 | Free Space vs Fiber TS (m7) | 2007-01-30 A |  | 0% → 25% |  |

| ID | Task | Start | Finish | Complete | Total float |
| --- | --- | --- | --- | --- | --- |
| 204 | LGS Asterism Geometry & Size TS (m2) | 2006-10-23 A | 2006-10-27 A | 0% → 100% | 235.83d → none |
| 205 | Variable vs fixed LGS Asterism Cost/Benefit TS (m2) | 2006-10-16 A | 2006-10-27 A | 0% → 100% | 235.83d → none |
| 293 | **Science Instruments** | 2006-10-02 A |  | 0% → 4% |  |
| 295 | Interferometer | 2006-10-02 A |  | 0% → 25% |  |
| 303 | **Systems Engineering Management Plan (SEMP)** | 2007-03-05 A |  | 0% → 1% |  |
| 310 | **Preliminary Design Phase Plan** | 2007-03-05 A |  | 0% → 9% |  |
| 311 | Preliminary Design Phase Plan Version 1 (to Support Observatory FY08 Planning) | 2007-03-05 A |  | 0% → 25% |  |

## Version 11 (saved 2007-04-16, file NGAO_SD_schedule_v20_final_tracked_version.mpp)

Last finish stays 2008-04-17. Complete tasks 26 → 35.

Changed:

| ID | Task | Start | Finish | Complete | Total float |
| --- | --- | --- | --- | --- | --- |
| 1 | **SD Phase Management** |  |  | 28% → 29% |  |
| 2 | **Planning and Contracting** |  |  | 69% → 73% |  |
| 9 | Mid-year Replan |  |  | 25% → 50% |  |
| 11 | **Project Meetings** |  |  | 24% → 25% |  |
| 12 | Executive Committee Telecons |  |  | 43% → 45% |  |
| 33 | SSC meeting (CA) |  | 2007-04-03 A | 25% → 100% | 272.33d → none |
| 52 | **System Requirements** |  |  | 35% → 44% |  |
| 53 | **Science Requirements** |  |  | 34% → 46% |  |
| 54 | **Solar System Science Requirements** |  |  | 44% → 60% |  |
| 55 | **Companions & Multiplicity of Small Solar System Bodies** |  |  | 49% → 74% |  |
| 56 | Point Source Companion Sensitivity Requirements |  |  | 40% → 75% |  |
| 57 | Spectral Sensitivity & Spectral Resolution Requirements |  |  | 60% → 85% |  |
| 58 | Observing Scenarios |  |  | 25% → 50% |  |
| 59 | Science Instrument Requirements |  |  | 70% → 80% |  |
| 64 | **Shape & Size of Asteroids** |  |  | 49% → 68% |  |
| 65 | Spatial Resolution Requirements |  |  | 45% → 70% |  |
| 66 | Spectral Sensitivity & Spectral Resolution Requirements |  |  | 60% → 80% |  |
| 67 | Observing Scenarios |  |  | 20% → 40% |  |
| 68 | Science Instrument Requirements |  |  | 70% → 80% |  |
| 69 | **Galactic Science Requirements** |  |  | 27% → 35% |  |
| 70 | **Galactic Center Proper Motions: Astrometry** |  |  | 46% → 60% |  |
| 72 | Observing Scenarios |  |  | 50% → 75% |  |
| 73 | Science Instrument Requirements |  |  | 50% → 75% |  |
| 82 | **Planets around Low Mass Stars & Brown Dwarfs: Companion Sensitivity** |  |  | 32% → 54% |  |
| 83 | Companion Sensitivity Performance Requirements |  |  | 35% → 60% |  |
| 85 | Science Instrument Requirements |  |  | 20% → 60% |  |
| 94 | **Extragalactic Science Requirements** |  |  | 37% → 51% |  |
| 95 | **Resolved Stellar Populations in Crowded Fields** |  |  | 47% → 57% |  |
| 96 | Performance Requirements |  |  | 50% → 60% |  |
| 97 | Observing Scenarios |  |  | 40% → 60% |  |
| 99 | **High Redshift Galaxies** |  |  | 41% → 67% |  |
| 100 | Encircled Energy (& d-IFU) Performance Requirements |  |  | 40% → 70% |  |
| 101 | Observing Scenarios |  |  | 35% → 70% |  |
| 102 | Science Instrument Requirements |  |  | 50% → 60% |  |
| 107 | **Gravitational Lensing** |  |  | 19% → 39% |  |
| 108 | Encircled Energy & PSF Performance Requirements |  |  | 10% → 30% |  |
| 109 | Observing Scenarios |  |  | 10% → 30% |  |
| 110 | Science Instrument Requirements |  |  | 40% → 60% |  |
| 134 | **System Design** |  |  | 16% → 18% |  |
| 135 | **Systems Engineering** |  |  | 40% → 44% |  |
| 136 | **Performance Budgets** |  |  | 52% → 57% |  |
| 137 | **Model Assumptions** |  |  | 63% → 70% |  |
| 141 | Telescope dynamic performance data |  | 2006-11-30 A | 75% → 100% | 177.53d → none |
| 142 | Telescope static wavefront errors |  | 2006-11-30 A | 75% → 100% | 177.53d → none |
| 144 | **Model/Tool Validation** |  |  | 68% → 71% |  |
| 145 | Agreement between Tomography Codes |  | 2006-09-29 A | 75% → 100% | 222.83d → none |
| 149 | Anchor to LAO Lab Experiments |  |  | 70% → 50% |  |
| 158 | Photometric Accuracy |  | 2007-01-26 A | 50% → 100% | 162.83d → none |
| 173 | **Trade Studies** |  |  | 37% → 41% |  |
| 174 | **System Architecture Trade Studies** |  |  | 62% → 69% |  |
| 175 | MOAO & MCAO TS |  | 2006-12-15 A | 95% → 100% | 228.83d → none |
| 177 | Adaptive Secondary Mirror option TS (m5) | 2007-03-05 A |  | 0% → 25% |  |
| 183 | Telescope Wavefront Errors TS |  | 2006-12-20 A | 90% → 100% | 164.83d → none |
| 184 | Observing Model TS |  |  | 60% → 90% |  |
| 185 | **Adaptive Optics System Trade Studies** |  |  | 27% → 30% |  |
| 191 | LGS WFS Type TS (m4) |  | 2007-01-19 A | 75% → 100% | 110.83d → none |
| 192 | LGS WFS number of subapertures TS (m4) |  | 2007-01-19 A | 75% → 100% | 110.83d → none |

## Version 12 (saved 2007-04-24, file NGAO_SD_schedule_v24_tracked.mpp)

Last finish 2008-04-17 → 2008-04-16 (-1d).

Added:

| ID | Task | Duration | Start | Finish | Predecessors | Constraint | Resources |
| --- | --- | --- | --- | --- | --- | --- | --- |
| 203 | Uplink compensation | 25d? | 2007-04-30 | 2007-06-01 |  | finish no earlier than 2007-06-01 | Gavel [20%]; Velur |
| 206 | Define Candidate Subsystems | 16d? | 2007-05-10 | 2007-05-31 |  | finish no earlier than 2007-05-31 | Bauman [31.2%]; Dekany; Gavel; Neyman; Velur; Wizinowich |
| 207 | Subsystems Performance Evaluation | 16d? | 2007-06-01 | 2007-06-22 | 206 | finish no earlier than 2007-06-22 | Dekany [26.6%]; Gavel; Neyman; Bauman |
| 208 | Subsystems Cost Evaluation | 16d? | 2007-06-01 | 2007-06-22 | 206 | finish no earlier than 2007-06-22 | Bauman [7.8%]; Dekany; Gavel; Neyman; Velur; Wizinowich |
| 209 | Subsystems Risk Evaluation | 16d? | 2007-06-01 | 2007-06-22 | 206 | finish no earlier than 2007-06-22 | Dekany [35%]; Gavel; Neyman [15.6%]; Wizinowich |
| 210 | Organize Candidate Subsystems | 7.14d? | 2007-06-25 | 2007-07-04 | 209 |  | Dekany [35%]; Gavel; Neyman; Wizinowich |
| 212 | Define Candidate Architectures | 12.5d? | 2007-07-04 | 2007-07-20 |  |  | Bauman [40%]; Dekany; Gavel; Neyman; Velur; Wizinowich |
| 213 | Architectures Performance Evaluation | 4.69d? | 2007-07-20 | 2007-07-27 | 212 |  | Bauman [40%]; Dekany; Gavel; Neyman; Velur; Wizinowich |
| 214 | Architectures Cost Evaluation | 12.5d? | 2007-07-20 | 2007-08-08 | 212 |  | Bauman [40%]; Dekany; Gavel; Neyman; Velur; Wizinowich |
| 215 | Architectures Risk Evaluation | 3.01d? | 2007-07-20 | 2007-07-25 | 212 |  | Neyman [83%]; Dekany; Gavel; Wizinowich |
| 216 | Adopt Baseline Architecture(s) | 10.71d? | 2007-08-08 | 2007-08-22 | 213, 214, 215 |  | Dekany [35%]; Gavel; Neyman; Wizinowich |
| 217 | System Architecture ver 1 | 14.29d? | 2007-08-22 | 2007-09-12 | 216 |  | Dekany [35%]; Gavel; Neyman; Wizinowich |
| 218 | System Architecture ver 2 | 7.14d? | 2007-12-18 | 2007-12-28 | 232, 262 |  | Dekany [35%]; Gavel; Neyman; Wizinowich |
| 220 | Draft Functional Requirements Document | 7.35d? | 2007-05-22 | 2007-05-31 |  | finish no earlier than 2007-05-31 | Wizinowich [34%] |
| 253 | Atmospheric Profiler | 30.14d? | 2007-08-22 | 2007-10-02 |  | finish no earlier than 2007-10-02 | Britton [20.7%] |
| 254 | d-IFU & LOWFS AO & Object Selection | 56d? | 2007-08-22 | 2007-11-07 |  | finish no earlier than 2007-08-06 | Moore [44.6%]; Gavel; Meguro |
| 290 | PSF Reconstruction | 100d? | 2007-09-03 | 2008-01-17 |  | start no earlier than 2007-09-03 | Le Mignant [10%]; Britton |
| 308 | **Instrument Requirements & Initial Definitions** | 211d? | 2007-04-09 | 2008-01-25 |  |  |  |
| 309 | Top Level Instrument Requirements & Definitions | 20d? | 2007-04-09 | 2007-05-04 |  | finish no earlier than 2007-05-04 | Adkins [10%] |
| 310 | **Instrument Suite Version 1** | 13.5d? | 2007-05-07 | 2007-05-24 |  |  |  |
| 311 | Instrument Function Allocation Review with Science Team | 1d? | 2007-05-07 | 2007-05-07 | 309 | finish no earlier than 2007-05-07 | Adkins [37.5%] |
| 312 | Summary Descriptions of Instruments | 12.5d? | 2007-05-08 | 2007-05-24 | 311 | start no earlier than 2007-05-08 | Adkins [10%] |
| 313 | **Instrument Suite Version 2** | 12d? | 2008-01-10 | 2008-01-25 |  |  |  |
| 314 | Instrument Review with Science Team | 2d? | 2008-01-10 | 2008-01-11 |  | start no earlier than 2008-01-10 | Adkins [18.8%] |
| 315 | Revised Summary Descriptions of Instruments | 10d? | 2008-01-14 | 2008-01-25 | 314 | finish no earlier than 2008-01-25 | Adkins [25%] |
| 316 | **Instrument Interfaces** | 18d? | 2007-06-06 | 2007-06-29 |  |  |  |
| 317 | Hardware Instrument Interfaces | 13d? | 2007-06-06 | 2007-06-22 |  | start no earlier than 2007-06-06 | Adkins [19.2%]; Meguro |
| 318 | Software Instrument Interfaces | 14d? | 2007-06-12 | 2007-06-29 |  | start no earlier than 2007-06-12 | Adkins [17.9%]; Johansson |
| 319 | **Deployable NIR IFU (DNIRI)** | 221d? | 2007-05-07 | 2008-03-07 |  |  |  |
| 320 | DNIRI Concept Development | 30d? | 2007-05-07 | 2007-06-15 |  | start no earlier than 2007-05-07 | Adkins [4.2%]; Mechanical Engineer 1; Optical Engineer 1 |
| 321 | **DNIRI AO Interface Issues** | 12d? | 2007-06-18 | 2007-07-03 |  |  |  |
| 322 | Object Selection for DNIRI | 10d? | 2007-06-18 | 2007-06-29 | 320 | finish no earlier than 2007-06-29 | Adkins [10%]; Mechanical Engineer 1; Optical Engineer 1; Moore |
| 323 | AO Design for DNIRI | 1d? | 2007-07-02 | 2007-07-02 | 322 | finish no earlier than 2007-07-02 | Moore [50%] |
| 324 | DNIRI AO Boundary | 1d? | 2007-07-03 | 2007-07-03 | 323 | finish no earlier than 2007-07-03 | Adkins [12.5%]; Mechanical Engineer 1; Optical Engineer 1; Moore |
| 325 | DNIRI Spectrograph Concepts | 25d? | 2007-07-04 | 2007-08-07 | 324 | finish no earlier than 2007-08-06 | Adkins [10%]; Mechanical Engineer 1; Optical Engineer 1 |
| 326 | DNIRI Imager Concepts | 25d? | 2007-07-04 | 2007-08-07 | 324 | finish no earlier than 2007-08-06 | Adkins [10%]; Mechanical Engineer 1; Optical Engineer 1 |
| 327 | DNIRI Concept Review with AO Team | 1d? | 2007-08-08 | 2007-08-08 | 325, 326 | finish no earlier than 2007-08-08 | Adkins [25%]; Mechanical Engineer 1; Optical Engineer 1; Moore |
| 328 | DNIRI Report ver 1 | 29d? | 2007-08-10 | 2007-09-18 | 327 | finish no earlier than 2007-09-18 | Adkins [17.2%] |
| 329 | DNIRI Report ver 2 | 31d? | 2008-01-25 | 2008-03-07 |  | start no earlier than 2008-01-25 | Adkins [8.1%] |
| 330 | **Single Object Imagers/Low Resolution Spectrographs (SOI/LRS)** | 222d? | 2007-05-07 | 2008-03-10 |  |  |  |
| 331 | SOI/LRS Coronagraph Requirements | 20d? | 2007-05-07 | 2007-06-01 | 309 | finish no earlier than 2007-06-01 | Adkins [12.5%] |
| 332 | SOI/LRS Spectrograph Requirements | 10d? | 2007-06-04 | 2007-06-15 | 331 | start no earlier than 2007-06-04 | Adkins [6.2%] |
| 333 | SOI/LRS Concept Development | 10d? | 2007-06-18 | 2007-06-29 | 332, 331 | finish no earlier than 2007-06-29 | Adkins [10%]; Mechanical Engineer 2; Optical Engineer 2 |
| 334 | **SOI/LRS Concept Review** | 2d? | 2007-07-02 | 2007-07-03 |  |  |  |
| 335 | SOI/LRS Concept Review with Science Team | 1d? | 2007-07-02 | 2007-07-02 | 333 | finish no earlier than 2007-07-02 | Adkins [37.5%] |
| 336 | SOI/LRS Concept Review with AO Team | 1d? | 2007-07-03 | 2007-07-03 | 335, 333 | finish no earlier than 2007-07-03 | Adkins [37.5%] |
| 337 | **SOI/LRS Reports** | 179d? | 2007-07-05 | 2008-03-10 |  |  |  |
| 338 | SOI/LRS Near-IR ver 1 | 75d? | 2007-07-05 | 2007-10-16 | 336 | start no earlier than 2007-07-05 | Adkins [5%] |
| 339 | SOI/LRS Visibile ver 1 | 75d? | 2007-07-06 | 2007-10-17 | 336 | finish no earlier than 2007-10-17 | Adkins [5%] |
| 340 | SOI/LRS Near-IR ver 2 | 16d? | 2008-01-25 | 2008-02-15 |  | start no earlier than 2008-01-25 | Adkins [9.4%] |
| 341 | SOI/LRS Visible ver 2 | 16d? | 2008-02-18 | 2008-03-10 | 340 | finish no earlier than 2008-03-10 | Adkins [9.4%] |
| 342 | **Single Object IFUs (SOIFU)** | 221d? | 2007-04-30 | 2008-02-29 |  |  |  |
| 343 | Near-IR IFU Requirements Review | 10d? | 2007-04-30 | 2007-05-11 |  | start no earlier than 2007-04-30 | Adkins [6.2%] |
| 344 | Visible IFU Requirements Review | 21d? | 2007-09-18 | 2007-10-16 |  | start no earlier than 2007-09-18 | Adkins [4.8%] |
| 345 | Visible IFU Concept Development | 31d? | 2007-10-17 | 2007-11-28 | 344 | finish no earlier than 2007-11-28 | Adkins [6%]; Mechanical Engineer 3; Optical Engineer 3 |
| 346 | **SOIFU Concept Review** | 2d? | 2007-11-29 | 2007-11-30 |  |  |  |
| 347 | SOIFU Concept Review with Science Team | 1d? | 2007-11-29 | 2007-11-29 | 343, 345 | finish no earlier than 2007-11-29 | Adkins [37.5%] |
| 348 | SOIFU Concept Review with AO Team | 1d? | 2007-11-30 | 2007-11-30 | 347 | finish no earlier than 2007-11-30 | Adkins [37.5%] |
| 349 | **Single Object IFU Reports** | 65d? | 2007-12-03 | 2008-02-29 |  |  |  |
| 350 | SOIFU Near-IR ver 1 | 10d? | 2007-12-03 | 2007-12-14 | 348 | finish no earlier than 2007-12-14 | Adkins [15%] |
| 351 | SOIFU Visible ver 1 | 20d? | 2007-12-17 | 2008-01-11 | 350 | finish no earlier than 2008-01-11 | Adkins [18.8%] |
| 352 | SOIFU Near-IR ver 2 | 10d? | 2008-01-28 | 2008-02-08 |  | finish no earlier than 2008-02-08 | Adkins [10%] |
| 353 | SOIFU Visible ver 2 | 10d? | 2008-02-18 | 2008-02-29 |  | start no earlier than 2008-02-18 | Adkins [25%] |
| 354 | **Special Purpose High Contrast Instrument (HCI)** | 52d? | 2008-01-10 | 2008-03-21 |  |  |  |
| 355 | HCI Requirements Development | 31d? | 2008-01-10 | 2008-02-21 |  | start no earlier than 2008-01-10 | Adkins [5.2%] |
| 356 | HCI Concept Development | 20d? | 2008-02-22 | 2008-03-20 | 355 | finish no earlier than 2008-03-20 | Adkins [12.5%]; Mechanical Engineer 2; Optical Engineer 2 |
| 357 | HCI Concept & Need Review with Science Team | 1d? | 2008-03-21 | 2008-03-21 | 356 | finish no earlier than 2008-03-21 | Adkins |
| 362 | SDM v1 | 5.51d? | 2007-08-22 | 2007-08-30 | 216 |  | Wizinowich [34%]; Dekany |
| 363 | SDM v2 | 9.19d? | 2008-02-01 | 2008-02-14 | 161, 219, 231, 232, 262, 276, 328 |  | Wizinowich [34%]; Dekany; Gavel |

Removed: 79 Performance Requirements; 80 Observing Scenarios; 81 Science Instrument Requirements; 294 OSIRIS; 297 Near-IR Imager; 298 Visible Imager; 299 Visible IFU; 300 Deployable Near-IR IFU

Changed:

| ID | Task | Start | Finish | Duration | Complete | Total float | Other |
| --- | --- | --- | --- | --- | --- | --- | --- |
| 1 | **SD Phase Management** |  | 2008-04-17 → 2008-04-16 (-1d) |  |  |  | baseline start none → 2006-06-21; baseline finish none → 2008-04-17 |
| 2 | **Planning and Contracting** |  | 2007-11-14 → 2007-11-13 (-1d) |  | 73% → 74% |  | baseline start none → 2006-06-21; baseline finish none → 2007-11-14 |
| 3 | NGAO Proposal to SSC |  |  |  |  |  | baseline start none → 2006-06-21; baseline finish none → 2006-06-21 |
| 4 | Management Structure Decision by Directors |  |  |  |  |  | baseline start none → 2006-07-14; baseline finish none → 2006-07-14 |
| 5 | SD Phase System Engineering Management Plan |  |  |  |  |  | baseline start none → 2006-09-01; baseline finish none → 2006-09-29 |
| 6 | SD Phase Contracts Generated |  |  |  |  |  | baseline start none → 2006-09-27; baseline finish none → 2006-10-27 |
| 7 | Director Approval |  |  |  |  |  | baseline start none → 2006-10-09; baseline finish none → 2006-10-09 |
| 8 | SD Partner Contracts Issued |  |  |  |  |  | baseline start none → 2006-10-27; baseline finish none → 2006-10-27 |
| 9 | Mid-year Replan | 2007-03-05 A → 2007-03-19 A (+14d) | 2007-03-16 → 2007-03-27 (+11d) | 10d → 7d |  | 283.33d → 276.33d | constraint start no earlier than 2007-03-05 → finish no earlier than 2007-03-27; resources Wizinowich [22.5%]; Dekany [10%]; Gavel [10%]; Max [7.5%] → Wizinowich [56.2%]; Dekany [25%]; Gavel [25%]; Max [18.8%]; baseline start none → 2007-03-05; baseline finish none → 2007-03-16 |
| 10 | FY08 Replan | 2007-10-25 → 2007-10-24 (-1d) | 2007-11-14 → 2007-11-13 (-1d) |  |  |  | baseline start none → 2007-10-25; baseline finish none → 2007-11-14 |
| 11 | **Project Meetings** |  | 2008-04-03 → 2008-04-02 (-1d) |  |  |  | baseline start none → 2006-06-21; baseline finish none → 2008-04-03 |
| 12 | Executive Committee Telecons |  | 2008-04-03 → 2008-04-02 (-1d) |  |  |  | baseline start none → 2006-06-21; baseline finish none → 2008-04-03 |
| 13 | Science Advisory Committee Telecons |  | 2008-03-28 → 2008-03-27 (-1d) |  |  |  | baseline start none → 2006-10-02; baseline finish none → 2008-03-28 |
| 14 | **Team Meetings** |  |  | 344.5d → 345.5d | 35% → 32% | 70.83d → 69.83d | baseline start none → 2006-09-14; baseline finish none → 2008-01-09 |
| 15 | Team Meeting #1 (mgmt, science & technical - Irvine) |  |  |  |  |  | baseline start none → 2006-09-14; baseline finish none → 2006-09-14 |
| 16 | Team Meeting #2 (CIT) |  |  |  |  |  | baseline start none → 2006-11-14; baseline finish none → 2006-11-14 |
| 17 | Team Videocon #3 |  |  |  |  |  | baseline start none → 2006-12-13; baseline finish none → 2006-12-13 |
| 18 | Team Meeting #4 (Keck) |  |  |  |  |  | baseline start none → 2007-01-22; baseline finish none → 2007-01-22 |
| 19 | Team Videocon #5 |  |  |  |  |  | baseline start none → 2007-03-07; baseline finish none → 2007-03-07 |
| 20 | Team Meeting #6 (UCSC) | 2007-04-18 → 2007-04-25 (+7d) | 2007-04-18 → 2007-04-26 (+8d) | 1d → 2d |  | 260.33d → 254.33d | constraint start no earlier than 2007-04-18 → finish no earlier than 2007-04-26; resources Wizinowich; Dekany; Gavel; Max; Bauman; Bouchez; Velur; Flicker; Neyman; Britton; Le Mignant → Wizinowich [50%]; Dekany [50%]; Gavel [50%]; Max [50%]; Bauman [50%]; Bouchez; Velur [50%]; Flicker [50%]; Neyman [50%]; Britton [50%]; Le Mignant; baseline start none → 2007-04-18; baseline finish none → 2007-04-18 |
| 21 | Team Videocon #7 |  |  |  |  |  | baseline start none → 2007-05-30; baseline finish none → 2007-05-30 |
| 22 | Team Retreat #8 (UCSC) |  |  |  |  |  | baseline start none → 2007-07-09; baseline finish none → 2007-07-11 |
| 23 | Team Videocon #9 |  |  |  |  |  | baseline start none → 2007-08-22; baseline finish none → 2007-08-22 |
| 24 | Team Meeting #10 (CIT) |  |  |  |  |  | baseline start none → 2007-09-11; baseline finish none → 2007-09-11 |
| 25 | Team Videocon #11 |  |  |  |  | 117.83d → 116.83d | baseline start none → 2007-11-05; baseline finish none → 2007-11-05 |
| 26 | Team Meeting #12 (Keck) |  |  |  |  | 90.33d → 89.33d | baseline start none → 2007-12-12; baseline finish none → 2007-12-12 |
| 27 | Team Videocon #13 |  |  |  |  | 70.83d → 69.83d | baseline start none → 2008-01-09; baseline finish none → 2008-01-09 |
| 28 | **Tracking and Reporting** |  |  | 404d? → 405d? |  | 9.33d → 8.33d | baseline start none → 2006-09-16; baseline finish none → 2008-04-03 |
| 29 | Report Preparation/Presentation |  | 2007-12-12 → 2007-12-11 (-1d) |  |  |  | baseline start none → 2006-10-02; baseline finish none → 2007-12-12 |
| 30 | Keck Science Meeting 06 (UCI) |  |  |  |  |  | baseline start none → 2006-09-16; baseline finish none → 2006-09-16 |
| 31 | SSC meeting (UCLA) |  |  |  |  |  | baseline start none → 2006-11-06; baseline finish none → 2006-11-06 |
| 32 | SSC meeting (Keck) |  |  |  |  |  | baseline start none → 2007-01-24; baseline finish none → 2007-01-24 |
| 33 | SSC meeting (CA) |  |  |  |  |  | baseline start none → 2007-04-03; baseline finish none → 2007-04-03 |
| 34 | SSC meeting (Keck) |  |  |  |  |  | baseline start none → 2007-06-20; baseline finish none → 2007-06-20 |
| 35 | Keck Science Meeting 07 | 2007-09-22 → 2007-09-15 (-7d) | 2007-09-22 → 2007-09-15 (-7d) |  |  | 148.33d → 153.33d | constraint finish no earlier than 2007-09-22 → start no earlier than 2007-09-15; baseline start none → 2007-09-22; baseline finish none → 2007-09-22 |
| 36 | SSC meeting (CA) |  |  |  |  | 117.33d → 116.33d | baseline start none → 2007-11-06; baseline finish none → 2007-11-06 |
| 37 | SSC meeting (Keck) |  |  |  |  | 60.33d → 59.33d | baseline start none → 2008-01-24; baseline finish none → 2008-01-24 |
| 38 | SSC meeting (CA) |  |  |  |  | 9.33d → 8.33d | baseline start none → 2008-04-03; baseline finish none → 2008-04-03 |
| 39 | **Proposals & Fundraising** |  |  |  |  |  | baseline start none → 2006-10-27; baseline finish none → 2007-01-01 |
| 40 | Dates & deliverables identified by Directors |  |  |  |  |  | baseline start none → 2006-10-27; baseline finish none → 2006-10-27 |
| 41 | Support Advancement Office |  |  |  |  |  | baseline start none → 2007-01-01; baseline finish none → 2007-01-01 |
| 42 | **System Design Report & Review** |  | 2008-04-17 → 2008-04-16 (-1d) | 143.33d? → 142.33d? |  |  | baseline start none → 2007-10-01; baseline finish none → 2008-04-17 |
| 43 | System Design Report | 2008-02-20 → 2008-02-19 (-1d) | 2008-03-03 → 2008-02-29 (-3d) |  |  |  | baseline start none → 2008-02-20; baseline finish none → 2008-03-03 |
| 44 | **System Design Review** |  | 2008-04-17 → 2008-04-16 (-1d) | 143.33d? → 142.33d? |  |  | baseline start none → 2007-10-01; baseline finish none → 2008-04-17 |
| 45 | Identify Reviewers |  |  |  |  | 59.33d → 58.33d | baseline start none → 2007-10-01; baseline finish none → 2007-12-14 |
| 46 | Review Package Distributed | 2008-03-03 → 2008-02-29 (-3d) | 2008-03-04 → 2008-03-03 (-1d) |  |  |  | baseline start none → 2008-03-03; baseline finish none → 2008-03-04 |
| 47 | Reviewer Comments Addressed | 2008-03-18 → 2008-03-17 (-1d) | 2008-03-25 → 2008-03-24 (-1d) |  |  |  | baseline start none → 2008-03-18; baseline finish none → 2008-03-25 |
| 48 | System Design Review Support | 2008-03-03 → 2008-02-29 (-3d) | 2008-03-31 → 2008-03-28 (-3d) |  |  |  | baseline start none → 2008-03-03; baseline finish none → 2008-03-31 |
| 49 | System Design Review Meeting | 2008-03-31 → 2008-03-28 (-3d) | 2008-03-31 → 2008-03-28 (-3d) |  |  |  | baseline start none → 2008-03-31; baseline finish none → 2008-03-31 |
| 50 | Reviewer Report Received | 2008-04-14 → 2008-04-11 (-3d) | 2008-04-14 → 2008-04-11 (-3d) |  |  |  | baseline start none → 2008-04-14; baseline finish none → 2008-04-14 |
| 51 | Response to Reviewer Report & Distribution | 2008-04-14 → 2008-04-11 (-3d) | 2008-04-17 → 2008-04-16 (-1d) |  |  |  | baseline start none → 2008-04-14; baseline finish none → 2008-04-17 |
| 52 | **System Requirements** |  |  | 285d? → 286d? | 44% → 48% | 118.33d → 117.33d | baseline start none → 2006-10-02; baseline finish none → 2007-11-02 |
| 53 | **Science Requirements** |  |  | 271d? → 272d? | 46% → 49% | 132.33d → 131.33d | baseline start none → 2006-10-02; baseline finish none → 2007-10-15 |
| 54 | **Solar System Science Requirements** |  | 2007-04-06 → 2007-08-31 (+147d) | 135d? → 240d? | 60% → 57% | 268.33d → 163.33d | baseline start none → 2006-10-02; baseline finish none → 2007-04-06 |
| 55 | **Companions & Multiplicity of Small Solar System Bodies** |  | 2007-01-12 → 2007-05-15 (+123d) | 75d? → 162d? |  | 328.33d → 241.33d | baseline start none → 2006-10-02; baseline finish none → 2007-01-12 |
| 56 | Point Source Companion Sensitivity Requirements |  | 2006-12-01 → 2007-05-15 (+165d) | 45d? → 162d? |  | 358.33d → 241.33d | constraint finish no earlier than 2006-12-01 → finish no earlier than 2007-05-15; baseline start none → 2006-10-02; baseline finish none → 2006-12-01 |
| 57 | Spectral Sensitivity & Spectral Resolution Requirements |  | 2006-12-01 → 2007-05-15 (+165d) | 45d? → 162d? |  | 358.33d → 241.33d | constraint finish no earlier than 2006-12-01 → finish no earlier than 2007-05-15; baseline start none → 2006-10-02; baseline finish none → 2006-12-01 |
| 58 | Observing Scenarios |  | 2007-01-12 → 2007-05-15 (+123d) | 30d? → 117d? |  | 328.33d → 241.33d | constraint finish no earlier than 2007-01-12 → finish no earlier than 2007-05-15; baseline start none → 2006-12-04; baseline finish none → 2007-01-12 |
| 59 | Science Instrument Requirements |  | 2007-01-12 → 2007-05-15 (+123d) | 30d? → 117d? |  | 328.33d → 241.33d | constraint start no earlier than 2006-12-04 → finish no earlier than 2007-05-15; resources Student1 [10.4%] → Le Mignant [10.4%]; baseline start none → 2006-12-04; baseline finish none → 2007-01-12 |
| 60 | **Moons of the Giant Planets** |  | 2007-03-09 → 2007-08-31 (+175d) | 70d? → 195d? |  | 288.33d → 163.33d | baseline start none → 2006-12-04; baseline finish none → 2007-03-09 |
| 61 | Performance Requirements |  | 2007-01-26 → 2007-08-31 (+217d) | 40d? → 195d? |  | 318.33d → 163.33d | constraint start no earlier than 2006-12-04 → finish no earlier than 2007-08-31; baseline start none → 2006-12-04; baseline finish none → 2007-01-26 |
| 62 | Observing Scenarios |  | 2007-03-09 → 2007-08-31 (+175d) | 30d? → 155d? |  | 288.33d → 163.33d | constraint finish no earlier than 2007-03-09 → finish no earlier than 2007-08-31; resources Student1 [10.4%] → Le Mignant [10.4%]; baseline start none → 2007-01-29; baseline finish none → 2007-03-09 |
| 63 | Science Instrument Requirements |  | 2007-03-09 → 2007-08-31 (+175d) | 30d? → 155d? |  | 288.33d → 163.33d | constraint start no earlier than 2007-01-29 → finish no earlier than 2007-08-31; baseline start none → 2007-01-29; baseline finish none → 2007-03-09 |
| 64 | **Shape & Size of Asteroids** |  | 2007-04-06 → 2007-05-15 (+39d) | 50d? → 77d? | 68% → 69% | 268.33d → 241.33d | baseline start none → 2007-01-29; baseline finish none → 2007-04-06 |
| 65 | Spatial Resolution Requirements |  | 2007-03-02 → 2007-05-15 (+74d) | 25d? → 77d? |  | 293.33d → 241.33d | constraint start no earlier than 2007-01-29 → finish no earlier than 2007-05-15; baseline start none → 2007-01-29; baseline finish none → 2007-03-02 |
| 66 | Spectral Sensitivity & Spectral Resolution Requirements |  | 2007-03-02 → 2007-05-15 (+74d) | 25d? → 77d? |  | 293.33d → 241.33d | constraint start no earlier than 2007-01-29 → finish no earlier than 2007-05-15; baseline start none → 2007-01-29; baseline finish none → 2007-03-02 |
| 67 | Observing Scenarios |  | 2007-04-06 → 2007-05-15 (+39d) | 25d? → 52d? |  | 268.33d → 241.33d | constraint finish no earlier than 2007-04-06 → finish no earlier than 2007-05-15; baseline start none → 2007-03-05; baseline finish none → 2007-04-06 |
| 68 | Science Instrument Requirements |  | 2007-04-06 → 2007-05-15 (+39d) | 25d? → 52d? |  | 268.33d → 241.33d | constraint start no earlier than 2007-03-05 → finish no earlier than 2007-05-15; baseline start none → 2007-03-05; baseline finish none → 2007-04-06 |
| 69 | **Galactic Science Requirements** |  | 2007-04-06 → 2007-08-31 (+147d) | 135d? → 240d? | 35% → 43% | 268.33d → 163.33d | baseline start none → 2006-10-02; baseline finish none → 2007-04-06 |
| 70 | **Galactic Center Proper Motions: Astrometry** |  | 2007-01-12 → 2007-07-02 (+171d) | 75d? → 196d? | 60% → 61% | 328.33d → 207.33d | baseline start none → 2006-10-02; baseline finish none → 2007-01-12 |

| ID | Task | Start | Finish | Duration | Complete | Total float | Predecessors | Other |
| --- | --- | --- | --- | --- | --- | --- | --- | --- |
| 71 | Astrometry requirements |  | 2006-12-08 → 2007-07-02 (+206d) | 50d? → 196d? |  | 353.33d → 207.33d |  | constraint start no earlier than 2006-10-02 → finish no earlier than 2007-07-02; baseline start none → 2006-10-02; baseline finish none → 2006-12-08 |
| 72 | Observing Scenarios |  | 2007-01-12 → 2007-07-02 (+171d) | 35d? → 156d? |  | 328.33d → 207.33d |  | constraint finish no earlier than 2007-01-12 → finish no earlier than 2007-07-02; baseline start none → 2006-11-27; baseline finish none → 2007-01-12 |
| 73 | Science Instrument Requirements |  | 2007-01-12 → 2007-07-02 (+171d) | 35d? → 156d? |  | 328.33d → 207.33d |  | constraint start no earlier than 2006-11-27 → finish no earlier than 2007-07-02; baseline start none → 2006-11-27; baseline finish none → 2007-01-12 |
| 74 | **Galactic Center Radial Velocities & Stellar Populations: Integral Field Spectroscopy** |  | 2007-03-09 → 2007-08-01 (+145d) | 75d? → 178d? |  | 288.33d → 185.33d |  | baseline start none → 2006-11-27; baseline finish none → 2007-03-09 |
| 75 | Performance Requirements |  | 2007-01-26 → 2007-08-01 (+187d) | 45d? → 178d? |  | 318.33d → 185.33d |  | constraint finish no earlier than 2007-01-26 → finish no earlier than 2007-08-01; baseline start none → 2006-11-27; baseline finish none → 2007-01-26 |
| 76 | Observing Scenarios |  | 2007-03-09 → 2007-08-01 (+145d) | 30d? → 133d? |  | 288.33d → 185.33d |  | constraint start no earlier than 2007-01-29 → finish no earlier than 2007-08-01; baseline start none → 2007-01-29; baseline finish none → 2007-03-09 |
| 77 | Science Instrument Requirements |  | 2007-03-09 → 2007-08-01 (+145d) | 30d? → 133d? |  | 288.33d → 185.33d |  | constraint start no earlier than 2007-01-29 → finish no earlier than 2007-08-01; baseline start none → 2007-01-29; baseline finish none → 2007-03-09 |
| 78 | Galactic Center Nature of Sgr A*: 3-5 um Color & 2 um Polarimetry Variability |  | 2007-04-06 → 2007-01-29 (-67d) | 50d? → 1d? |  | 268.33d → 317.33d |  | baseline start none → 2007-01-29; baseline finish none → 2007-04-06 |
| 79 | **Planets around Low Mass Stars & Brown Dwarfs: Companion Sensitivity** |  | 2007-01-12 → 2007-06-01 (+140d) | 75d? → 175d? |  | 328.33d → 228.33d |  | baseline start none → 2006-10-02; baseline finish none → 2007-01-12 |
| 80 | Companion Sensitivity Performance Requirements |  | 2006-12-08 → 2007-06-01 (+175d) | 50d? → 175d? |  | 353.33d → 228.33d |  | constraint start no earlier than 2006-10-02 → finish no earlier than 2007-06-01; baseline start none → 2006-10-02; baseline finish none → 2006-12-08 |
| 81 | Observing Scenarios |  | 2007-01-12 → 2007-06-01 (+140d) | 35d? → 135d? |  | 328.33d → 228.33d |  | constraint start no earlier than 2006-11-27 → finish no earlier than 2007-06-01; baseline start none → 2006-11-27; baseline finish none → 2007-01-12 |
| 82 | Science Instrument Requirements |  | 2007-01-12 → 2007-06-01 (+140d) | 35d? → 135d? |  | 328.33d → 228.33d |  | constraint start no earlier than 2006-11-27 → finish no earlier than 2007-06-01; baseline start none → 2006-11-27; baseline finish none → 2007-01-12 |
| 83 | **Debris Disks, Protostellar Envelopes & Outflows: Contrast** |  | 2007-04-06 → 2007-07-02 (+87d) | 50d? → 111d? |  | 268.33d → 207.33d |  | baseline start none → 2007-01-29; baseline finish none → 2007-04-06 |
| 84 | Contrast Performance Requirements |  | 2007-03-02 → 2007-07-02 (+122d) | 25d? → 111d? |  | 293.33d → 207.33d |  | constraint finish no earlier than 2007-03-02 → finish no earlier than 2007-07-02; baseline start none → 2007-01-29; baseline finish none → 2007-03-02 |
| 85 | Observing Scenarios |  | 2007-04-06 → 2007-07-02 (+87d) | 25d? → 86d? |  | 268.33d → 207.33d |  | constraint start no earlier than 2007-03-05 → finish no earlier than 2007-07-02; baseline start none → 2007-03-05; baseline finish none → 2007-04-06 |
| 86 | Science Instrument Requirements |  | 2007-04-06 → 2007-07-02 (+87d) | 25d? → 86d? |  | 268.33d → 207.33d |  | constraint start no earlier than 2007-03-05 → finish no earlier than 2007-07-02; baseline start none → 2007-03-05; baseline finish none → 2007-04-06 |
| 87 | **Debris Disks, Protostellar Envelopes & Outflows: Polarimetry** | 2006-11-27 → 2007-05-15 (+169d) | 2007-03-09 → 2007-08-31 (+175d) | 75d? → 79d? |  | 288.33d → 163.33d |  | baseline start none → 2006-11-27; baseline finish none → 2007-03-09 |
| 88 | Polarimetry Performance Requirements | 2006-11-27 → 2007-05-15 (+169d) | 2007-01-26 → 2007-08-31 (+217d) | 45d? → 79d? |  | 318.33d → 163.33d |  | constraint finish no earlier than 2007-01-26 → start no earlier than 2007-05-15; resources Student2 [41.7%] → Student2 [23.7%]; baseline start none → 2006-11-27; baseline finish none → 2007-01-26 |
| 89 | Observing Scenarios | 2007-01-29 → 2007-05-15 (+106d) | 2007-03-09 → 2007-08-31 (+175d) | 30d? → 79d? |  | 288.33d → 163.33d |  | constraint start no earlier than 2007-01-29 → start no earlier than 2007-05-15; resources Student2 [10.4%] → Student2 [4%]; baseline start none → 2007-01-29; baseline finish none → 2007-03-09 |
| 90 | Science Instrument Requirements | 2007-01-29 → 2007-05-15 (+106d) | 2007-03-09 → 2007-08-31 (+175d) | 30d? → 79d? |  | 288.33d → 163.33d |  | constraint start no earlier than 2007-01-29 → start no earlier than 2007-05-15; resources Student2 [10.4%] → Student2 [4%]; baseline start none → 2007-01-29; baseline finish none → 2007-03-09 |
| 91 | **Extragalactic Science Requirements** |  | 2007-04-27 → 2007-10-01 (+157d) | 150d? → 262d? | 51% → 52% | 253.33d → 141.33d |  | baseline start none → 2006-10-02; baseline finish none → 2007-04-27 |
| 92 | **Resolved Stellar Populations in Crowded Fields** |  | 2007-02-02 → 2007-10-01 (+241d) | 90d? → 262d? |  | 313.33d → 141.33d |  | baseline start none → 2006-10-02; baseline finish none → 2007-02-02 |
| 93 | Performance Requirements |  | 2006-12-22 → 2007-10-01 (+283d) | 60d? → 261d? |  | 343.33d → 141.33d |  | constraint start no earlier than 2006-10-02 → finish no earlier than 2007-10-01; resources Postdoc [52.1%] → McGraw [52.1%]; baseline start none → 2006-10-02; baseline finish none → 2006-12-22 |
| 94 | Observing Scenarios |  | 2007-02-02 → 2007-10-01 (+241d) | 40d? → 211d? |  | 313.33d → 141.33d |  | constraint finish no earlier than 2007-02-02 → finish no earlier than 2007-10-01; resources Postdoc [7.8%] → McGraw [7.8%]; baseline start none → 2006-12-11; baseline finish none → 2007-02-02 |
| 95 | Science Instrument Requirements |  | 2007-02-02 → 2007-10-01 (+241d) | 40d? → 211d? |  | 313.33d → 141.33d |  | constraint start no earlier than 2006-12-11 → finish no earlier than 2007-10-01; resources Postdoc [7.8%] → McGraw [7.8%]; baseline start none → 2006-12-11; baseline finish none → 2007-02-02 |
| 96 | **High Redshift Galaxies** |  | 2007-02-02 → 2007-06-01 (+119d) | 90d? → 175d? |  | 313.33d → 228.33d |  | baseline start none → 2006-10-02; baseline finish none → 2007-02-02 |
| 97 | Encircled Energy (& d-IFU) Performance Requirements |  | 2006-12-22 → 2007-06-01 (+161d) | 60d? → 175d? |  | 343.33d → 228.33d |  | constraint start no earlier than 2006-10-02 → finish no earlier than 2007-06-01; resources Postdoc [41.7%] → McGraw [41.7%]; baseline start none → 2006-10-02; baseline finish none → 2006-12-22 |
| 98 | Observing Scenarios |  | 2007-02-02 → 2007-06-01 (+119d) | 40d? → 125d? |  | 313.33d → 228.33d |  | constraint start no earlier than 2006-12-11 → finish no earlier than 2007-06-01; resources Postdoc [15.6%] → McGraw [15.6%]; baseline start none → 2006-12-11; baseline finish none → 2007-02-02 |
| 99 | Science Instrument Requirements |  | 2007-02-02 → 2007-06-01 (+119d) | 40d? → 125d? |  | 313.33d → 228.33d |  | constraint start no earlier than 2006-12-11 → finish no earlier than 2007-06-01; resources Postdoc [15.6%] → McGraw [15.6%]; baseline start none → 2006-12-11; baseline finish none → 2007-02-02 |
| 100 | **Nearby Galaxies** |  | 2007-04-27 → 2007-08-31 (+126d) | 100d? → 190d? |  | 253.33d → 163.33d |  | baseline start none → 2006-12-11; baseline finish none → 2007-04-27 |
| 101 | Encircled Energy & PSF Performance Requirements |  | 2007-03-02 → 2007-08-31 (+182d) | 60d? → 190d? |  | 293.33d → 163.33d |  | constraint finish no earlier than 2007-03-02 → finish no earlier than 2007-08-31; resources Postdoc [31.2%] → McGraw [31.2%]; baseline start none → 2006-12-11; baseline finish none → 2007-03-02 |
| 102 | Observing Scenarios |  | 2007-04-27 → 2007-08-31 (+126d) | 40d? → 130d? |  | 253.33d → 163.33d |  | constraint finish no earlier than 2007-04-27 → finish no earlier than 2007-08-31; resources Postdoc [7.8%] → McGraw [7.8%]; baseline start none → 2007-03-05; baseline finish none → 2007-04-27 |
| 103 | Science Instrument Requirements |  | 2007-04-27 → 2007-08-31 (+126d) | 40d? → 130d? |  | 253.33d → 163.33d |  | constraint start no earlier than 2007-03-05 → finish no earlier than 2007-08-31; resources Postdoc [7.8%] → McGraw [7.8%]; baseline start none → 2007-03-05; baseline finish none → 2007-04-27 |
| 104 | **Gravitational Lensing** |  | 2007-04-27 → 2007-07-02 (+66d) | 100d? → 146d? | 39% → 38% | 253.33d → 207.33d |  | baseline start none → 2006-12-11; baseline finish none → 2007-04-27 |
| 105 | Encircled Energy & PSF Performance Requirements |  | 2007-03-02 → 2007-07-02 (+122d) | 60d? → 146d? |  | 293.33d → 207.33d |  | constraint start no earlier than 2006-12-11 → finish no earlier than 2007-07-02; resources Postdoc [31.2%] → McGraw [31.2%]; baseline start none → 2006-12-11; baseline finish none → 2007-03-02 |
| 106 | Observing Scenarios |  | 2007-04-27 → 2007-07-02 (+66d) | 40d? → 86d? |  | 253.33d → 207.33d |  | constraint start no earlier than 2007-03-05 → finish no earlier than 2007-07-02; resources Postdoc [7.8%] → McGraw [7.8%]; baseline start none → 2007-03-05; baseline finish none → 2007-04-27 |
| 107 | Science Instrument Requirements |  | 2007-04-27 → 2007-07-02 (+66d) | 40d? → 86d? |  | 253.33d → 207.33d |  | constraint start no earlier than 2007-03-05 → finish no earlier than 2007-07-02; resources Postdoc [7.8%] → McGraw [7.8%]; baseline start none → 2007-03-05; baseline finish none → 2007-04-27 |
| 108 | **Science Case Requirements Document** |  |  | 271d? → 272d? | 25% → 14% | 122.83d → 131.33d |  | was named Science Requirements Summary; baseline start none → 2006-10-02; baseline finish none → 2007-10-15 |
| 109 | Science Case Requirements Doc Rev 1 |  |  |  |  |  |  | was named Science Requirements Summary Rev 1; baseline start none → 2006-10-02; baseline finish none → 2006-10-19 |
| 110 | Science Case Requirements Doc Rev 2 | 2007-02-13 → 2007-04-02 (+48d) | 2007-03-02 → 2007-06-01 (+91d) | 14d? → 45d? |  | 283.83d → 228.33d |  | was named Science Requirements Summary Rev 2; constraint start no earlier than 2007-02-13 → start no earlier than 2007-04-02; resources Max [89.3%]; Wizinowich [17.9%] → Max [27.8%]; Wizinowich [5.6%]; baseline start none → 2007-02-13; baseline finish none → 2007-03-02 |
| 111 | Science Case Requirements Doc Rev 3 |  | 2007-06-22 → 2007-07-09 (+17d) | 13.89d? → 24.89d? |  | 203.33d → 192.33d |  | was named Science Requirements Summary Rev 3; constraint finish no earlier than 2007-06-22 → finish no earlier than 2007-07-09; resources Max [18%]; Wizinowich [18%] → Max [10%]; Wizinowich [10%]; baseline start none → 2007-06-05; baseline finish none → 2007-06-22 |
| 112 | Science Case Requirements Doc Final |  |  |  |  | 81.33d → 80.33d |  | was named Science Requirements Summary Final; baseline start none → 2007-09-26; baseline finish none → 2007-10-15 |
| 113 | **Observatory Requirements** |  |  |  |  |  |  | baseline start none → 2006-10-02; baseline finish none → 2007-09-07 |
| 114 | Development Requirements |  |  |  |  |  |  | baseline start none → 2006-10-02; baseline finish none → 2006-11-24 |
| 115 | Observatory Interface Requirements |  |  |  |  |  |  | baseline start none → 2006-10-02; baseline finish none → 2006-10-27 |
| 116 | Science Operations Requirements |  |  |  |  |  |  | baseline start none → 2006-10-02; baseline finish none → 2006-11-24 |
| 117 | Observatory Requirements Rev 2 |  |  |  |  |  |  | baseline start none → 2007-01-22; baseline finish none → 2007-02-09 |
| 118 | Observatory Requirements Rev 3 |  |  |  |  |  |  | baseline start none → 2007-04-09; baseline finish none → 2007-05-18 |
| 119 | Observatory Requirements Rev 4 |  |  |  |  |  |  | baseline start none → 2007-07-16; baseline finish none → 2007-09-07 |
| 120 | **System Requirements Document** |  |  | 280d? → 281d? | 19% → 17% | 118.33d → 117.33d |  | baseline start none → 2006-10-09; baseline finish none → 2007-11-02 |
| 121 | **Traceability Matrix** |  |  | 270d? → 271d? |  | 128.33d → 127.33d |  | baseline start none → 2006-10-09; baseline finish none → 2007-10-20 |
| 122 | Traceability Matrix Rev 1 |  |  |  |  |  |  | baseline start none → 2006-10-09; baseline finish none → 2006-10-20 |
| 123 | Traceability Matrix Rev 2 |  |  |  |  | 286.83d → 275.43d |  | constraint start no earlier than 2007-02-12 → finish no earlier than 2007-02-27; resources Neyman [25%]; Wizinowich [25%]; Adkins [25%]; Flicker [25%] → Wizinowich [10.4%]; baseline start none → 2007-02-12; baseline finish none → 2007-02-27 |
| 124 | Traceability Matrix Rev 3 |  |  |  |  |  |  | baseline start none → 2007-06-15; baseline finish none → 2007-06-28 |
| 125 | Traceability Matrix Rev 4 |  |  |  |  | 77.33d → 76.33d |  | baseline start none → 2007-10-09; baseline finish none → 2007-10-20 |
| 126 | **System Requirements Document** |  |  | 245d → 246d | 26% → 21% | 118.33d → 117.33d |  | baseline start none → 2006-11-27; baseline finish none → 2007-11-02 |
| 127 | SRD Rev 1 |  |  |  |  |  | 109, 122, 114, 115, 116 → 109, 122, 114, 115 | baseline start none → 2006-11-27; baseline finish none → 2006-12-08 |
| 128 | SRD Rev 2 | 2007-03-09 A → 2007-04-16 A (+38d) | 2007-03-22 → 2007-05-15 (+54d) | 10d → 22d |  | 279.33d → 241.33d | 110, 123, 117 → 123, 117, 109 | constraint start no earlier than 2007-03-09 → finish no earlier than 2007-05-15; resources Neyman [25%] → Wizinowich [25%]; baseline start none → 2007-03-09; baseline finish none → 2007-03-22 |
| 129 | SRD Rev 3 | 2007-06-29 → 2007-07-17 (+18d) | 2007-07-12 → 2007-07-30 (+18d) |  |  | 199.33d → 187.33d |  | constraint start no earlier than 2007-06-29 → finish no earlier than 2007-07-30; resources Neyman [25%] → Wizinowich [25%]; baseline start none → 2007-06-29; baseline finish none → 2007-07-12 |
| 130 | SRD Final SD Phase Version |  |  |  |  | 77.33d → 76.33d |  | resources Neyman [25%] → Wizinowich [25%]; baseline start none → 2007-10-22; baseline finish none → 2007-11-02 |
| 131 | **System Design** |  | 2008-01-18 → 2008-03-21 (+63d) | 375d? → 421d? | 18% → 26% | 63.33d → 17.33d |  | baseline start none → 2006-08-14; baseline finish none → 2008-01-18 |
| 132 | **Systems Engineering** |  | 2007-12-28 → 2008-02-01 (+35d) | 360d? → 385d? | 44% → 51% | 78.33d → 53.33d |  | baseline start none → 2006-08-14; baseline finish none → 2007-12-28 |
| 133 | **Performance Budgets** |  | 2007-12-12 → 2007-12-13 (+1d) | 348d? → 349.75d? | 57% → 54% | 90.33d → 88.58d |  | baseline start none → 2006-08-14; baseline finish none → 2007-12-12 |
| 134 | **Model Assumptions** |  |  |  |  |  |  | baseline start none → 2006-08-14; baseline finish none → 2007-06-29 |
| 135 | **TMT site monitoring data mining** |  |  |  |  |  |  | baseline start none → 2006-08-14; baseline finish none → 2007-06-29 |
| 136 | Tools in place & 1st release |  |  |  |  |  |  | baseline start none → 2006-08-14; baseline finish none → 2006-09-14 |
| 137 | Release updated data (every two months) |  |  |  |  |  |  | baseline start none → 2006-09-18; baseline finish none → 2007-06-29 |
| 138 | Telescope dynamic performance data |  |  |  |  |  |  | baseline start none → 2006-10-02; baseline finish none → 2006-11-30 |
| 139 | Telescope static wavefront errors |  |  |  |  |  |  | baseline start none → 2006-10-02; baseline finish none → 2006-11-30 |
| 140 | Sodium return vs laser format |  |  |  |  |  |  | baseline start none → 2006-11-01; baseline finish none → 2006-11-30 |

| ID | Task | Start | Finish | Duration | Complete | Total float | Predecessors | Other |
| --- | --- | --- | --- | --- | --- | --- | --- | --- |
| 141 | **Model/Tool Validation** |  | 2006-12-15 → 2007-06-29 (+196d) | 90d? → 230d? | 71% → 45% | 167.83d → 208.33d |  | baseline start none → 2006-08-14; baseline finish none → 2006-12-15 |
| 142 | Agreement between Tomography Codes |  |  |  |  |  |  | baseline start none → 2006-08-14; baseline finish none → 2006-09-29 |
| 143 | Agreement between Sky Coverage Codes |  |  |  |  |  |  | baseline start none → 2006-10-16; baseline finish none → 2006-11-03 |
| 144 | Anchor to Keck II LGS AO PSFs |  | 2006-10-30 → 2007-06-29 (+242d) | 21d? → 195d? |  | 201.83d → 208.33d |  | constraint finish no earlier than 2006-10-30 → finish no earlier than 2007-06-29; baseline start none → 2006-10-02; baseline finish none → 2006-10-30 |
| 145 | Anchor to On-sky MGSU Experiments |  |  |  |  |  |  | baseline start none → 2006-11-10; baseline finish none → 2006-11-15 |
| 146 | Anchor to LAO Lab Experiments |  | 2006-12-15 → 2007-06-29 (+196d) | 30d? → 170d? |  | 167.83d → 208.33d |  | constraint start no earlier than 2006-11-06 → finish no earlier than 2007-06-29; baseline start none → 2006-11-06; baseline finish none → 2006-12-15 |
| 147 | Throughput |  | 2006-12-29 → 2007-05-18 (+140d) | 65d? → 165d? |  | 203.83d → 173.14d |  | constraint start no earlier than 2006-10-02 → finish no earlier than 2007-05-18; baseline start none → 2006-10-02; baseline finish none → 2006-12-29 |
| 148 | **Background** |  | 2007-01-09 → 2007-05-18 (+129d) | 71.5d? → 165d? | 47% → 50% | 197.33d → 173.14d |  | baseline start none → 2006-10-02; baseline finish none → 2007-01-09 |
| 149 | Document Proposal Analysis |  | 2006-10-12 → 2006-10-02 (-10d) | 9d? → 0.9d? |  | 259.83d → 337.24d |  | baseline start none → 2006-10-02; baseline finish none → 2006-10-12 |
| 150 | Develop Background Performance Budget |  | 2007-01-09 → 2007-05-18 (+129d) | 62.5d? → 156d? |  | 197.33d → 173.14d |  | constraint start no earlier than 2006-10-02 → finish no earlier than 2007-05-18; baseline start none → 2006-10-02; baseline finish none → 2007-01-09 |
| 151 | **Wavefront Error vs Sky Coverage** |  | 2007-01-30 → 2007-09-28 (+241d) | 87d? → 261d? | 33% → 34% | 160.83d → 77.14d |  | baseline start none → 2006-10-02; baseline finish none → 2007-01-30 |
| 152 | Document WFE Budget Rev 1 |  | 2006-12-08 → 2007-05-04 (+147d) | 50d? → 155d? |  | 197.83d → 35.28d |  | constraint start no earlier than 2006-10-02 → finish no earlier than 2007-05-04; baseline start none → 2006-10-02; baseline finish none → 2006-12-08 |
| 153 | Document WFE Budget Rev 2 | 2006-12-27 → 2007-06-19 (+174d) | 2007-01-30 → 2007-09-28 (+241d) | 25d? → 75d? |  | 160.83d → 77.14d | 136, 140, 141, 180 → 136, 140, 180, 142, 143 | constraint finish no earlier than 2007-01-30 → finish no earlier than 2007-09-28; resources Dekany [20%]; Flicker [17%] → Dekany [6.7%]; Flicker [17%]; baseline start none → 2006-12-27; baseline finish none → 2007-01-30 |
| 154 | Encircled Energy vs Sky Coverage |  | 2006-12-29 → 2007-05-04 (+126d) | 50d? → 140d? |  |  |  | constraint start no earlier than 2006-10-23 → finish no earlier than 2007-05-04; baseline start none → 2006-10-23; baseline finish none → 2006-12-29 |
| 155 | Photometric Accuracy |  |  |  |  |  |  | baseline start none → 2006-10-16; baseline finish none → 2007-01-26 |
| 156 | Astrometric Accuracy |  |  |  |  |  |  | baseline start none → 2006-11-13; baseline finish none → 2007-06-29 |
| 157 | Polarimetric Accuracy |  | 2007-03-09 → 2007-05-25 (+77d) | 25d? → 80d? |  | 153.83d → 168.14d |  | constraint start no earlier than 2007-02-05 → finish no earlier than 2007-05-25; baseline start none → 2007-02-05; baseline finish none → 2007-03-09 |
| 158 | Companion Sensitivity |  | 2007-01-09 → 2007-05-25 (+136d) | 41.25d? → 140d? |  | 176.58d → 20.28d |  | constraint start no earlier than 2006-11-13 → finish no earlier than 2007-05-25; baseline start none → 2006-11-13; baseline finish none → 2007-01-09 |
| 159 | Observing Efficiency |  | 2007-03-16 → 2007-05-25 (+70d) | 30d? → 80d? |  | 148.83d → 168.14d |  | constraint start no earlier than 2007-02-05 → finish no earlier than 2007-05-25; baseline start none → 2007-02-05; baseline finish none → 2007-03-16 |
| 160 | Observing Uptime | 2007-11-05 A → 2007-08-27 A (-70d) | 2007-12-12 → 2007-09-28 (-75d) | 28d? → 26d? | 25% → 27% | 90.33d → 77.14d |  | constraint start no earlier than 2007-11-05 → finish no earlier than 2007-09-28; resources Chin [17.9%]; Johansson [17.9%] → Chin [19.7%]; Johansson [19.7%]; baseline start none → 2007-11-05; baseline finish none → 2007-12-12 |
| 161 | **Performance Budgets Summary** | 2007-01-31 → 2007-05-28 (+117d) | 2007-07-20 → 2007-10-19 (+91d) | 123d? → 106d? |  | 73.83d → 20.28d |  | baseline start none → 2007-01-31; baseline finish none → 2007-07-20 |
| 162 | Performance Budgets Summary Ver 1 | 2007-01-31 → 2007-05-28 (+117d) | 2007-02-27 → 2007-06-08 (+101d) | 20d? → 10d? |  | 160.83d → 20.28d | 151, 154, 155, 158 → 154, 155, 158, 152 | constraint start no earlier than 2007-01-15 → start no earlier than 2007-05-28; resources Dekany [25%]; Neyman [37.5%] → Britton [50%]; baseline start none → 2007-01-31; baseline finish none → 2007-02-27 |
| 163 | Performance Budgets Summary Ver 2 | 2007-07-02 → 2007-10-01 (+91d) | 2007-07-20 → 2007-10-19 (+91d) |  |  | 73.83d → 77.14d | 151, 154, 155, 156, 157, 158, 159, 147, 148 → 151, 154, 155, 156, 157, 158, 159, 147, 148, 160 | resources Dekany [16.7%]; Neyman [33.3%] → Dekany [16.7%]; Britton [33.3%]; baseline start none → 2007-07-02; baseline finish none → 2007-07-20 |
| 164 | **Science Products** | 2007-07-23 → 2007-10-22 (+91d) | 2007-10-19 → 2007-12-13 (+55d) | 65d? → 38.75d? |  | 128.33d → 88.58d |  | baseline start none → 2007-07-23; baseline finish none → 2007-10-19 |
| 165 | All-In Science Simulations | 2007-07-23 → 2007-10-22 (+91d) | 2007-08-17 → 2007-11-16 (+91d) |  |  | 154.58d → 88.58d |  | constraint start no earlier than 2007-07-16 → finish no earlier than 2007-11-16; resources Neyman [50%]; Flicker [50%] → Neyman [25%]; Flicker [25%]; baseline start none → 2007-07-23; baseline finish none → 2007-08-17 |
| 166 | **Additional Science Characterization Results** | 2007-08-20 → 2007-11-19 (+91d) | 2007-10-19 → 2007-12-13 (+55d) | 45d? → 18.75d? |  | 128.33d → 88.58d |  | baseline start none → 2007-08-20; baseline finish none → 2007-10-19 |
| 167 | Point Source Sensitivities | 2007-08-20 → 2007-11-19 (+91d) | 2007-09-13 → 2007-12-13 (+91d) |  |  | 154.58d → 88.58d |  | baseline start none → 2007-08-20; baseline finish none → 2007-09-13 |
| 168 | PSF Uniformity & Stability | 2007-08-20 → 2007-11-19 (+91d) | 2007-09-07 → 2007-12-07 (+91d) |  |  | 158.33d → 92.33d |  | baseline start none → 2007-08-20; baseline finish none → 2007-09-07 |
| 169 | Other | 2007-10-01 → 2007-11-19 (+49d) | 2007-10-19 → 2007-11-22 (+34d) | 15d? → 3.75d? |  | 128.33d → 103.58d |  | constraint start no earlier than 2007-10-01 → start no earlier than 2007-11-19; baseline start none → 2007-10-01; baseline finish none → 2007-10-19 |
| 170 | **Trade Studies** |  | 2007-05-25 → 2007-06-01 (+7d) | 160d? → 165d? | 41% → 64% | 113.83d → 25.28d |  | baseline start none → 2006-10-16; baseline finish none → 2007-05-25 |
| 171 | **System Architecture Trade Studies** |  | 2007-03-30 → 2007-05-18 (+49d) | 120d? → 155d? | 69% → 74% | 153.83d → 35.28d |  | baseline start none → 2006-10-16; baseline finish none → 2007-03-30 |
| 172 | MOAO & MCAO TS |  |  |  |  |  |  | baseline start none → 2006-11-13; baseline finish none → 2006-12-15 |
| 173 | NGAO versus Keck AO upgrades TS (meeting 5) |  |  |  |  |  |  | baseline start none → 2007-02-05; baseline finish none → 2007-03-02 |
| 174 | Adaptive Secondary Mirror option TS (m5) | 2007-03-05 A → 2007-04-06 A (+32d) | 2007-03-30 → 2007-04-30 (+31d) | 20d? → 17d? |  | 153.83d → 0d |  | constraint start no earlier than 2007-03-05 → finish no earlier than 2007-04-30; resources Bauman [15%]; Wizinowich [10%] → Bauman [15%]; Wizinowich [12.5%]; baseline start none → 2007-03-05; baseline finish none → 2007-03-30 |
| 175 | K & L-band Science TS (m5) |  | 2007-03-02 → 2007-02-05 (-25d) | 20d? → 0.5d? |  | 173.83d → 109.78d |  | baseline start none → 2007-02-05; baseline finish none → 2007-03-02 |
| 176 | Keck Interferometer Support TS (m5) |  |  |  |  |  |  | baseline start none → 2006-10-16; baseline finish none → 2007-03-02 |
| 177 | Instrument Balance TS |  | 2006-12-08 → 2006-11-14 (-24d) | 20d? → 2d? |  | 233.83d → 168.28d |  | baseline start none → 2006-11-13; baseline finish none → 2006-12-08 |
| 178 | GLAO for non-NGAO Instruments TS (m5) |  |  |  |  |  |  | baseline start none → 2007-02-05; baseline finish none → 2007-03-02 |
| 179 | Science Instrument Re-use Cost/Benefit TS (m3) |  | 2006-12-08 → 2007-05-18 (+161d) | 20d? → 135d? |  | 233.83d → 35.28d |  | constraint start no earlier than 2006-11-13 → finish no earlier than 2007-05-18; baseline start none → 2006-11-13; baseline finish none → 2006-12-08 |
| 180 | Telescope Wavefront Errors TS |  |  |  |  |  |  | baseline start none → 2006-12-04; baseline finish none → 2006-12-20 |
| 181 | Observing Model TS |  | 2007-01-12 → 2007-05-04 (+112d) | 45d? → 125d? |  | 208.83d → 45.28d |  | constraint finish no earlier than 2007-01-12 → finish no earlier than 2007-05-04; baseline start none → 2006-11-13; baseline finish none → 2007-01-12 |
| 182 | **Adaptive Optics System Trade Studies** |  | 2007-05-25 → 2007-04-23 (-32d) | 150d? → 125.62d? | 30% → 54% | 113.83d → 54.66d |  | baseline start none → 2006-10-30; baseline finish none → 2007-05-25 |
| 183 | AO Enclosure Temperature TS (m6) |  | 2007-04-13 → 2007-01-03 (-100d) | 74d? → 1.06d? |  | 143.83d → 133.22d |  | baseline start none → 2007-01-02; baseline finish none → 2007-04-13 |
| 184 | Optical Relay TS (m6) |  |  |  |  | 85.83d → 60.28d |  | baseline start none → 2007-01-02; baseline finish none → 2007-04-13 |
| 185 | Field Rotation Strategy TS (m6) |  |  |  |  | 91.33d → 60.28d |  | resources Bauman [10.1%]; Meguro [3.4%] → Bauman [10.1%]; Dekany [3.4%]; baseline start none → 2007-01-02; baseline finish none → 2007-04-13 |
| 186 | Dichroics & Beamsplitters TS (m6) |  | 2007-04-13 → 2007-01-03 (-100d) | 74d? → 1.23d? |  | 118.83d → 133.05d |  | baseline start none → 2007-01-02; baseline finish none → 2007-04-13 |
| 187 | Rayleigh Rejection TS (m3) |  |  |  |  | 233.83d → 150.28d |  | baseline start none → 2006-10-30; baseline finish none → 2006-12-08 |
| 188 | LGS WFS Type TS (m4) |  |  |  |  |  |  | baseline start none → 2006-12-04; baseline finish none → 2007-01-19 |
| 189 | LGS WFS number of subapertures TS (m4) |  |  |  |  |  |  | baseline start none → 2006-12-04; baseline finish none → 2007-01-19 |
| 190 | Slow WFS TS (m7) |  | 2007-05-25 → 2007-04-23 (-32d) | 25d? → 0.31d? |  | 35.83d → 54.97d |  | baseline start none → 2007-04-23; baseline finish none → 2007-05-25 |
| 191 | LOWFS Architecture TS |  |  |  |  |  |  | baseline start none → 2006-12-04; baseline finish none → 2007-02-09 |
| 192 | Number & Type of LOWFS TS (m4) |  |  |  |  |  |  | baseline start none → 2006-12-04; baseline finish none → 2007-01-26 |
| 193 | Centroid Anisoplanatism TS (m7) |  | 2007-05-25 → 2007-04-23 (-32d) | 25d? → 0.62d? |  | 113.83d → 54.66d |  | baseline start none → 2007-04-23; baseline finish none → 2007-05-25 |
| 194 | Deformable Mirror Stroke Requirement TS (m6) |  | 2007-04-13 → 2007-01-03 (-100d) | 74d? → 1.48d? |  | 143.83d → 132.8d |  | baseline start none → 2007-01-02; baseline finish none → 2007-04-13 |
| 195 | Stand-alone vs DM on T/T Stage TS (m3) |  | 2006-12-08 → 2006-10-30 (-39d) | 30d? → 0.5d? |  | 233.83d → 179.78d |  | baseline start none → 2006-10-30; baseline finish none → 2006-12-08 |
| 196 | Correcting Fast T/T with DM TS | 2006-10-30 → 2006-12-08 (+39d) |  | 30d? → 0.75d? |  | 233.83d → 150.28d |  | baseline start none → 2006-10-30; baseline finish none → 2006-12-08 |
| 197 | Focus Compensation TS (m6) |  | 2007-05-03 → 2007-01-24 (-99d) | 74d? → 2.47d? |  | 129.83d → 117.81d |  | baseline start none → 2007-01-22; baseline finish none → 2007-05-03 |
| 198 | **Laser Facility Trade Studies** |  | 2007-03-05 → 2007-06-01 (+88d) | 101d? → 165d? | 35% → 37% | 144.83d → 25.28d |  | baseline start none → 2006-10-16; baseline finish none → 2007-03-05 |
| 199 | Laser Pulse Format TS (m6) |  | 2007-01-29 → 2007-01-02 (-27d) | 20d? → 0.25d? |  | 151.08d → 133.84d |  | baseline start none → 2007-01-02; baseline finish none → 2007-01-29 |
| 200 | Free Space vs Fiber TS (m7) |  | 2007-03-05 → 2007-01-30 (-34d) | 25d? → 0.25d? |  | 144.83d → 114.03d |  | baseline start none → 2007-01-30; baseline finish none → 2007-03-05 |
| 201 | LGS Asterism Geometry & Size TS (m2) |  |  |  |  |  |  | baseline start none → 2006-10-23; baseline finish none → 2006-10-27 |
| 202 | Variable vs fixed LGS Asterism Cost/Benefit TS (m2) |  |  |  |  |  |  | baseline start none → 2006-10-16; baseline finish none → 2006-10-27 |
| 204 | **System Architecture** | 2007-02-28 → 2007-05-08 (+69d) | 2007-12-28 → 2008-02-01 (+35d) | 218d? → 194d? |  | 78.33d → 5.14d |  | baseline start none → 2007-02-28; baseline finish none → 2007-12-28 |
| 205 | **Candidate Subsystems** | 2007-02-28 → 2007-05-10 (+71d) | 2007-04-18 → 2007-07-04 (+77d) | 36d? → 39.14d? |  | 160.83d → 3.14d | 162 → none | was named System Architecture Ver 1; constraint start no earlier than 2006-11-01 → none; resources Dekany [10.4%]; Gavel [10.4%]; Wizinowich [6.9%] → none; baseline start none → 2007-02-28; baseline finish none → 2007-04-18 |
| 211 | **Candidate Architectures** | 2007-07-23 → 2007-07-04 (-19d) | 2007-08-17 → 2007-12-28 (+133d) | 20d? → 127.86d? |  | 73.83d → 3.14d | 163, 171, 182, 198 → 171, 182, 198, 162, 210 | was named System Architecture Ver 2; resources Dekany [12.5%]; Gavel [12.5%]; Wizinowich [12.5%] → none; baseline start none → 2007-07-23; baseline finish none → 2007-08-17 |
| 219 | **Functional Requirements** | 2007-04-19 → 2007-05-08 (+19d) | 2007-11-30 → 2008-02-01 (+63d) | 162d? → 194d? |  | 23.83d → 3.14d |  | baseline start none → 2007-04-19; baseline finish none → 2007-11-30 |
| 221 | AO System Functional Requirements Ver 1 | 2007-04-19 → 2007-08-06 (+109d) | 2007-05-14 → 2007-08-29 (+107d) |  |  | 168.58d → 115.89d |  | constraint finish no earlier than 2007-02-02 → start no earlier than 2007-08-06; resources Neyman [54.3%]; Chin [18.1%]; Stomski [18.1%]; Meguro [18.1%]; Bauman [18.1%]; Johansson [18.1%] → Neyman [54.3%]; Chin [18.1%]; Stomski [18.1%]; Meguro [18.1%]; Bauman [18.1%]; Johansson [18.1%]; Wizinowich [34%]; baseline start none → 2007-04-19; baseline finish none → 2007-05-14 |
| 222 | AO System Functional Requirements Ver 2 | 2007-10-29 → 2007-12-28 (+60d) | 2007-11-30 → 2008-01-16 (+47d) | 25d? → 13.33d? |  | 23.83d → 14.8d |  | baseline start none → 2007-10-29; baseline finish none → 2007-11-30 |
| 223 | Laser System Functional Requirements Ver 1 | 2007-04-19 → 2007-07-04 (+76d) | 2007-05-16 → 2007-08-01 (+77d) |  |  | 165.83d → 135.99d |  | resources Chin [34.4%]; Velur [34.4%]; Stomski [15.6%] → Chin [34.4%]; Velur [34.4%]; Stomski [15.6%]; Meguro [27%]; Wizinowich [34%]; baseline start none → 2007-04-19; baseline finish none → 2007-05-16 |
| 224 | Laser System Functional Requirements Ver 2 | 2007-10-29 → 2007-12-28 (+60d) | 2007-11-30 → 2008-01-25 (+56d) | 25d? → 20d? |  | 23.83d → 8.14d |  | baseline start none → 2007-10-29; baseline finish none → 2007-11-30 |

| ID | Task | Start | Finish | Duration | Total float | Predecessors | Other |
| --- | --- | --- | --- | --- | --- | --- | --- |
| 225 | Science Operations Functional Requirements Ver 1 | 2007-04-19 → 2007-07-04 (+76d) | 2007-05-22 → 2007-08-07 (+77d) |  | 161.83d → 131.99d |  | resources Le Mignant [20.8%]; Other [31.2%] → Le Mignant [20.8%]; Wizinowich [31.2%]; baseline start none → 2007-04-19; baseline finish none → 2007-05-22 |
| 226 | Science Operations Functional Requirements Ver 2 | 2007-10-29 → 2007-12-28 (+60d) | 2007-11-30 → 2008-02-01 (+63d) |  | 23.83d → 3.14d |  | baseline start none → 2007-10-29; baseline finish none → 2007-11-30 |
| 227 | Science Instruments Function Allocation Ver 1 | 2007-04-19 → 2007-05-08 (+19d) | 2007-05-14 → 2007-05-31 (+17d) |  | 167.83d → 179.14d | 205 → 311 | constraint start no earlier than 2007-01-02 → finish no earlier than 2007-05-31; resources Adkins [20.8%]; Moore [34.7%] → Adkins [4.2%]; Wizinowich [34.7%]; baseline start none → 2007-04-19; baseline finish none → 2007-05-14 |
| 228 | Science Instruments Function Allocation Ver 2 | 2007-10-29 → 2008-01-14 (+77d) | 2007-11-14 → 2008-01-17 (+64d) | 12.5d? → 3.75d? | 36.33d → 13.39d | 211 → 314 | constraint start no earlier than 2007-10-29 → finish no earlier than 2007-06-29; resources Adkins [20%]; Moore [60%] → Adkins [20%]; Wizinowich [60%]; baseline start none → 2007-10-29; baseline finish none → 2007-11-14 |
| 229 | Technology Drivers Summary | 2007-07-23 → 2007-10-23 (+92d) | 2007-07-26 → 2007-10-25 (+91d) | 3.63d? → 2.27d? | 135.2d → 123.33d | 205, 163, 171, 182, 198 → 216 | constraint none → finish no earlier than 2007-10-25; resources Neyman [82.7%]; Gavel [55.1%] → Gavel [55.1%]; baseline start none → 2007-07-23; baseline finish none → 2007-07-26 |
| 230 | Technical Risk Analysis Ver 1 | 2007-07-26 → 2007-08-27 (+32d) | 2007-08-28 → 2007-09-14 (+17d) | 23d? → 15d? | 166.7d → 153.33d | 229 → 216 | constraint start no earlier than 2007-03-19 → finish no earlier than 2007-09-14; resources Neyman [13%]; Gavel [8.7%] → Neyman [8.3%]; baseline start none → 2007-07-26; baseline finish none → 2007-08-28 |
| 231 | Technical Risk Analysis Ver 2 | 2007-12-03 → 2007-12-28 (+25d) | 2007-12-28 → 2008-01-25 (+28d) |  | 23.83d → 8.14d | 219 → 218 | baseline start none → 2007-12-03; baseline finish none → 2007-12-28 |
| 232 | **AO System** | 2007-03-05 → 2007-06-18 (+105d) | 2007-12-14 → 2007-12-18 (+4d) | 205d? → 132.86d? | 33.83d → 3.14d |  | baseline start none → 2007-03-05; baseline finish none → 2007-12-14 |
| 233 | AO System Architecture | 2007-04-19 → 2007-08-22 (+125d) | 2007-06-20 → 2007-11-13 (+146d) | 45d? → 60d? | 160.83d → 28.14d | 205 → 216 | resources Neyman [13.9%]; Gavel [8.3%]; Johansson [11.1%]; Bauman [11.1%]; Velur [11.1%]; Wizinowich [5.6%]; Dekany [5.6%] → Gavel [8.3%]; baseline start none → 2007-04-19; baseline finish none → 2007-06-20 |
| 234 | AO Enclosure | 2007-05-14 → 2007-08-22 (+100d) | 2007-08-17 → 2007-09-28 (+42d) | 70d? → 28d? | 118.83d → 60.14d | 237SS+4w → 216 | baseline start none → 2007-05-14; baseline finish none → 2007-08-17 |
| 235 | **Opto-mechanical** | 2007-04-02 → 2007-08-22 (+142d) | 2007-12-14 → 2007-12-18 (+4d) | 185d? → 85d? | 33.83d → 3.14d | none → 216 | baseline start none → 2007-04-02; baseline finish none → 2007-12-14 |
| 236 | Field Rotation | 2007-04-16 → 2007-08-22 (+128d) | 2007-08-08 → 2007-11-02 (+86d) | 82.5d? → 53.14d? | 91.33d → 14.99d |  | constraint finish no earlier than 2007-06-29 → finish no earlier than 2007-11-02; resources Bauman [4.5%]; Lockwood [2.3%] → Bauman [7.1%]; Lockwood [3.5%]; baseline start none → 2007-04-16; baseline finish none → 2007-08-08 |
| 237 | Optical Relay | 2007-04-16 → 2007-08-22 (+128d) | 2007-08-15 → 2007-11-02 (+79d) | 88d? → 53.14d? | 85.83d → 14.99d |  | constraint start no earlier than 2007-03-05 → finish no earlier than 2007-11-02; resources Bauman [5.7%]; Lockwood [3.4%]; Dekany [2%] → Bauman [9.4%]; Lockwood [3.4%]; Dekany [2.4%]; baseline start none → 2007-04-16; baseline finish none → 2007-08-15 |
| 238 | Optical Switchyard | 2007-04-16 → 2007-08-22 (+128d) | 2007-06-29 → 2007-11-02 (+126d) | 55d? → 53.14d? | 118.83d → 14.99d |  | constraint finish no earlier than 2007-06-29 → finish no earlier than 2007-11-02; resources Bauman [5.7%]; Lockwood [5.7%] → Bauman [5.9%]; Lockwood [5.9%]; baseline start none → 2007-04-16; baseline finish none → 2007-06-29 |
| 239 | Optical Support Structure | 2007-10-01 → 2007-11-05 (+35d) | 2007-11-16 → 2007-11-30 (+14d) | 35d? → 20d? | 53.83d → 14.99d |  | constraint finish no earlier than 2007-11-16 → finish no earlier than 2007-11-30; resources Lockwood [10.7%]; Bauman [5.4%] → Lockwood [18.8%]; Bauman [9.4%]; baseline start none → 2007-10-01; baseline finish none → 2007-11-16 |
| 240 | **Wavefront Sensors** | 2007-05-07 → 2007-08-22 (+107d) | 2007-12-12 → 2007-11-16 (-26d) | 158d? → 63.14d? | 35.83d → 24.99d |  | baseline start none → 2007-05-07; baseline finish none → 2007-12-12 |
| 241 | High Order LGS Wavefront Sensors | 2007-05-07 → 2007-08-22 (+107d) | 2007-12-12 → 2007-11-16 (-26d) | 158d? → 63.14d? | 35.83d → 24.99d |  | constraint start no earlier than 2007-05-07 → finish no earlier than 2007-11-16; resources Velur [4.7%]; Meguro [1.6%] → Velur [11.9%]; Meguro [4%]; baseline start none → 2007-05-07; baseline finish none → 2007-12-12 |
| 242 | High Order NGS Wavefront Sensor | 2007-05-07 → 2007-08-22 (+107d) | 2007-12-12 → 2007-11-16 (-26d) | 158d? → 63.14d? | 35.83d → 24.99d |  | constraint start no earlier than 2007-05-07 → finish no earlier than 2007-11-16; resources Velur [2.4%]; Meguro [0.8%] → Velur [5.9%]; Meguro [2%]; baseline start none → 2007-05-07; baseline finish none → 2007-12-12 |
| 243 | Low Order NGS Wavefront Sensors | 2007-05-07 → 2007-08-22 (+107d) | 2007-12-12 → 2007-11-16 (-26d) | 158d? → 63.14d? | 35.83d → 24.99d |  | constraint start no earlier than 2007-05-07 → finish no earlier than 2007-11-16; resources Kellner [3.2%]; Meguro [1.6%]; Velur [1.6%] → Kellner [3.2%]; Meguro [4%]; Velur [7.9%]; Moore [40%]; baseline start none → 2007-05-07; baseline finish none → 2007-12-12 |
| 244 | Calibration Wavefront Sensor | 2007-05-28 → 2007-08-22 (+86d) | 2007-12-12 → 2007-11-16 (-26d) | 143d? → 63.14d? | 35.83d → 24.99d |  | constraint start no earlier than 2007-04-16 → finish no earlier than 2007-11-16; resources Kellner [3.5%] → Neyman [7.9%]; baseline start none → 2007-05-28; baseline finish none → 2007-12-12 |
| 245 | **Wavefront Correctors** | 2007-04-02 → 2007-08-22 (+142d) |  | 175d? → 73.14d? | 43.83d → 14.99d |  | baseline start none → 2007-04-02; baseline finish none → 2007-11-30 |
| 246 | Tip/Tilt Corrector |  |  |  | 43.83d → 14.99d |  | baseline start none → 2007-10-01; baseline finish none → 2007-11-30 |
| 247 | Deformable Mirror | 2007-04-02 → 2007-08-22 (+142d) | 2007-06-29 → 2007-11-20 (+144d) |  | 153.83d → 23.14d |  | resources Flicker [7.7%]; Bauman [11.8%]; Dekany [15%] → Neyman [7.7%]; Bauman [11.8%]; baseline start none → 2007-04-02; baseline finish none → 2007-06-29 |
| 248 | **Acquisition Cameras** |  |  |  | 68.83d → 39.99d |  | baseline start none → 2007-10-01; baseline finish none → 2007-10-26 |
| 249 | NGS Acquisition Camera |  |  |  | 68.83d → 39.99d |  | resources Bouchez [12.5%] → Neyman [12.5%]; baseline start none → 2007-10-01; baseline finish none → 2007-10-26 |
| 250 | LGS Acquisition Camera |  |  |  | 68.83d → 39.99d |  | resources Bouchez [12.5%] → Neyman [12.5%]; baseline start none → 2007-10-01; baseline finish none → 2007-10-26 |
| 251 | Atmospheric Dispersion Correction | 2007-08-20 → 2007-08-22 (+2d) | 2007-12-14 → 2007-12-18 (+4d) |  | 33.83d → 3.14d |  | constraint start no earlier than 2007-08-20 → finish no earlier than 2007-12-14; resources Kellner [2.9%] → Bauman [2.9%]; Dekany [35%]; baseline start none → 2007-08-20; baseline finish none → 2007-12-14 |
| 252 | Alignment, Calibration, Diagnostics, Metrology and Monitoring | 2007-04-02 → 2007-08-22 (+142d) | 2007-06-29 → 2007-09-24 (+87d) | 65d? → 24d? | 153.83d → 64.14d |  | constraint start no earlier than 2007-04-02 → finish no earlier than 2007-06-29; resources Neyman [5.8%]; Flicker [5.8%] → Neyman [10.4%]; Flicker [10.4%]; Le Mignant [10.4%]; baseline start none → 2007-04-02; baseline finish none → 2007-06-29 |
| 255 | **Non-real-time Control** |  | 2007-11-23 → 2007-11-22 (-1d) |  | 48.83d → 20.99d |  | baseline start none → 2007-06-25; baseline finish none → 2007-11-23 |
| 256 | Non-RTC Software |  |  |  | 108.83d → 80.99d |  | baseline start none → 2007-06-25; baseline finish none → 2007-08-31 |
| 257 | Non-RTC Electronics |  | 2007-11-23 → 2007-11-22 (-1d) |  | 48.83d → 20.99d |  | constraint start no earlier than 2007-07-23 → finish no earlier than 2007-11-22; resources Chin [13.9%]; Reinig [13.9%] → Chin [8.3%]; Reinig [8.3%]; Johansson [33%]; baseline start none → 2007-07-23; baseline finish none → 2007-11-23 |
| 258 | **Real-time Control** | 2007-03-05 → 2007-06-18 (+105d) | 2007-08-07 → 2007-11-19 (+104d) |  | 126.83d → 23.99d |  | baseline start none → 2007-03-05; baseline finish none → 2007-08-07 |
| 259 | RTC Architecture Analysis and Design Study | 2007-03-05 → 2007-06-18 (+105d) | 2007-05-04 → 2007-08-17 (+105d) |  | 126.83d → 23.99d |  | constraint finish no earlier than 2007-05-04 → start no earlier than 2007-06-18; baseline start none → 2007-03-05; baseline finish none → 2007-05-04 |
| 260 | RTC Software Module Definition | 2007-05-07 → 2007-08-20 (+105d) | 2007-08-07 → 2007-11-19 (+104d) |  | 126.83d → 23.99d |  | baseline start none → 2007-05-07; baseline finish none → 2007-08-07 |
| 261 | RTC Hardware Module Definition | 2007-05-07 → 2007-08-20 (+105d) | 2007-08-07 → 2007-11-19 (+104d) |  | 126.83d → 23.99d |  | baseline start none → 2007-05-07; baseline finish none → 2007-08-07 |
| 262 | **Laser Facility** | 2007-03-06 → 2007-06-04 (+90d) |  | 204d? → 141d? | 33.83d → 4.99d |  | baseline start none → 2007-03-06; baseline finish none → 2007-12-14 |
| 263 | Laser System Architecture | 2007-03-06 → 2007-06-04 (+90d) | 2007-05-14 → 2007-08-10 (+88d) |  | 144.83d → 52.99d | 151, 154, 198 → 154, 198, 152 | baseline start none → 2007-03-06; baseline finish none → 2007-05-14 |
| 264 | Laser Enclosure | 2007-05-15 → 2007-08-13 (+90d) | 2007-07-12 → 2007-10-09 (+89d) |  | 144.83d → 52.99d |  | baseline start none → 2007-05-15; baseline finish none → 2007-07-12 |
| 265 | Laser | 2007-05-15 → 2007-08-13 (+90d) | 2007-07-02 → 2007-09-27 (+87d) |  | 152.83d → 60.99d |  | constraint start no earlier than 2007-03-05 → finish no earlier than 2007-09-27; resources Velur [35.7%] → Velur [7.1%]; baseline start none → 2007-05-15; baseline finish none → 2007-07-02 |
| 266 | **Laser Launch Facility** | 2007-04-09 → 2007-08-06 (+119d) | 2007-06-01 → 2007-09-07 (+98d) | 40d? → 25d? | 173.83d → 75.99d |  | baseline start none → 2007-04-09; baseline finish none → 2007-06-01 |
| 267 | Laser Beam Transport | 2007-04-09 → 2007-08-06 (+119d) | 2007-06-01 → 2007-09-07 (+98d) | 40d? → 25d? | 173.83d → 75.99d |  | constraint start no earlier than 2007-04-09 → finish no earlier than 2007-09-07; resources Neyman [10.9%]; Kellner [6.2%]; Chin [1.6%] → Neyman [15%]; Velur [8%]; Chin [2%]; baseline start none → 2007-04-09; baseline finish none → 2007-06-01 |
| 268 | Laser Pointing & Diagnostics | 2007-04-09 → 2007-08-06 (+119d) | 2007-06-01 → 2007-09-07 (+98d) | 40d? → 25d? | 173.83d → 75.99d |  | constraint start no earlier than 2007-04-09 → start no earlier than 2007-08-06; resources Velur [21.9%]; Kellner [21.9%]; Chin [6.2%]; Moore [22%] → Velur [20%]; Neyman [21.9%]; Chin [6.2%]; Bauman [22%]; baseline start none → 2007-04-09; baseline finish none → 2007-06-01 |
| 269 | Laser Launch Telescope | 2007-04-09 → 2007-08-06 (+119d) | 2007-06-01 → 2007-09-07 (+98d) | 40d? → 25d? | 173.83d → 75.99d |  | constraint finish no earlier than 2007-06-01 → start no earlier than 2007-08-06; resources Velur [15.6%]; Kellner [15.6%]; Chin [11.1%] → Velur [15%]; Neyman [15%]; Chin [11.1%]; baseline start none → 2007-04-09; baseline finish none → 2007-06-01 |
| 270 | **Laser Safety Systems** |  |  |  | 63.83d → 34.99d |  | baseline start none → 2007-10-08; baseline finish none → 2007-11-02 |
| 271 | Personnel and Equipment Safety Systems |  |  |  | 63.83d → 34.99d |  | baseline start none → 2007-10-08; baseline finish none → 2007-11-02 |
| 272 | Aircraft, Satellite & Laser Traffic Control Safety Systems |  |  |  | 63.83d → 34.99d |  | baseline start none → 2007-10-08; baseline finish none → 2007-11-02 |
| 273 | **Laser System Control** |  |  |  | 33.83d → 4.99d |  | baseline start none → 2007-10-01; baseline finish none → 2007-12-14 |
| 274 | Laser System Software |  |  |  | 33.83d → 4.99d |  | baseline start none → 2007-10-01; baseline finish none → 2007-12-14 |
| 275 | Laser System Electronics |  |  |  | 33.83d → 4.99d |  | baseline start none → 2007-10-01; baseline finish none → 2007-12-14 |
| 276 | **Science Operations** | 2007-01-02 → 2007-05-22 (+140d) | 2007-12-14 → 2008-01-17 (+34d) | 249d? → 174d? | 33.83d → 13.14d |  | baseline start none → 2007-01-02; baseline finish none → 2007-12-14 |
| 277 | **Astronomical Observations Operations** | 2007-03-01 → 2007-05-28 (+88d) | 2007-12-14 → 2008-01-17 (+34d) | 207d? → 170d? | 33.83d → 13.14d |  | baseline start none → 2007-03-01; baseline finish none → 2007-12-14 |
| 278 | **Pre-Observing Interfaces** | 2007-05-01 → 2007-07-26 (+86d) | 2007-05-30 → 2007-08-24 (+86d) |  | 175.83d → 118.14d |  | baseline start none → 2007-05-01; baseline finish none → 2007-05-30 |
| 279 | AO Guide Star Interface | 2007-05-01 → 2007-07-26 (+86d) | 2007-05-30 → 2007-08-24 (+86d) |  | 175.83d → 118.14d |  | constraint finish no earlier than 2007-05-30 → start no earlier than 2007-07-26; resources Postdoc [11.4%] → McGraw [11.4%]; baseline start none → 2007-05-01; baseline finish none → 2007-05-30 |
| 280 | Science Observations Simulation Tools | 2007-05-01 → 2007-07-26 (+86d) | 2007-05-30 → 2007-08-24 (+86d) |  | 175.83d → 118.14d |  | constraint start no earlier than 2007-05-01 → start no earlier than 2007-07-26; resources Postdoc [22.7%] → McGraw [22.7%]; baseline start none → 2007-05-01; baseline finish none → 2007-05-30 |
| 281 | **Observing Interfaces** | 2007-03-01 → 2007-05-28 (+88d) |  | 207d? → 146d? | 33.83d → 37.14d |  | baseline start none → 2007-03-01; baseline finish none → 2007-12-14 |
| 282 | Acquisition | 2007-03-01 → 2007-05-28 (+88d) | 2007-04-30 → 2007-07-25 (+86d) |  | 197.83d → 140.14d |  | constraint finish no earlier than 2007-04-30 → finish no earlier than 2007-07-25; resources Postdoc [5.8%] → McGraw [5.8%]; baseline start none → 2007-03-01; baseline finish none → 2007-04-30 |
| 283 | Observing Sequences | 2007-03-01 → 2007-05-28 (+88d) | 2007-04-30 → 2007-07-25 (+86d) |  | 197.83d → 140.14d |  | constraint start no earlier than 2007-03-01 → start no earlier than 2007-05-28; resources Postdoc [5.8%] → McGraw [5.8%]; baseline start none → 2007-03-01; baseline finish none → 2007-04-30 |
| 284 | Instrument, AO & Telescope Observer Interfaces | 2007-03-01 → 2007-05-28 (+88d) | 2007-04-30 → 2007-07-25 (+86d) |  | 197.83d → 140.14d |  | constraint start no earlier than 2007-03-01 → start no earlier than 2007-05-28; baseline start none → 2007-03-01; baseline finish none → 2007-04-30 |
| 285 | Science Data Quality Monitoring |  |  |  | 33.83d → 37.14d |  | resources Postdoc [5.8%] → McGraw [5.8%]; baseline start none → 2007-10-17; baseline finish none → 2007-12-14 |
| 286 | **Post-Observing Interfaces** | 2007-10-01 → 2007-09-03 (-28d) | 2007-11-27 → 2008-01-17 (+51d) | 42d? → 100d? | 46.83d → 13.14d |  | baseline start none → 2007-10-01; baseline finish none → 2007-11-27 |
| 287 | Generic Data Products |  |  |  | 46.83d → 50.14d |  | resources Postdoc [6%] → McGraw [6%]; baseline start none → 2007-10-01; baseline finish none → 2007-11-27 |
| 288 | Science Data Quality Assessment |  |  |  | 46.83d → 50.14d |  | resources Postdoc [6%] → McGraw [6%]; baseline start none → 2007-10-01; baseline finish none → 2007-11-27 |
| 289 | Science Data Archiving |  |  |  | 46.83d → 50.14d |  | resources Postdoc [11.9%] → McGraw [11.9%]; baseline start none → 2007-10-01; baseline finish none → 2007-11-27 |
| 291 | **AO-Instrument Operations** | 2007-01-02 → 2007-05-22 (+140d) |  | 214d? → 115d? | 68.83d → 72.14d |  | baseline start none → 2007-01-02; baseline finish none → 2007-10-26 |
| 292 | **AO-Instrument Operations Architecture** | 2007-01-02 → 2007-05-22 (+140d) |  | 214d? → 115d? | 68.83d → 72.14d |  | baseline start none → 2007-01-02; baseline finish none → 2007-10-26 |
| 293 | AO-Instrument Observing Modes | 2007-01-02 → 2007-05-22 (+140d) | 2007-02-02 → 2007-06-22 (+140d) |  | 258.83d → 163.14d |  | constraint start no earlier than 2007-01-02 → start no earlier than 2007-05-22; resources Le Mignant [20.8%]; Postdoc [20.8%] → Le Mignant [20.8%]; McGraw [20.8%]; baseline start none → 2007-01-02; baseline finish none → 2007-02-02 |
| 294 | AO-Instrument Operations Support | 2007-02-05 → 2007-06-25 (+140d) | 2007-05-30 → 2007-07-13 (+44d) | 83d? → 15d? | 175.83d → 148.14d |  | constraint finish no earlier than 2007-05-30 → finish no earlier than 2007-07-13; resources Le Mignant [3%] → Le Mignant [16.7%]; baseline start none → 2007-02-05; baseline finish none → 2007-05-30 |
| 295 | AO-Instrument Configuration & Setup | 2007-07-04 → 2007-07-05 (+1d) |  |  | 68.83d → 72.14d |  | baseline start none → 2007-07-04; baseline finish none → 2007-10-26 |
| 296 | AO-Instrument Calibrations |  | 2007-09-26 → 2007-09-25 (-1d) |  | 90.83d → 95.14d |  | baseline start none → 2007-06-04; baseline finish none → 2007-09-26 |
| 297 | AO-Instrument Nighttime Operation Modes |  | 2007-09-26 → 2007-09-25 (-1d) |  | 90.83d → 95.14d |  | baseline start none → 2007-06-04; baseline finish none → 2007-09-26 |

| ID | Task | Start | Finish | Duration | Complete | Total float | Predecessors | Other |
| --- | --- | --- | --- | --- | --- | --- | --- | --- |
| 298 | AO-Instrument Science Acquisition & Control |  | 2007-10-24 → 2007-10-23 (-1d) |  |  | 70.83d → 75.14d |  | resources Postdoc [3%] → McGraw [3%]; baseline start none → 2007-07-02; baseline finish none → 2007-10-24 |
| 299 | AO-Instrument Health Monitoring & Automated Recovery |  | 2007-10-03 → 2007-10-02 (-1d) |  |  | 85.83d → 90.14d |  | baseline start none → 2007-06-11; baseline finish none → 2007-10-03 |
| 300 | AO-Instrument Laser Traffic Control |  |  |  |  | 68.83d → 72.14d |  | baseline start none → 2007-10-01; baseline finish none → 2007-10-26 |
| 301 | AO-Instrument User Interfaces |  |  |  |  | 68.83d → 72.14d |  | baseline start none → 2007-10-01; baseline finish none → 2007-10-26 |
| 302 | AO-Instrument Maintenance Plan |  |  |  |  | 68.83d → 72.14d |  | resources Chin [12.5%] → Johansson [12.5%]; baseline start none → 2007-10-01; baseline finish none → 2007-10-26 |
| 303 | **AO-Instrument Operations Optimization** | 2007-03-05 → 2007-06-18 (+105d) | 2007-05-04 → 2007-07-27 (+84d) | 45d? → 30d? |  | 193.83d → 138.14d |  | baseline start none → 2007-03-05; baseline finish none → 2007-05-04 |
| 304 | AO-Instrument Performance Prediction | 2007-03-05 → 2007-06-18 (+105d) | 2007-04-13 → 2007-07-27 (+105d) |  |  | 208.83d → 138.14d |  | constraint start no earlier than 2007-03-05 → start no earlier than 2007-06-18; baseline start none → 2007-03-05; baseline finish none → 2007-04-13 |
| 305 | AO-Instrument Real-Time Optimization | 2007-03-05 → 2007-06-18 (+105d) | 2007-04-13 → 2007-07-27 (+105d) |  |  | 208.83d → 138.14d |  | constraint start no earlier than 2007-03-05 → start no earlier than 2007-06-18; baseline start none → 2007-03-05; baseline finish none → 2007-04-13 |
| 306 | AO-Instrument Environment Monitoring | 2007-04-16 → 2007-06-18 (+63d) | 2007-05-04 → 2007-07-06 (+63d) |  |  | 193.83d → 153.14d |  | constraint finish no earlier than 2007-05-04 → start no earlier than 2007-06-18; resources Chin [16.7%] → Johansson [16.7%]; baseline start none → 2007-04-16; baseline finish none → 2007-05-04 |
| 307 | **Science Instruments** |  | 2007-11-16 → 2008-03-21 (+126d) | 295d? → 386d? | 4% → 2% | 53.83d → 17.33d |  | baseline start none → 2006-10-02; baseline finish none → 2007-11-16 |
| 358 | Interferometer |  | 2007-03-30 → 2007-10-31 (+215d) | 130d? → 68d |  | 218.83d → 119.47d | none → 216 | constraint start no earlier than 2006-10-02 → finish no earlier than 2007-10-30; resources Adkins [1.5%]; Neyman [3.8%]; Other [3.3%]; Wizinowich [1%] → Neyman [10.2%]; Other [7.3%]; Wizinowich [2.5%]; baseline start none → 2006-10-02; baseline finish none → 2007-03-30 |
| 359 | OHANA | 2007-02-01 → 2007-08-22 (+202d) | 2007-04-11 → 2007-10-30 (+202d) |  |  | 210.83d → 120.47d | none → 216 | constraint start no earlier than 2007-02-01 → finish no earlier than 2007-04-11; resources Adkins [2%]; Neyman [2%]; Woillez [6%] → Neyman [2.5%]; Woillez [7.5%]; baseline start none → 2007-02-01; baseline finish none → 2007-04-11 |
| 360 | Thermal Near-IR Imager |  | 2007-11-16 → 2007-07-24 (-115d) | 95d? → 11.88d? |  | 53.83d → 191.45d |  | baseline start none → 2007-07-09; baseline finish none → 2007-11-16 |
| 361 | **System Design Manual (SDM)** | 2008-01-01 → 2007-08-22 (-132d) | 2008-01-18 → 2008-02-14 (+27d) | 12.5d? → 126.33d? |  | 22.33d → 3.14d | 219, 231, 307, 161, 276, 229, 262, 232 → none | was named System Design Manual; constraint finish no earlier than 2008-01-18 → none; resources Wizinowich [42%]; Dekany [20%]; Gavel [20%] → none; baseline start none → 2008-01-01; baseline finish none → 2008-01-18 |
| 364 | **Systems Engineering Management Plan (SEMP)** |  | 2008-02-20 → 2008-02-19 (-1d) |  | 1% → 4% |  |  | baseline start none → 2007-03-05; baseline finish none → 2008-02-20 |
| 365 | **Project Plan** | 2007-09-26 → 2007-09-25 (-1d) | 2007-12-20 → 2007-12-19 (-1d) |  |  |  |  | baseline start none → 2007-09-26; baseline finish none → 2007-12-20 |
| 366 | WBS and Task Definition | 2007-09-26 → 2007-09-25 (-1d) | 2007-10-25 → 2007-10-24 (-1d) |  |  |  |  | baseline start none → 2007-09-26; baseline finish none → 2007-10-25 |
| 367 | Cost Estimation | 2007-10-25 → 2007-10-24 (-1d) | 2007-11-30 → 2007-11-29 (-1d) |  |  |  |  | baseline start none → 2007-10-25; baseline finish none → 2007-11-30 |
| 368 | Major Project Milestones | 2007-10-25 → 2007-10-24 (-1d) | 2007-11-05 → 2007-11-02 (-3d) |  |  |  |  | baseline start none → 2007-10-25; baseline finish none → 2007-11-05 |
| 369 | Develop Full Schedule (MS Project Plan) | 2007-11-30 → 2007-11-29 (-1d) | 2007-12-20 → 2007-12-19 (-1d) |  |  |  |  | baseline start none → 2007-11-30; baseline finish none → 2007-12-20 |
| 370 | Risk Assessment & Management Plan | 2007-09-26 → 2007-09-25 (-1d) | 2007-11-13 → 2007-11-12 (-1d) |  |  |  |  | baseline start none → 2007-09-26; baseline finish none → 2007-11-13 |
| 371 | **Preliminary Design Phase Plan** |  | 2008-01-24 → 2008-01-23 (-1d) |  | 9% → 15% |  |  | baseline start none → 2007-03-05; baseline finish none → 2008-01-24 |
| 372 | Preliminary Design Phase Plan Version 1 (to Support Observatory FY08 Planning) |  | 2007-03-30 → 2007-05-18 (+49d) | 20d? → 55d? |  | 219.33d → 184.33d |  | constraint start no earlier than 2007-03-05 → finish no earlier than 2007-05-18; baseline start none → 2007-03-05; baseline finish none → 2007-03-30 |
| 373 | Preliminary Design Phase Plan Version 2 | 2007-10-25 → 2007-10-24 (-1d) | 2007-11-21 → 2007-11-20 (-1d) |  |  |  |  | baseline start none → 2007-10-25; baseline finish none → 2007-11-21 |
| 374 | Preliminary Design Phase Plan Final Version | 2008-01-03 → 2008-01-02 (-1d) | 2008-01-24 → 2008-01-23 (-1d) |  |  |  |  | baseline start none → 2008-01-03; baseline finish none → 2008-01-24 |
| 375 | **Integration and Test Plans** | 2007-10-25 → 2007-10-24 (-1d) | 2008-02-01 → 2008-01-31 (-1d) |  |  |  |  | baseline start none → 2007-10-25; baseline finish none → 2008-02-01 |
| 376 | **Subsystem Testing Plans** | 2007-10-25 → 2007-10-24 (-1d) | 2008-02-01 → 2008-01-31 (-1d) |  |  |  |  | baseline start none → 2007-10-25; baseline finish none → 2008-02-01 |
| 377 | AO System Test Plan | 2007-10-25 → 2007-10-24 (-1d) | 2007-11-20 → 2007-11-19 (-1d) |  |  |  |  | baseline start none → 2007-10-25; baseline finish none → 2007-11-20 |
| 378 | Laser System Test Plan | 2007-11-20 → 2007-11-19 (-1d) | 2007-12-14 → 2007-12-13 (-1d) |  |  |  |  | baseline start none → 2007-11-20; baseline finish none → 2007-12-14 |
| 379 | Science Operations Test Plan | 2007-12-14 → 2007-12-13 (-1d) | 2008-01-08 → 2008-01-07 (-1d) |  |  |  |  | baseline start none → 2007-12-14; baseline finish none → 2008-01-08 |
| 380 | Science Instruments Test Plan | 2008-01-08 → 2008-01-07 (-1d) | 2008-02-01 → 2008-01-31 (-1d) |  |  |  |  | baseline start none → 2008-01-08; baseline finish none → 2008-02-01 |
| 381 | System Integration & Test Plans | 2007-10-25 → 2007-10-24 (-1d) | 2007-12-06 → 2007-12-05 (-1d) |  |  |  |  | baseline start none → 2007-10-25; baseline finish none → 2007-12-06 |
| 382 | Configuration Management Plan | 2007-10-25 → 2007-10-24 (-1d) | 2008-01-22 → 2008-01-21 (-1d) |  |  |  |  | baseline start none → 2007-10-25; baseline finish none → 2008-01-22 |
| 383 | Project Management Plan | 2007-12-20 → 2007-12-19 (-1d) | 2008-01-17 → 2008-01-16 (-1d) |  |  |  |  | baseline start none → 2007-12-20; baseline finish none → 2008-01-17 |
| 384 | SEMP Document | 2008-02-01 → 2008-01-31 (-1d) | 2008-02-20 → 2008-02-19 (-1d) |  |  |  |  | baseline start none → 2008-02-01; baseline finish none → 2008-02-20 |

## Version 13 (saved 2007-05-04, file NGAO_SD_schedule_v25.mpp)

Last finish stays 2008-04-16.

Added:

| ID | Task | Duration | Start | Finish | Constraint | Resources |
| --- | --- | --- | --- | --- | --- | --- |
| 141 | **Evaluate & Adopt New Model Assumptions** | 63.43d? | 2007-06-11 | 2007-09-06 |  |  |
| 142 | New Model Assumptions Rev 1 | 5d? | 2007-06-11 | 2007-06-15 | finish no earlier than 2007-06-15 | Dekany [35%]; Flicker [30%]; Neyman |
| 143 | New Model Assumptions Rev 2 | 1.43d? | 2007-09-05 | 2007-09-06 | start no earlier than 2007-09-05 | Dekany [35%]; Flicker; Neyman |
| 207 | Trade Study Conclusions Summary | 20d? | 2007-05-14 | 2007-06-08 | start no earlier than 2007-05-14 | Neyman [18.8%]; Wizinowich; Gavel; Dekany |
| 252 | Tip/tilt Vibration Mitigation | 28.14d? | 2007-08-22 | 2007-09-28 | finish no earlier than 2007-09-28 | Neyman [8.9%]; Johansson; Gavel |
| 260 | PSF Monitoring Camera | 20d? | 2007-10-01 | 2007-10-26 | start no earlier than 2007-10-01 | Britton [6.2%]; Neyman |

Changed:

| ID | Task | Start | Finish | Duration | Complete | Total float | Predecessors | Other |
| --- | --- | --- | --- | --- | --- | --- | --- | --- |
| 133 | **Performance Budgets** |  | 2007-12-13 → 2007-11-27 (-16d) | 349.75d? → 337.75d? |  | 88.58d → 100.58d |  |  |
| 134 | **Model Assumptions** |  | 2007-06-29 → 2007-09-06 (+69d) | 230d? → 278.43d? | 70% → 68% | 208.33d → 159.9d |  |  |
| 149 | Anchor to LAO Lab Experiments |  |  |  |  |  |  | resources Gavel [1.7%]; Flicker [16.7%]; Kupke [33.3%]; Ammons [33.3%] → Gavel [1.7%]; Dekany [16.7%]; Kupke [33.3%]; Ammons [33.3%] |
| 155 | Document WFE Budget Rev 1 |  |  |  |  |  |  | resources Dekany [10%] → Dekany [10%]; Britton [40%] |
| 156 | Document WFE Budget Rev 2 |  |  |  |  |  | 136, 140, 183, 145, 146 → 136, 140, 183, 145, 146, 220FF | resources Dekany [6.7%]; Flicker [17%] → Dekany [6.7%]; Britton [17%] |
| 161 | Companion Sensitivity |  |  |  |  | 20.28d → 0d |  | resources Macintosh [30.3%]; Neyman [24.2%]; Flicker [18.2%] → Macintosh [30.3%]; Neyman [24.2%]; Flicker [26.7%]; Dekany [35%] |
| 162 | Observing Efficiency |  | 2007-05-25 → 2007-09-28 (+126d) | 80d? → 171d? |  | 168.14d → 77.14d |  | constraint finish no earlier than 2007-05-25 → finish no earlier than 2007-09-28 |
| 167 | **Science Products** | 2007-10-22 → 2007-10-01 (-21d) | 2007-12-13 → 2007-11-27 (-16d) | 38.75d? → 41.75d? |  | 88.58d → 100.58d |  |  |
| 168 | All-In Science Simulations | 2007-10-22 → 2007-10-01 (-21d) | 2007-11-16 → 2007-10-31 (-16d) | 20d? → 23d? |  | 88.58d → 100.58d | 166 → 156 | constraint finish no earlier than 2007-11-16 → finish no earlier than 2007-10-31; resources Neyman [25%]; Flicker [25%] → Neyman [21.7%]; Flicker [21.7%] |
| 169 | **Additional Science Characterization Results** | 2007-11-19 → 2007-11-01 (-18d) | 2007-12-13 → 2007-11-27 (-16d) |  |  | 88.58d → 100.58d |  |  |
| 170 | Point Source Sensitivities | 2007-11-19 → 2007-11-01 (-18d) | 2007-12-13 → 2007-11-27 (-16d) |  |  | 88.58d → 100.58d |  |  |
| 171 | PSF Uniformity & Stability | 2007-11-19 → 2007-11-01 (-18d) | 2007-12-07 → 2007-11-21 (-16d) |  |  | 92.33d → 104.33d |  | resources Neyman [66.7%] → Neyman [66.7%]; Britton [40%] |
| 173 | **Trade Studies** |  | 2007-06-01 → 2007-06-08 (+7d) | 165d? → 170d? | 64% → 62% | 25.28d → 223.33d |  |  |
| 185 | **Adaptive Optics System Trade Studies** |  | 2007-04-23 → 2007-05-09 (+16d) | 125.62d? → 138d? |  | 54.66d → 42.28d |  |  |
| 190 | Rayleigh Rejection TS (m3) |  | 2006-12-08 → 2007-05-09 (+152d) | 30d? → 54d? |  | 150.28d → 42.28d |  | constraint start no earlier than 2006-10-30 → finish no earlier than 2007-05-09; resources Kellner [16.7%] → Velur [16.7%] |
| 194 | LOWFS Architecture TS |  | 2007-02-09 → 2007-05-09 (+89d) | 50d? → 80.5d? |  |  |  | constraint start no earlier than 2006-12-04 → finish no earlier than 2007-05-09; resources Kellner [71.4%]; Velur [20%] → Flicker [71.4%]; Velur [20%]; Kellner [18.8%] |
| 221 | System Architecture ver 1 | 2007-08-22 → 2007-08-23 (+1d) | 2007-09-12 → 2007-08-31 (-12d) | 14.29d? → 7d |  | 80.99d → 88.14d |  | constraint none → finish no earlier than 2007-08-31; resources Dekany [35%]; Gavel; Neyman; Wizinowich → Dekany [71.4%]; Gavel; Neyman; Wizinowich |
| 234 | Technical Risk Analysis Ver 1 |  |  |  |  |  |  | resources Neyman [8.3%] → Neyman [8.3%]; Wizinowich [34%]; Dekany [35%]; Gavel [35%] |
| 250 | Tip/Tilt Corrector |  |  |  |  |  | none → 252 |  |
| 385 | Science Operations Test Plan |  |  |  |  |  |  | resources Neyman [14.2%] → Le Mignant [14.2%] |
| 386 | Science Instruments Test Plan |  |  |  |  |  |  | resources Neyman [14.2%] → Adkins [14.2%] |
| 387 | System Integration & Test Plans | 2007-10-24 → 2007-10-25 (+1d) |  |  |  | 40.4d → 40.33d |  | constraint none → finish no earlier than 2007-12-05; resources Neyman [41.7%] → Neyman [37.5%]; Wizinowich [34%] |

## Version 14 (saved 2007-05-22, file NGAO_SD_schedule_v26.mpp)

Last finish 2008-04-16 → 2008-04-17 (+1d).

Added:

| ID | Task | Duration | Start | Finish | Predecessors | Constraint | Resources |
| --- | --- | --- | --- | --- | --- | --- | --- |
| 201 | d-IFU & LOWFS AO & Object Selection TS | 45d? | 2007-05-28 | 2007-07-27 |  | start no earlier than 2007-05-28 | Moore [24.4%]; Adkins [10%]; Dekany [35%]; Velur [60%] |
| 220 | Architecture Risk Analysis | 5d? | 2007-08-06 | 2007-08-10 | 219 | start no earlier than 2007-08-06 | Bauman [30%]; Neyman; Velur |

Removed: 219 Architectures Risk Evaluation; 221 System Architecture ver 1; 222 System Architecture ver 2

Changed:

| ID | Task | Start | Finish | Duration | Complete | Total float | Predecessors | Other |
| --- | --- | --- | --- | --- | --- | --- | --- | --- |
| 1 | **SD Phase Management** |  | 2008-04-16 → 2008-04-17 (+1d) | 476.33d? → 477.4d? |  |  |  |  |
| 2 | **Planning and Contracting** |  | 2007-11-13 → 2007-11-29 (+16d) | 365.26d? → 377.83d? |  | 111.07d → 99.57d |  |  |
| 10 | FY08 Replan | 2007-10-24 → 2007-11-12 (+19d) | 2007-11-13 → 2007-11-29 (+16d) |  |  | 111.07d → 99.57d |  |  |
| 42 | **System Design Report & Review** |  | 2008-04-16 → 2008-04-17 (+1d) | 142.33d? → 143.4d? |  |  |  |  |
| 43 | System Design Report | 2008-02-19 → 2008-02-20 (+1d) | 2008-02-29 → 2008-03-03 (+3d) |  |  |  |  |  |
| 44 | **System Design Review** |  | 2008-04-16 → 2008-04-17 (+1d) | 142.33d? → 143.4d? |  |  |  |  |
| 45 | Identify Reviewers |  |  |  |  | 58.33d → 59.4d |  | resources Adkins(IPM) [2.3%]; Wizinowich [0.5%]; Max [0.2%]; Gavel [0.2%]; Dekany [0.2%] → Adkins(IPM) [2.3%]; Wizinowich [0.5%] |
| 46 | Review Package Distributed | 2008-02-29 → 2008-03-03 (+3d) | 2008-03-03 → 2008-03-04 (+1d) |  |  |  |  |  |
| 47 | Reviewer Comments Addressed | 2008-03-17 → 2008-03-18 (+1d) | 2008-03-24 → 2008-03-25 (+1d) |  |  |  |  |  |
| 48 | System Design Review Support | 2008-02-29 → 2008-03-03 (+3d) | 2008-03-28 → 2008-03-31 (+3d) |  |  |  |  |  |
| 49 | System Design Review Meeting | 2008-03-28 → 2008-03-31 (+3d) | 2008-03-28 → 2008-03-31 (+3d) |  |  |  |  |  |
| 50 | Reviewer Report Received | 2008-04-11 → 2008-04-14 (+3d) | 2008-04-11 → 2008-04-14 (+3d) |  |  |  |  |  |
| 51 | Response to Reviewer Report & Distribution | 2008-04-11 → 2008-04-14 (+3d) | 2008-04-16 → 2008-04-17 (+1d) |  |  |  |  |  |
| 120 | **System Requirements Document** |  |  |  | 17% → 16% | 117.33d → 118.4d |  |  |
| 126 | **System Requirements Document** |  |  |  | 21% → 19% | 117.33d → 118.4d |  |  |
| 129 | SRD Rev 3 | 2007-07-17 → 2007-08-13 (+27d) | 2007-07-30 → 2007-08-31 (+32d) | 10d → 15d |  | 187.33d → 164.4d |  | constraint finish no earlier than 2007-07-30 → finish no earlier than 2007-08-31; resources Wizinowich [25%] → Wizinowich [16.7%] |
| 132 | **Systems Engineering** |  | 2008-02-01 → 2008-01-17 (-15d) | 385d? → 374.75d? | 51% → 49% | 53.33d → 64.65d |  |  |
| 133 | **Performance Budgets** |  |  |  | 54% → 52% | 100.58d → 101.65d |  |  |
| 156 | Document WFE Budget Rev 2 |  |  |  |  | 77.14d → 74.53d | 136, 140, 183, 145, 146, 221FF → 136, 140, 183, 145, 146 |  |
| 157 | Encircled Energy vs Sky Coverage |  |  | 140d? → 50d? | 75% → 57% | 0d → 111.53d |  |  |
| 173 | **Trade Studies** |  | 2007-06-08 → 2007-07-27 (+49d) | 170d? → 205d? | 62% → 56% | 223.33d → 189.4d |  |  |
| 185 | **Adaptive Optics System Trade Studies** |  | 2007-05-09 → 2007-07-27 (+79d) | 138d? → 195d? | 54% → 45% | 42.28d → 189.4d |  |  |
| 187 | Optical Relay TS (m6) |  | 2007-04-13 → 2007-06-15 (+63d) | 74d? → 119d? |  | 60.28d → 100.53d |  | constraint finish no earlier than 2007-04-13 → finish no earlier than 2007-06-15 |
| 188 | Field Rotation Strategy TS (m6) |  | 2007-04-13 → 2007-06-15 (+63d) | 74d? → 119d? |  | 60.28d → 100.53d |  | constraint start no earlier than 2007-01-02 → finish no earlier than 2007-06-15 |
| 202 | **Laser Facility Trade Studies** |  | 2007-06-01 → 2007-06-22 (+21d) | 165d? → 180d? |  | 25.28d → 76.53d |  |  |
| 207 | Uplink compensation | 2007-04-30 → 2007-05-21 (+21d) | 2007-06-01 → 2007-06-22 (+21d) |  |  | 25.28d → 76.53d |  | constraint finish no earlier than 2007-06-01 → finish no earlier than 2007-06-22 |
| 209 | **System Architecture** |  | 2008-02-01 → 2008-01-17 (-15d) | 194d? → 183.75d? |  | 5.14d → 64.65d |  |  |
| 210 | **Candidate Subsystems** | 2007-05-10 → 2007-05-21 (+11d) | 2007-07-04 → 2007-06-29 (-5d) | 39.14d? → 30d? |  | 3.14d → 125.53d |  |  |
| 211 | Define Candidate Subsystems | 2007-05-10 → 2007-05-21 (+11d) | 2007-05-31 → 2007-06-01 (+1d) | 16d? → 10d? |  | 3.14d → 135.53d |  | constraint finish no earlier than 2007-05-31 → finish no earlier than 2007-06-01; resources Bauman [31.2%]; Dekany; Gavel; Neyman; Velur; Wizinowich → Bauman [30%]; Dekany [60%]; Gavel; Neyman; Velur; Wizinowich; Other [75%] |
| 212 | Subsystems Performance Evaluation | 2007-06-01 → 2007-06-04 (+3d) | 2007-06-22 → 2007-06-15 (-7d) | 16d? → 10d? |  | 139.14d → 135.53d |  | constraint finish no earlier than 2007-06-22 → finish no earlier than 2007-06-15; resources Dekany [26.6%]; Gavel; Neyman; Bauman → Dekany [30%]; Gavel; Wizinowich |
| 213 | Subsystems Cost Evaluation | 2007-06-01 → 2007-06-04 (+3d) | 2007-06-22 → 2007-06-15 (-7d) | 16d? → 10d? |  | 139.14d → 135.53d |  | constraint finish no earlier than 2007-06-22 → finish no earlier than 2007-06-15; resources Bauman [7.8%]; Dekany; Gavel; Neyman; Velur; Wizinowich → Bauman [30%]; Neyman; Velur |
| 214 | Subsystems Risk Analysis | 2007-06-01 → 2007-06-18 (+17d) |  | 16d? → 5d? |  | 3.14d → 130.53d |  | was named Subsystems Risk Evaluation; resources Dekany [35%]; Gavel; Neyman [15.6%]; Wizinowich → Bauman [35%]; Neyman [30%]; Velur |
| 215 | Organize Candidate Subsystems |  | 2007-07-04 → 2007-06-29 (-5d) | 7.14d? → 5d? |  | 3.14d → 125.53d | 214 → none | constraint none → start no earlier than 2007-06-25; resources Dekany [35%]; Gavel; Neyman; Wizinowich → Dekany [30%]; Gavel; Neyman; Wizinowich; Bauman [40%]; Velur [60%] |
| 216 | **Candidate Architectures** | 2007-07-04 → 2007-07-09 (+5d) | 2007-12-28 → 2007-08-17 (-133d) | 127.86d? → 30d? |  | 3.14d → 174.4d | 174, 185, 202, 165, 215 → none | baseline start 2007-07-23 → none; baseline finish 2007-08-17 → none |
| 217 | Define Candidate Architectures | 2007-07-04 → 2007-07-09 (+5d) |  | 12.5d? → 10d? |  | 3.14d → 174.4d |  | constraint none → start no earlier than 2007-07-09; resources Bauman [40%]; Dekany; Gavel; Neyman; Velur; Wizinowich → Dekany [85%]; Bauman; Gavel; Neyman; Velur; Wizinowich |
| 218 | Architectures Performance Evaluation | 2007-07-20 → 2007-07-23 (+3d) | 2007-07-27 → 2007-08-03 (+7d) | 4.69d? → 10d? |  | 10.95d → 184.4d |  | constraint none → finish no earlier than 2007-08-03; resources Bauman [40%]; Dekany; Gavel; Neyman; Velur; Wizinowich → Dekany [22.5%]; Gavel; Wizinowich; Flicker |
| 219 | Architectures Cost Evaluation | 2007-07-20 → 2007-07-23 (+3d) | 2007-08-08 → 2007-08-03 (-5d) | 12.5d? → 10d? |  | 3.14d → 174.4d |  | constraint none → start no earlier than 2007-07-23; resources Bauman [40%]; Dekany; Gavel; Neyman; Velur; Wizinowich → Bauman [30%]; Neyman; Velur |
| 221 | Adopt Baseline Architecture(s) | 2007-08-08 → 2007-08-13 (+5d) | 2007-08-22 → 2007-08-17 (-5d) | 10.71d? → 5d? |  | 3.14d → 174.4d | 218, 219, Architectures Risk Evaluation → 220 | constraint none → start no earlier than 2007-08-13; resources Dekany [35%]; Gavel; Neyman; Wizinowich → Bauman [20%]; Dekany; Gavel; Neyman; Velur; Wizinowich |
| 222 | **Functional Requirements** |  | 2008-02-01 → 2008-01-17 (-15d) | 194d? → 183.75d? |  | 3.14d → 10.78d |  |  |
| 224 | AO System Functional Requirements Ver 1 | 2007-08-06 → 2007-07-09 (-28d) | 2007-08-29 → 2007-08-17 (-12d) | 17.25d? → 30d? |  | 115.89d → 120.53d |  | constraint start no earlier than 2007-08-06 → finish no earlier than 2007-08-17; resources Neyman [54.3%]; Chin [18.1%]; Stomski [18.1%]; Meguro [18.1%]; Bauman [18.1%]; Johansson [18.1%]; Wizinowich [34%] → Neyman [54.3%]; Dekany [13.3%]; Gavel [13.3%]; Johansson [13.3%]; Wizinowich [34%] |
| 225 | AO System Functional Requirements Ver 2 | 2007-12-28 → 2007-10-29 (-60d) | 2008-01-16 → 2007-11-30 (-47d) | 13.33d? → 25d? |  | 14.8d → 44.53d | 216 → none | constraint start no earlier than 2007-10-29 → finish no earlier than 2007-11-30; resources Neyman [12.5%]; Chin [7.5%]; Stomski [7.5%]; Meguro [7.5%]; Bauman [7.5%]; Johansson [7.5%] → Neyman [8%]; Dekany [8%]; Gavel [8%]; Wizinowich [8%]; Johansson [8%] |
| 226 | Laser System Functional Requirements Ver 1 | 2007-07-04 → 2007-07-09 (+5d) | 2007-08-01 → 2007-08-03 (+2d) |  |  | 135.99d → 130.53d |  | constraint finish no earlier than 2007-03-02 → finish no earlier than 2007-08-03; resources Chin [34.4%]; Velur [34.4%]; Stomski [15.6%]; Meguro [27%]; Wizinowich [34%] → Chin [34.4%]; Velur [34.4%]; Johansson [20%] |
| 227 | Laser System Functional Requirements Ver 2 | 2007-12-28 → 2007-10-29 (-60d) | 2008-01-25 → 2007-11-30 (-56d) | 20d? → 25d? |  | 8.14d → 44.53d | 216 → none | constraint start no earlier than 2007-10-29 → finish no earlier than 2007-11-30; resources Chin [12.5%]; Velur [12.5%]; Stomski [7.5%] → Chin [12.5%]; Velur [12.5%]; Johansson [8%] |
| 228 | Science Operations Functional Requirements Ver 1 | 2007-07-04 → 2007-08-06 (+33d) | 2007-08-07 → 2007-08-31 (+24d) | 24d? → 20d? |  | 131.99d → 110.53d |  | constraint finish no earlier than 2007-02-02 → finish no earlier than 2007-08-31; resources Le Mignant [20.8%]; Wizinowich [31.2%] → Le Mignant [25%]; Wizinowich [31.2%] |
| 229 | Science Operations Functional Requirements Ver 2 | 2007-12-28 → 2007-10-29 (-60d) | 2008-02-01 → 2007-11-30 (-63d) |  |  | 3.14d → 44.53d | 216 → none |  |
| 232 | Technology Drivers Summary | 2007-10-23 → 2007-10-25 (+2d) |  | 2.27d? → 0.23d? |  | 123.33d → 124.4d | 221 → none |  |
| 233 | Technical Risk Analysis Ver 1 |  |  |  |  | 153.33d → 154.4d | 221 → none |  |
| 234 | Technical Risk Analysis Ver 2 | 2007-12-28 → 2007-12-03 (-25d) | 2008-01-25 → 2007-12-28 (-28d) |  |  | 8.14d → 24.53d | System Architecture ver 2 → none | constraint finish no earlier than 2007-12-28 → start no earlier than 2007-12-03; resources Neyman [15%]; Gavel [10%] → Neyman [15.6%] |
| 235 | **AO System** | 2007-06-18 → 2007-05-29 (-20d) | 2007-12-18 → 2007-12-14 (-4d) | 132.86d? → 145d? |  | 3.14d → 34.53d |  |  |
| 236 | AO System Architecture | 2007-08-22 → 2007-09-04 (+13d) | 2007-11-13 → 2007-11-23 (+10d) |  |  | 28.14d → 49.53d | 221 → none | constraint start no earlier than 2007-02-05 → start no earlier than 2007-09-04 |
| 237 | AO Enclosure | 2007-08-22 → 2007-10-01 (+40d) | 2007-09-28 → 2007-11-07 (+40d) |  |  | 60.14d → 61.53d | 221 → none | constraint none → start no earlier than 2007-10-01 |
| 238 | **Opto-mechanical** | 2007-08-22 → 2007-05-29 (-85d) | 2007-12-18 → 2007-12-14 (-4d) | 85d? → 145d? |  | 3.14d → 34.53d | 221 → none |  |
| 239 | Field Rotation | 2007-08-22 → 2007-09-04 (+13d) |  | 53.14d? → 45d? |  | 14.99d → 44.53d |  | constraint finish no earlier than 2007-11-02 → start no earlier than 2007-09-04; resources Bauman [7.1%]; Lockwood [3.5%] → Bauman [8.3%]; Lockwood [4.2%] |
| 240 | Optical Relay | 2007-08-22 → 2007-09-04 (+13d) |  | 53.14d? → 45d? |  | 14.99d → 44.53d |  | constraint finish no earlier than 2007-11-02 → start no earlier than 2007-09-04; resources Bauman [9.4%]; Lockwood [3.4%]; Dekany [2.4%] → Bauman [11.1%]; Lockwood [3.4%]; Dekany [2.8%] |
| 241 | Optical Switchyard | 2007-08-22 → 2007-09-04 (+13d) |  | 53.14d? → 45d? |  | 14.99d → 44.53d |  | constraint finish no earlier than 2007-11-02 → start no earlier than 2007-09-04; resources Bauman [5.9%]; Lockwood [5.9%] → Bauman [6.9%]; Lockwood [6.9%] |
| 248 | **Wavefront Correctors** | 2007-08-22 → 2007-08-13 (-9d) |  | 73.14d? → 81d? |  | 14.99d → 44.53d |  |  |
| 250 | Deformable Mirror | 2007-08-22 → 2007-08-13 (-9d) | 2007-11-20 → 2007-09-21 (-60d) | 65d? → 31d? |  | 23.14d → 94.53d |  | constraint start no earlier than 2007-04-02 → start no earlier than 2007-08-13; resources Neyman [7.7%]; Bauman [11.8%] → Neyman [16.1%]; Bauman [11.8%] |
| 255 | Atmospheric Dispersion Correction | 2007-08-22 → 2007-08-21 (-1d) | 2007-12-18 → 2007-12-14 (-4d) |  |  | 3.14d → 34.53d |  |  |
| 256 | Alignment, Calibration, Diagnostics, Metrology and Monitoring | 2007-08-22 → 2007-05-29 (-85d) | 2007-09-24 → 2007-06-29 (-87d) |  |  | 64.14d → 155.53d |  |  |
| 258 | d-IFU & LOWFS AO & Object Selection |  |  | 56d? → 56.14d? |  | 32.14d → 61.53d |  | constraint finish no earlier than 2007-08-06 → finish no earlier than 2007-11-07; resources Moore [44.6%]; Gavel; Meguro → Moore [17.8%]; Gavel; Meguro |
| 263 | **Real-time Control** | 2007-06-18 → 2007-08-01 (+44d) | 2007-11-19 → 2007-12-03 (+14d) | 112d? → 90d? |  | 23.99d → 43.53d |  |  |
| 264 | RTC Architecture Analysis and Design Study | 2007-06-18 → 2007-08-01 (+44d) | 2007-08-17 → 2007-08-31 (+14d) | 45d? → 23d? |  | 23.99d → 43.53d |  | constraint start no earlier than 2007-06-18 → finish no earlier than 2007-08-31; resources Gavel [5.6%]; Johansson [11.1%]; Flicker [11.1%]; Reinig [22.2%] → Gavel [10.9%]; Johansson [21.7%]; Flicker [21.7%]; Reinig [43.5%] |
| 265 | RTC Software Module Definition | 2007-08-20 → 2007-09-03 (+14d) | 2007-11-19 → 2007-12-03 (+14d) |  |  | 23.99d → 43.53d |  | constraint none → finish no earlier than 2007-11-19 |
| 266 | RTC Hardware Module Definition | 2007-08-20 → 2007-09-03 (+14d) | 2007-11-19 → 2007-12-03 (+14d) |  |  | 23.99d → 43.53d |  | constraint none → finish no earlier than 2007-11-19 |
| 267 | **Laser Facility** | 2007-06-04 → 2007-08-06 (+63d) | 2007-12-14 → 2007-12-19 (+5d) | 141d? → 99d? |  | 4.99d → 31.53d |  |  |
| 268 | Laser System Architecture | 2007-06-04 → 2007-08-27 (+84d) | 2007-08-10 → 2007-10-19 (+70d) | 50d? → 41d? |  | 52.99d → 31.53d |  | constraint none → finish no earlier than 2007-10-19; resources Velur [20%] → Velur [24.4%] |
| 269 | Laser Enclosure | 2007-08-13 → 2007-10-22 (+70d) | 2007-10-09 → 2007-12-19 (+71d) |  |  | 52.99d → 31.53d |  |  |
| 270 | Laser | 2007-08-13 → 2007-10-22 (+70d) | 2007-09-27 → 2007-12-07 (+71d) |  |  | 60.99d → 39.53d |  |  |
| 272 | Laser Beam Transport |  |  |  |  | 75.99d → 105.53d | 203, 204 → none |  |
| 273 | Laser Pointing & Diagnostics |  |  |  |  | 75.99d → 105.53d | 203, 204 → none |  |

| ID | Task | Start | Finish | Duration | Complete | Total float | Predecessors | Other |
| --- | --- | --- | --- | --- | --- | --- | --- | --- |
| 274 | Laser Launch Telescope |  |  |  |  | 75.99d → 105.53d | 205, 203, 204 → 205 |  |
| 281 | **Science Operations** |  | 2008-01-17 → 2007-12-14 (-34d) | 174d? → 150d? |  | 13.14d → 34.53d |  |  |
| 282 | **Astronomical Observations Operations** |  | 2008-01-17 → 2007-12-14 (-34d) | 170d? → 146d? |  | 13.14d → 34.53d |  |  |
| 291 | **Post-Observing Interfaces** | 2007-09-03 → 2007-10-01 (+28d) | 2008-01-17 → 2007-11-30 (-48d) | 100d? → 45d? |  | 13.14d → 44.53d |  |  |
| 295 | PSF Reconstruction | 2007-09-03 → 2007-10-01 (+28d) | 2008-01-17 → 2007-11-30 (-48d) | 100d? → 45d? |  | 13.14d → 44.53d |  | constraint start no earlier than 2007-09-03 → finish no earlier than 2007-11-30; resources Le Mignant [10%]; Britton → Le Mignant [22.2%]; Britton |
| 363 | Interferometer |  | 2007-10-31 → 2007-10-30 (-1d) |  |  | 119.47d → 121.4d | 221 → none |  |
| 364 | OHANA | 2007-08-22 → 2007-02-01 (-202d) | 2007-10-30 → 2007-04-11 (-202d) |  |  | 120.47d → 266.4d | 221 → none |  |
| 366 | **System Design Manual (SDM)** | 2007-08-22 → 2007-08-13 (-9d) | 2008-02-14 → 2008-02-05 (-9d) | 126.33d? → 127.62d? |  | 3.14d → 10.78d |  |  |
| 367 | SDM v1 | 2007-08-22 → 2007-08-13 (-9d) | 2007-08-30 → 2007-09-14 (+15d) | 5.51d? → 25d? |  | 123.96d → 113.4d | 221 → none | constraint none → finish no earlier than 2007-09-14; resources Wizinowich [34%]; Dekany → Wizinowich [15%]; Dekany |
| 368 | SDM v2 | 2008-02-01 → 2008-01-17 (-15d) | 2008-02-14 → 2008-02-05 (-9d) | 9.19d? → 12.87d? |  | 3.14d → 10.78d |  | constraint none → finish no earlier than 2008-01-30 |
| 369 | **Systems Engineering Management Plan (SEMP)** |  | 2008-02-19 → 2008-02-20 (+1d) | 252.33d? → 253.4d? | 4% → 3% |  |  |  |
| 370 | **Project Plan** |  | 2007-12-19 → 2007-12-20 (+1d) | 60.57d? → 61.64d? |  | 0d → 28.19d |  |  |
| 371 | WBS and Task Definition |  | 2007-10-24 → 2007-11-12 (+19d) | 21.43d? → 34d? |  | 0d → 40.15d |  | constraint none → start no earlier than 2007-09-25; resources Wizinowich [35%]; Dekany [35%]; Gavel [35%]; Max [35%] → Wizinowich [22.1%]; Dekany [22.1%]; Gavel [22.1%]; Max [35%] |
| 372 | Cost Estimation | 2007-10-24 → 2007-10-26 (+2d) | 2007-11-29 → 2007-11-30 (+1d) |  |  |  | 371 → none | constraint none → start no earlier than 2007-10-26 |
| 373 | Major Project Milestones | 2007-10-24 → 2007-10-26 (+2d) | 2007-11-02 → 2007-11-05 (+3d) |  |  |  | 371 → none | constraint none → start no earlier than 2007-10-26 |
| 374 | Develop Full Schedule (MS Project Plan) | 2007-11-29 → 2007-11-30 (+1d) | 2007-12-19 → 2007-12-20 (+1d) |  |  |  |  |  |
| 375 | Risk Assessment & Management Plan |  | 2007-11-12 → 2007-11-09 (-3d) |  |  | 57.83d → 59.4d | 371SS → none | constraint none → start no earlier than 2007-09-25 |
| 376 | **Preliminary Design Phase Plan** |  | 2008-01-23 → 2008-01-24 (+1d) | 233.64d? → 234.71d? |  |  |  |  |
| 378 | Preliminary Design Phase Plan Version 2 | 2007-10-24 → 2007-11-12 (+19d) | 2007-11-20 → 2007-12-07 (+17d) |  |  | 51.65d → 40.15d |  |  |
| 379 | Preliminary Design Phase Plan Final Version | 2008-01-02 → 2008-01-03 (+1d) | 2008-01-23 → 2008-01-24 (+1d) |  |  |  |  |  |
| 380 | **Integration and Test Plans** | 2007-10-24 → 2007-10-26 (+2d) | 2008-01-31 → 2008-02-01 (+1d) |  |  |  |  |  |
| 381 | **Subsystem Testing Plans** | 2007-10-24 → 2007-10-26 (+2d) | 2008-01-31 → 2008-02-01 (+1d) |  |  |  |  |  |
| 382 | AO System Test Plan | 2007-10-24 → 2007-10-26 (+2d) | 2007-11-19 → 2007-11-20 (+1d) |  |  |  | 371 → none | constraint none → start no earlier than 2007-10-26 |
| 383 | Laser System Test Plan | 2007-11-19 → 2007-11-20 (+1d) | 2007-12-13 → 2007-12-14 (+1d) |  |  |  |  |  |
| 384 | Science Operations Test Plan | 2007-12-13 → 2007-12-14 (+1d) | 2008-01-07 → 2008-01-08 (+1d) |  |  |  |  |  |
| 385 | Science Instruments Test Plan | 2008-01-07 → 2008-01-08 (+1d) | 2008-01-31 → 2008-02-01 (+1d) |  |  |  |  |  |
| 386 | System Integration & Test Plans | 2007-10-25 → 2007-12-03 (+39d) | 2007-12-05 → 2008-01-31 (+57d) | 30d? → 44d? |  | 40.33d → 0.4d | 371 → none | constraint finish no earlier than 2007-12-05 → finish no earlier than 2008-01-31; resources Neyman [37.5%]; Wizinowich [34%] → Neyman [25.6%]; Wizinowich [2.8%] |
| 387 | Configuration Management Plan | 2007-10-24 → 2007-10-26 (+2d) | 2008-01-21 → 2008-01-18 (-3d) | 62.5d? → 60.5d? |  | 7.9d → 9.9d | 371 → none | constraint start no earlier than 2007-01-15 → start no earlier than 2007-10-26; resources Johnson [10%]; Randolph [10%]; Chin [5%] → Johansson [10.3%]; Randolph [10%]; Chin [5%] |
| 388 | Project Management Plan | 2007-12-19 → 2007-12-20 (+1d) | 2008-01-16 → 2008-01-17 (+1d) |  |  |  |  |  |
| 389 | SEMP Document | 2008-01-31 → 2008-02-01 (+1d) | 2008-02-19 → 2008-02-20 (+1d) |  |  |  |  |  |

## Version 15 (saved 2007-09-15, file NGAO_SD_schedule_v26_tracked.mpp)

Last finish stays 2008-04-17. Complete tasks 35 → 71.

Changed:

| ID | Task | Start | Finish | Complete | Total float |
| --- | --- | --- | --- | --- | --- |
| 1 | **SD Phase Management** |  |  | 29% → 46% |  |
| 2 | **Planning and Contracting** |  |  | 74% → 79% |  |
| 7 | Director Approval |  | 2006-10-09 A | 75% → 100% | 384.4d → none |
| 9 | Mid-year Replan |  | 2007-03-27 A | 50% → 100% | 277.4d → none |
| 11 | **Project Meetings** |  |  | 25% → 39% |  |
| 12 | Executive Committee Telecons |  |  | 45% → 70% |  |
| 14 | **Team Meetings** |  |  | 32% → 78% |  |
| 20 | Team Meeting #6 (UCSC) | 2007-04-25 A | 2007-04-26 A | 0% → 100% | 255.4d → none |
| 21 | Team Videocon #7 | 2007-05-30 A | 2007-05-30 A | 0% → 100% | 231.4d → none |
| 22 | Team Retreat #8 (UCSC) | 2007-07-09 A | 2007-07-11 A | 0% → 100% | 40.15d → none |
| 23 | Team Videocon #9 | 2007-08-22 A | 2007-08-22 A | 0% → 100% | 171.9d → none |
| 24 | Team Meeting #10 (CIT) | 2007-09-11 A |  | 0% → 20% |  |
| 28 | **Tracking and Reporting** |  |  | 40% → 75% |  |
| 29 | Report Preparation/Presentation |  |  | 40% → 75% |  |
| 34 | SSC meeting (Keck) | 2007-06-20 A | 2007-06-20 A | 0% → 100% | 217.4d → none |
| 35 | Keck Science Meeting 07 | 2007-09-15 A |  | 0% → 35% |  |
| 52 | **System Requirements** |  |  | 48% → 49% |  |
| 108 | **Science Case Requirements Document** |  |  | 14% → 26% |  |
| 110 | Science Case Requirements Doc Rev 2 | 2007-04-02 A |  | 0% → 25% |  |
| 113 | **Observatory Requirements** |  |  | 43% → 56% |  |
| 116 | Science Operations Requirements |  | 2006-11-24 A | 50% → 100% | 108.4d → none |
| 117 | Observatory Requirements Rev 2 | 2007-01-22 A |  | 0% → 25% |  |
| 120 | **System Requirements Document** |  |  | 16% → 35% |  |
| 121 | **Traceability Matrix** |  |  | 12% → 18% |  |
| 122 | Traceability Matrix Rev 1 |  |  | 50% → 75% |  |
| 126 | **System Requirements Document** |  |  | 19% → 46% |  |
| 128 | SRD Rev 2 |  |  | 5% → 75% |  |
| 131 | **System Design** |  |  | 26% → 41% |  |
| 132 | **Systems Engineering** |  |  | 49% → 75% |  |
| 133 | **Performance Budgets** |  |  | 52% → 76% |  |
| 134 | **Model Assumptions** |  |  | 68% → 99% |  |
| 135 | **TMT site monitoring data mining** |  | 2007-06-29 A | 55% → 100% | 209.4d → none |
| 137 | Release updated data (every two months) |  | 2007-06-29 A | 50% → 100% | 209.4d → none |
| 141 | **Evaluate & Adopt New Model Assumptions** | 2007-06-11 A |  | 0% → 78% |  |
| 142 | New Model Assumptions Rev 1 | 2007-06-11 A | 2007-06-15 A | 0% → 100% | 219.4d → none |
| 150 | Throughput |  | 2007-05-18 A | 50% → 100% | 170.53d → none |
| 151 | **Background** |  |  | 50% → 99% |  |
| 153 | Develop Background Performance Budget |  | 2007-05-18 A | 50% → 100% | 170.53d → none |
| 154 | **Wavefront Error vs Sky Coverage** |  |  | 34% → 67% |  |
| 155 | Document WFE Budget Rev 1 |  | 2007-05-04 A | 50% → 100% | 111.53d → none |
| 157 | Encircled Energy vs Sky Coverage |  | 2007-05-04 → 2006-12-29 A (-126d) | 57% → 100% | 111.53d → none |
| 159 | Astrometric Accuracy |  | 2007-06-29 A | 50% → 100% | 0d → none |
| 161 | Companion Sensitivity |  | 2007-05-25 A | 75% → 100% | 0d → none |
| 163 | Observing Uptime |  |  | 27% → 25% |  |
| 164 | **Performance Budgets Summary** | 2007-05-28 A |  | 0% → 40% |  |
| 165 | Performance Budgets Summary Ver 1 | 2007-05-28 A | 2007-06-08 A | 0% → 100% | 170.53d → none |
| 173 | **Trade Studies** |  |  | 56% → 80% |  |
| 174 | **System Architecture Trade Studies** |  |  | 74% → 99% |  |
| 177 | Adaptive Secondary Mirror option TS (m5) |  | 2007-04-30 A | 25% → 100% | 0d → none |
| 179 | Keck Interferometer Support TS (m5) |  | 2007-03-02 A | 75% → 100% | 0d → none |
| 182 | Science Instrument Re-use Cost/Benefit TS (m3) |  | 2007-05-18 A | 50% → 100% | 239.4d → none |
| 184 | Observing Model TS |  | 2007-05-04 A | 90% → 100% | 249.4d → none |
| 185 | **Adaptive Optics System Trade Studies** |  |  | 45% → 61% |  |
| 190 | Rayleigh Rejection TS (m3) |  | 2007-05-09 A | 75% → 100% | 246.4d → none |
| 194 | LOWFS Architecture TS |  | 2007-05-09 A | 35% → 100% | 0d → none |
| 201 | d-IFU & LOWFS AO & Object Selection TS | 2007-05-28 A |  | 0% → 50% | 189.4d → 0d |
| 202 | **Laser Facility Trade Studies** |  |  | 37% → 99% | 76.53d → 78.21d |
| 207 | Uplink compensation | 2007-05-21 A | 2007-06-22 A | 0% → 100% | 76.53d → none |
| 208 | Trade Study Conclusions Summary | 2007-05-14 A | 2007-06-08 A | 0% → 100% | 224.4d → none |
| 209 | **System Architecture** | 2007-05-08 A |  | 0% → 46% |  |
| 210 | **Candidate Subsystems** | 2007-05-21 A | 2007-06-29 A | 0% → 100% | 125.53d → none |
| 211 | Define Candidate Subsystems | 2007-05-21 A | 2007-06-01 A | 0% → 100% | 135.53d → none |
| 212 | Subsystems Performance Evaluation | 2007-06-04 A | 2007-06-15 A | 0% → 100% | 135.53d → none |
| 213 | Subsystems Cost Evaluation | 2007-06-04 A | 2007-06-15 A | 0% → 100% | 135.53d → none |
| 214 | Subsystems Risk Analysis | 2007-06-18 A | 2007-06-22 A | 0% → 100% | 130.53d → none |
| 215 | Organize Candidate Subsystems | 2007-06-25 A | 2007-06-29 A | 0% → 100% | 125.53d → none |
| 216 | **Candidate Architectures** | 2007-07-09 A |  | 0% → 94% | 174.4d → 0d |
| 217 | Define Candidate Architectures | 2007-07-09 A | 2007-07-20 A | 0% → 100% | 174.4d → none |
| 218 | Architectures Performance Evaluation | 2007-07-23 A | 2007-08-03 A | 0% → 100% | 184.4d → none |
| 219 | Architectures Cost Evaluation | 2007-07-23 A |  | 0% → 75% | 174.4d → 0d |

| ID | Task | Start | Finish | Complete | Total float |
| --- | --- | --- | --- | --- | --- |
| 220 | Architecture Risk Analysis | 2007-08-06 A | 2007-08-10 A | 0% → 100% | 174.4d → none |
| 221 | Adopt Baseline Architecture(s) | 2007-08-13 A | 2007-08-17 A | 0% → 100% | 174.4d → none |
| 222 | **Functional Requirements** | 2007-05-08 A |  | 0% → 26% |  |
| 223 | Draft Functional Requirements Document | 2007-05-22 A | 2007-05-31 A | 0% → 100% | 176.53d → none |
| 224 | AO System Functional Requirements Ver 1 | 2007-07-09 A |  | 0% → 75% | 120.53d → 0d |
| 226 | Laser System Functional Requirements Ver 1 | 2007-07-09 A |  | 0% → 75% | 130.53d → 0d |
| 233 | Technical Risk Analysis Ver 1 | 2007-08-27 A |  | 0% → 75% | 154.4d → 0d |
| 235 | **AO System** | 2007-05-29 A |  | 0% → 2% |  |
| 236 | AO System Architecture | 2007-09-04 A |  | 0% → 10% |  |
| 237 | AO Enclosure | 2007-10-01 A |  | 0% → 2% |  |
| 238 | **Opto-mechanical** | 2007-05-29 A |  | 0% → 2% |  |
| 239 | Field Rotation | 2007-09-04 A |  | 0% → 2% | 44.53d → 44.93d |
| 240 | Optical Relay | 2007-09-04 A |  | 0% → 2% | 44.53d → 44.93d |
| 241 | Optical Switchyard | 2007-09-04 A |  | 0% → 2% | 44.53d → 44.93d |
| 242 | Optical Support Structure | 2007-11-05 A |  | 0% → 2% |  |
| 243 | **Wavefront Sensors** | 2007-08-22 A |  | 0% → 2% |  |
| 244 | High Order LGS Wavefront Sensors | 2007-08-22 A |  | 0% → 2% |  |
| 245 | High Order NGS Wavefront Sensor | 2007-08-22 A |  | 0% → 2% |  |
| 246 | Low Order NGS Wavefront Sensors | 2007-08-22 A |  | 0% → 2% |  |
| 247 | Calibration Wavefront Sensor | 2007-08-22 A |  | 0% → 2% |  |
| 248 | **Wavefront Correctors** | 2007-08-13 A |  | 0% → 2% |  |
| 249 | Tip/Tilt Corrector | 2007-10-01 A |  | 0% → 2% |  |
| 250 | Deformable Mirror | 2007-08-13 A |  | 0% → 2% |  |
| 251 | Tip/tilt Vibration Mitigation | 2007-08-22 A |  | 0% → 2% | 44.53d → 45.43d |
| 252 | **Acquisition Cameras** | 2007-10-01 A |  | 0% → 2% |  |
| 253 | NGS Acquisition Camera | 2007-10-01 A |  | 0% → 2% |  |
| 254 | LGS Acquisition Camera | 2007-10-01 A |  | 0% → 2% |  |
| 255 | Atmospheric Dispersion Correction | 2007-08-21 A |  | 0% → 2% | 34.53d → 0d |
| 256 | Alignment, Calibration, Diagnostics, Metrology and Monitoring | 2007-05-29 A |  | 0% → 2% |  |
| 257 | Atmospheric Profiler | 2007-08-22 A |  | 0% → 2% |  |
| 259 | PSF Monitoring Camera | 2007-10-01 A |  | 0% → 2% |  |
| 260 | **Non-real-time Control** | 2007-06-25 A |  | 0% → 2% |  |
| 261 | Non-RTC Software | 2007-06-25 A |  | 0% → 2% |  |
| 262 | Non-RTC Electronics | 2007-07-23 A |  | 0% → 2% |  |
| 263 | **Real-time Control** | 2007-08-01 A |  | 0% → 2% |  |
| 264 | RTC Architecture Analysis and Design Study | 2007-08-01 A |  | 0% → 2% | 43.53d → 44.87d |
| 265 | RTC Software Module Definition | 2007-09-03 A |  | 0% → 2% |  |
| 266 | RTC Hardware Module Definition | 2007-09-03 A |  | 0% → 2% |  |
| 267 | **Laser Facility** | 2007-08-06 A |  | 0% → 2% |  |
| 268 | Laser System Architecture | 2007-08-27 A |  | 0% → 2% | 31.53d → 32.39d |
| 269 | Laser Enclosure | 2007-10-22 A |  | 0% → 2% |  |
| 270 | Laser | 2007-10-22 A |  | 0% → 2% |  |
| 271 | **Laser Launch Facility** | 2007-08-06 A |  | 0% → 2% |  |
| 272 | Laser Beam Transport | 2007-08-06 A |  | 0% → 2% |  |
| 273 | Laser Pointing & Diagnostics | 2007-08-06 A |  | 0% → 2% |  |
| 274 | Laser Launch Telescope | 2007-08-06 A |  | 0% → 2% |  |
| 275 | **Laser Safety Systems** | 2007-10-08 A |  | 0% → 2% |  |
| 276 | Personnel and Equipment Safety Systems | 2007-10-08 A |  | 0% → 2% |  |
| 277 | Aircraft, Satellite & Laser Traffic Control Safety Systems | 2007-10-08 A |  | 0% → 2% |  |
| 278 | **Laser System Control** | 2007-10-01 A |  | 0% → 2% |  |
| 279 | Laser System Software | 2007-10-01 A |  | 0% → 2% |  |
| 280 | Laser System Electronics | 2007-10-01 A |  | 0% → 2% |  |
| 281 | **Science Operations** | 2007-05-22 A |  | 0% → 2% |  |
| 282 | **Astronomical Observations Operations** | 2007-05-28 A |  | 0% → 2% |  |
| 283 | **Pre-Observing Interfaces** | 2007-07-26 A |  | 0% → 2% |  |
| 284 | AO Guide Star Interface | 2007-07-26 A |  | 0% → 2% |  |
| 285 | Science Observations Simulation Tools | 2007-07-26 A |  | 0% → 2% |  |
| 286 | **Observing Interfaces** | 2007-05-28 A |  | 0% → 2% |  |
| 287 | Acquisition | 2007-05-28 A |  | 0% → 2% |  |
| 288 | Observing Sequences | 2007-05-28 A |  | 0% → 2% |  |
| 289 | Instrument, AO & Telescope Observer Interfaces | 2007-05-28 A |  | 0% → 2% |  |
| 290 | Science Data Quality Monitoring | 2007-10-17 A |  | 0% → 2% |  |
| 291 | **Post-Observing Interfaces** | 2007-10-01 A |  | 0% → 2% |  |
| 292 | Generic Data Products | 2007-10-01 A |  | 0% → 2% |  |
| 293 | Science Data Quality Assessment | 2007-10-01 A |  | 0% → 2% |  |
| 294 | Science Data Archiving | 2007-10-01 A |  | 0% → 2% |  |
| 295 | PSF Reconstruction | 2007-10-01 A |  | 0% → 2% |  |
| 296 | **AO-Instrument Operations** | 2007-05-22 A |  | 0% → 2% |  |
| 297 | **AO-Instrument Operations Architecture** | 2007-05-22 A |  | 0% → 2% |  |
| 298 | AO-Instrument Observing Modes | 2007-05-22 A |  | 0% → 2% |  |

| ID | Task | Start | Finish | Complete | Total float |
| --- | --- | --- | --- | --- | --- |
| 299 | AO-Instrument Operations Support | 2007-06-25 A |  | 0% → 2% |  |
| 300 | AO-Instrument Configuration & Setup | 2007-07-05 A |  | 0% → 2% |  |
| 301 | AO-Instrument Calibrations | 2007-06-04 A |  | 0% → 2% |  |
| 302 | AO-Instrument Nighttime Operation Modes | 2007-06-04 A |  | 0% → 2% |  |
| 303 | AO-Instrument Science Acquisition & Control | 2007-07-02 A |  | 0% → 2% |  |
| 304 | AO-Instrument Health Monitoring & Automated Recovery | 2007-06-11 A |  | 0% → 2% |  |
| 305 | AO-Instrument Laser Traffic Control | 2007-10-01 A |  | 0% → 2% |  |
| 306 | AO-Instrument User Interfaces | 2007-10-01 A |  | 0% → 2% |  |
| 307 | AO-Instrument Maintenance Plan | 2007-10-01 A |  | 0% → 2% |  |
| 308 | **AO-Instrument Operations Optimization** | 2007-06-18 A |  | 0% → 2% |  |
| 309 | AO-Instrument Performance Prediction | 2007-06-18 A |  | 0% → 2% |  |
| 310 | AO-Instrument Real-Time Optimization | 2007-06-18 A |  | 0% → 2% |  |
| 311 | AO-Instrument Environment Monitoring | 2007-06-18 A |  | 0% → 2% |  |
| 312 | **Science Instruments** |  |  | 2% → 17% |  |
| 313 | **Instrument Requirements & Initial Definitions** | 2007-04-09 A |  | 0% → 22% |  |
| 314 | Top Level Instrument Requirements & Definitions | 2007-04-09 A |  | 0% → 50% | 132.4d → 169.9d |
| 315 | **Instrument Suite Version 1** | 2007-05-07 A |  | 0% → 46% | 176.53d → 235.9d |
| 317 | Summary Descriptions of Instruments | 2007-05-08 A |  | 0% → 50% |  |
| 324 | **Deployable NIR IFU (DNIRI)** | 2007-05-07 A |  | 0% → 10% |  |
| 325 | DNIRI Concept Development | 2007-05-07 A |  | 0% → 50% | 98.53d → 0d |
| 335 | **Single Object Imagers/Low Resolution Spectrographs (SOI/LRS)** | 2007-05-07 A |  | 0% → 33% |  |
| 342 | **SOI/LRS Reports** | 2007-07-05 A |  | 0% → 41% |  |
| 343 | SOI/LRS Near-IR ver 1 | 2007-07-05 A |  | 0% → 50% |  |
| 344 | SOI/LRS Visibile ver 1 | 2007-07-06 A |  | 0% → 50% |  |
| 347 | **Single Object IFUs (SOIFU)** | 2007-04-30 A |  | 0% → 4% |  |
| 348 | Near-IR IFU Requirements Review | 2007-04-30 A |  | 0% → 50% |  |
| 366 | **System Design Manual (SDM)** | 2007-08-13 A |  | 0% → 33% |  |
| 367 | SDM v1 | 2007-08-13 A |  | 0% → 50% | 113.4d → 0d |
| 369 | **Systems Engineering Management Plan (SEMP)** |  |  | 3% → 14% |  |
| 376 | **Preliminary Design Phase Plan** |  |  | 15% → 64% |  |
| 377 | Preliminary Design Phase Plan Version 1 (to Support Observatory FY08 Planning) |  | 2007-05-18 A | 25% → 100% | 185.4d → none |
| 378 | Preliminary Design Phase Plan Version 2 | 2007-11-12 A |  | 0% → 10% |  |

## Version 16 (saved 2007-11-03, file NGAO_SD_schedule_v26_tracked_TS_deleted.mpp)

Last finish stays 2008-04-17. Complete tasks 71 → 84.

Removed: 178 K & L-band Science TS (m5); 180 Instrument Balance TS; 186 AO Enclosure Temperature TS (m6); 187 Optical Relay TS (m6); 188 Field Rotation Strategy TS (m6); 189 Dichroics & Beamsplitters TS (m6); 193 Slow WFS TS (m7); 196 Centroid Anisoplanatism TS (m7); 197 Deformable Mirror Stroke Requirement TS (m6); 198 Stand-alone vs DM on T/T Stage TS (m3); 199 Correcting Fast T/T with DM TS; 200 Focus Compensation TS (m6); 203 Laser Pulse Format TS (m6); 204 Free Space vs Fiber TS (m7)

Changed:

| ID | Task | Start | Finish | Complete | Total float | Predecessors |
| --- | --- | --- | --- | --- | --- | --- |
| 1 | **SD Phase Management** |  |  | 46% → 51% |  |  |
| 11 | **Project Meetings** |  |  | 39% → 42% |  |  |
| 12 | Executive Committee Telecons |  |  | 70% → 75% |  |  |
| 14 | **Team Meetings** |  |  | 78% → 85% |  |  |
| 24 | Team Meeting #10 (CIT) |  | 2007-09-11 A | 20% → 100% | 157.4d → none |  |
| 25 | Team Videocon #11 | 2007-11-05 A |  | 0% → 20% |  |  |
| 28 | **Tracking and Reporting** |  |  | 75% → 85% |  |  |
| 29 | Report Preparation/Presentation |  |  | 75% → 85% |  |  |
| 35 | Keck Science Meeting 07 |  | 2007-09-15 A | 35% → 100% | 154.4d → none |  |
| 36 | SSC meeting (CA) | 2007-11-06 A |  | 0% → 20% |  |  |
| 52 | **System Requirements** |  |  | 49% → 50% |  |  |
| 53 | **Science Requirements** |  |  | 49% → 50% |  |  |
| 54 | **Solar System Science Requirements** |  |  | 57% → 59% |  |  |
| 55 | **Companions & Multiplicity of Small Solar System Bodies** |  |  | 74% → 80% |  |  |
| 58 | Observing Scenarios |  |  | 50% → 80% |  |  |
| 108 | **Science Case Requirements Document** |  |  | 26% → 33% |  |  |
| 110 | Science Case Requirements Doc Rev 2 |  |  | 25% → 40% |  |  |
| 113 | **Observatory Requirements** |  |  | 56% → 58% |  |  |
| 117 | Observatory Requirements Rev 2 |  |  | 25% → 50% |  |  |
| 120 | **System Requirements Document** |  |  | 35% → 37% |  |  |
| 121 | **Traceability Matrix** |  |  | 18% → 24% | 128.4d → 122.9d |  |
| 122 | Traceability Matrix Rev 1 |  | 2006-10-20 A | 75% → 100% | 389.4d → none |  |
| 131 | **System Design** |  |  | 41% → 48% |  |  |
| 132 | **Systems Engineering** |  |  | 75% → 80% |  |  |
| 173 | **Trade Studies** |  |  | 80% → 97% | 189.4d → 0d |  |
| 174 | **System Architecture Trade Studies** |  | 2007-05-18 A | 99% → 100% | 239.4d → none |  |
| 183 | **Adaptive Optics System Trade Studies** |  |  | 61% → 92% | 189.4d → 0d |  |
| 190 | **Laser Facility Trade Studies** |  | 2007-06-22 A | 99% → 100% | 78.21d → none |  |
| 195 | **System Architecture** |  |  | 46% → 58% |  |  |
| 202 | **Candidate Architectures** |  | 2007-08-17 A | 94% → 100% | 0d → none |  |
| 205 | Architectures Cost Evaluation |  | 2007-08-03 A | 75% → 100% | 0d → none |  |
| 208 | **Functional Requirements** |  |  | 26% → 42% |  |  |
| 210 | AO System Functional Requirements Ver 1 |  | 2007-08-17 A | 75% → 100% | 0d → none |  |
| 211 | AO System Functional Requirements Ver 2 | 2007-10-29 A |  | 0% → 25% |  |  |
| 212 | Laser System Functional Requirements Ver 1 |  | 2007-08-03 A | 75% → 100% | 0d → none |  |
| 213 | Laser System Functional Requirements Ver 2 | 2007-10-29 A |  | 0% → 40% |  |  |
| 219 | Technical Risk Analysis Ver 1 |  | 2007-09-14 A | 75% → 100% | 0d → none |  |
| 221 | **AO System** |  |  | 2% → 16% |  |  |
| 222 | AO System Architecture |  |  | 10% → 60% |  |  |
| 224 | **Opto-mechanical** |  |  | 2% → 15% |  |  |
| 225 | Field Rotation |  |  | 2% → 40% | 44.93d → 45.53d | Field Rotation Strategy TS (m6) → none |
| 226 | Optical Relay |  |  | 2% → 40% | 44.93d → 45.53d | Optical Relay TS (m6) → none |
| 227 | Optical Switchyard |  |  |  | 44.93d → 45.53d | Dichroics & Beamsplitters TS (m6) → none |
| 228 | Optical Support Structure |  |  | 2% → 5% |  |  |
| 229 | **Wavefront Sensors** |  |  | 2% → 9% |  |  |
| 230 | High Order LGS Wavefront Sensors |  |  | 2% → 10% |  |  |
| 231 | High Order NGS Wavefront Sensor |  |  | 2% → 15% |  |  |
| 232 | Low Order NGS Wavefront Sensors |  |  | 2% → 5% |  |  |
| 233 | Calibration Wavefront Sensor |  |  | 2% → 5% |  | Slow WFS TS (m7) → none |
| 238 | **Acquisition Cameras** |  |  | 2% → 50% |  |  |
| 239 | NGS Acquisition Camera |  |  | 2% → 50% |  |  |
| 240 | LGS Acquisition Camera |  |  | 2% → 50% |  |  |
| 241 | Atmospheric Dispersion Correction |  |  | 2% → 30% |  |  |
| 242 | Alignment, Calibration, Diagnostics, Metrology and Monitoring |  |  | 2% → 25% |  |  |
| 246 | **Non-real-time Control** |  |  | 2% → 10% |  |  |
| 247 | Non-RTC Software |  |  | 2% → 10% |  |  |
| 248 | Non-RTC Electronics |  |  | 2% → 10% |  |  |
| 249 | **Real-time Control** |  |  | 2% → 16% |  |  |
| 250 | RTC Architecture Analysis and Design Study |  |  | 2% → 20% | 44.87d → 50.23d |  |
| 251 | RTC Software Module Definition |  |  | 2% → 10% |  |  |
| 252 | RTC Hardware Module Definition |  |  | 2% → 20% |  |  |
| 253 | **Laser Facility** |  |  | 2% → 9% |  |  |
| 254 | Laser System Architecture |  |  | 2% → 25% | 32.39d → 35.83d |  |
| 255 | Laser Enclosure |  |  | 2% → 10% |  |  |
| 256 | Laser |  |  | 2% → 10% |  |  |
| 257 | **Laser Launch Facility** |  |  | 2% → 4% |  |  |
| 259 | Laser Pointing & Diagnostics |  |  | 2% → 5% |  |  |
| 260 | Laser Launch Telescope |  |  | 2% → 5% |  |  |
| 261 | **Laser Safety Systems** |  |  | 2% → 6% |  |  |
| 262 | Personnel and Equipment Safety Systems |  |  | 2% → 10% |  |  |

| ID | Task | Start | Finish | Complete | Total float |
| --- | --- | --- | --- | --- | --- |
| 264 | **Laser System Control** |  |  | 2% → 8% |  |
| 265 | Laser System Software |  |  | 2% → 10% |  |
| 266 | Laser System Electronics |  |  | 2% → 5% |  |
| 267 | **Science Operations** |  |  | 2% → 5% |  |
| 268 | **Astronomical Observations Operations** |  |  | 2% → 9% |  |
| 269 | **Pre-Observing Interfaces** |  |  | 2% → 50% |  |
| 270 | AO Guide Star Interface |  |  | 2% → 80% |  |
| 271 | Science Observations Simulation Tools |  |  | 2% → 20% |  |
| 272 | **Observing Interfaces** |  |  | 2% → 6% |  |
| 273 | Acquisition |  |  | 2% → 10% |  |
| 274 | Observing Sequences |  |  | 2% → 10% |  |
| 298 | **Science Instruments** |  |  | 17% → 31% |  |
| 299 | **Instrument Requirements & Initial Definitions** |  |  | 22% → 31% |  |
| 301 | **Instrument Suite Version 1** |  |  | 46% → 93% | 235.9d → 164.03d |
| 303 | Summary Descriptions of Instruments |  | 2007-05-24 A | 50% → 100% | 235.9d → none |
| 310 | **Deployable NIR IFU (DNIRI)** |  |  | 10% → 60% |  |
| 311 | DNIRI Concept Development |  | 2007-06-15 A | 50% → 100% | 0d → none |
| 312 | **DNIRI AO Interface Issues** | 2007-06-18 A |  | 0% → 97% | 98.53d → 0d |
| 313 | Object Selection for DNIRI | 2007-06-18 A | 2007-06-29 A | 0% → 100% | 98.53d → none |
| 314 | AO Design for DNIRI | 2007-07-02 A |  | 0% → 80% | 98.53d → 0.8d |
| 315 | DNIRI AO Boundary | 2007-07-03 A |  | 0% → 80% | 98.53d → 0d |
| 316 | DNIRI Spectrograph Concepts | 2007-07-04 A | 2007-08-07 A | 0% → 100% | 98.53d → none |
| 317 | DNIRI Imager Concepts | 2007-07-04 A | 2007-08-07 A | 0% → 100% | 98.53d → none |
| 321 | **Single Object Imagers/Low Resolution Spectrographs (SOI/LRS)** |  |  | 33% → 42% |  |
| 322 | SOI/LRS Coronagraph Requirements | 2007-05-07 A |  | 0% → 50% | 169.9d → 10d |
| 323 | SOI/LRS Spectrograph Requirements | 2007-06-04 A |  | 0% → 50% | 169.9d → 5d |
| 324 | SOI/LRS Concept Development | 2007-06-18 A |  | 0% → 50% | 169.9d → 0d |
| 352 | **System Design Manual (SDM)** |  |  | 33% → 66% |  |
| 353 | SDM v1 |  | 2007-09-14 A | 50% → 100% | 0d → none |

## Version 17 (saved 2007-12-12, file NGAO_SD_schedule_v30.mpp)

Last finish 2008-04-17 → 2008-04-30 (+13d). Complete tasks 84 → 87.

Added:

| ID | Task | Duration | Start | Finish | Constraint | Resources |
| --- | --- | --- | --- | --- | --- | --- |
| 55 | **Minor Planets Survey Requirements** | 325d? | 2006-12-04 A | 2008-02-28 |  |  |
| 56 | MP Survey Science Requirements | 325d? | 2006-12-04 A | 2008-02-28 | finish no earlier than 2008-02-28 | McGrath [468.8%] |
| 57 | MP Survey AO Requirements | 325d? | 2006-12-04 A | 2008-02-28 | finish no earlier than 2008-02-28 | Le Mignant [468.8%] |
| 58 | MP Survey Observing Requirements | 325d? | 2006-12-04 A | 2008-02-28 | finish no earlier than 2008-02-28 | Le Mignant [468.8%] |
| 59 | MP Survey Instrument Requirements | 325d? | 2006-12-04 A | 2008-02-28 | finish no earlier than 2008-02-28 | McGrath [468.8%] |
| 60 | **Minor Planet Orbit Determination Requirements** | 325d? | 2006-12-04 A | 2008-02-28 |  |  |
| 61 | MP Orbit Science Requirements | 325d? | 2006-12-04 A | 2008-02-28 | finish no earlier than 2008-02-28 | McGrath [468.8%] |
| 62 | MP Orbit AO Requirements | 325d? | 2006-12-04 A | 2008-02-28 | finish no earlier than 2008-02-28 | Le Mignant [468.8%] |
| 63 | MP Orbit Observing Requirements | 325d? | 2006-12-04 A | 2008-02-28 | finish no earlier than 2008-02-28 | Le Mignant [468.8%] |
| 64 | MP Orbit Instrument Requirements | 325d? | 2006-12-04 A | 2008-02-28 | finish no earlier than 2008-02-28 | McGrath [468.8%] |
| 66 | **Giant Planet Requirements** | 325d? | 2006-12-04 A | 2008-02-28 |  |  |
| 67 | GP Science Requirements | 0.08d? | 2006-12-04 A | 2008-02-28 | finish no earlier than 2008-02-28 | Le Mignant [468.8%] |
| 68 | GP AO Requirements | 0.08d? | 2006-12-04 A | 2008-02-28 | finish no earlier than 2008-02-28 | Le Mignant [468.8%] |
| 69 | GP Observing Requirements | 0.08d? | 2006-12-04 A | 2008-02-28 | finish no earlier than 2008-02-28 | Le Mignant [468.8%] |
| 70 | GP Instrument Requirements | 0.08d? | 2006-12-04 A | 2008-02-28 | finish no earlier than 2008-02-28 | Le Mignant [468.8%] |
| 71 | **Giant Planet Moons Requirements** | 325d? | 2006-12-04 A | 2008-02-28 |  |  |
| 72 | GP Moons Science Requirements | 0.13d? | 2006-12-04 A | 2008-02-28 | finish no earlier than 2008-02-28 | Le Mignant [468.8%] |
| 73 | GP Moons AO Requirements | 0.13d? | 2006-12-04 A | 2008-02-28 | finish no earlier than 2008-02-28 | Le Mignant [468.8%] |
| 74 | GP Moons Observing Requirements | 0.13d? | 2006-12-04 A | 2008-02-28 | finish no earlier than 2008-02-28 | Le Mignant [468.8%] |
| 75 | GP Moons Instrument Requirements | 0.13d? | 2006-12-04 A | 2008-02-28 | finish no earlier than 2008-02-28 | Le Mignant [468.8%] |
| 77 | Asteroids Science Requirements | 325d? | 2006-12-04 A | 2008-02-28 | finish no earlier than 2008-02-28 | Le Mignant [35%]; McGrath |
| 78 | Asteroids AO Requirements | 325d? | 2006-12-04 A | 2008-02-28 | finish no earlier than 2008-02-28 | Le Mignant [35%]; McGrath |
| 79 | Asteroids Observing Requirements | 325d? | 2006-12-04 A | 2008-02-28 | finish no earlier than 2008-02-28 | Le Mignant [35%]; McGrath |
| 80 | Asteroids Instrument Requirements | 325d? | 2006-12-04 A | 2008-02-28 | finish no earlier than 2008-02-28 | Le Mignant [35%]; McGrath |
| 84 | GR Astrometry Science Requirements | 325d? | 2006-12-04 A | 2008-02-28 | finish no earlier than 2008-02-28 | Max [35%] |
| 85 | GR Astrometry AO Requirements | 325d? | 2006-12-04 A | 2008-02-28 | finish no earlier than 2008-02-28 | Max [35%] |
| 86 | GR Astrometry Observing Requirements | 325d? | 2006-12-04 A | 2008-02-28 | finish no earlier than 2008-02-28 | Max [35%] |
| 87 | GR Astrometry Instrument Requirements | 325d? | 2006-12-04 A | 2008-02-28 | finish no earlier than 2008-02-28 | Max [35%] |
| 89 | GR RV Science Requirements | 325d? | 2006-12-04 A | 2008-02-28 | finish no earlier than 2008-02-28 | Max [35%] |
| 90 | GR RV AO Requirements | 325d? | 2006-12-04 A | 2008-02-28 | finish no earlier than 2008-02-28 | Max [35%] |
| 91 | GR RV Observing Requirements | 325d? | 2006-12-04 A | 2008-02-28 | finish no earlier than 2008-02-28 | Max [35%] |
| 92 | GR RV Instrument Requirements | 325d? | 2006-12-04 A | 2008-02-28 | finish no earlier than 2008-02-28 | Max [35%] |
| 97 | Companion Sensitivy AO Requirements | 325d? | 2006-12-04 A | 2008-02-28 | finish no earlier than 2008-02-28 | Max [35%] |
| 102 | Disk AO Requirements | 325d? | 2006-12-04 A | 2008-02-28 | finish no earlier than 2008-02-28 | Max [35%]; Le Mignant |
| 107 | YSO AO Requirements | 325d? | 2006-12-04 | 2008-02-28 | finish no earlier than 2008-02-28 | Max [0.2%]; McGrath |
| 113 | Stellar Populations AO Requirements | 325d? | 2006-12-04 A | 2008-02-28 | finish no earlier than 2008-02-28 | McGrath; Max |
| 118 | High Redshift AO Requirements | 325d? | 2006-12-04 A | 2008-02-28 | finish no earlier than 2008-02-28 | Max [35%]; McGrath |
| 123 | AGN AO Requirements | 325d? | 2006-12-04 A | 2008-02-28 | finish no earlier than 2008-02-28 | Max [35%] |
| 128 | Lensing AO Requirements | 325d? | 2006-12-04 A | 2008-02-28 | finish no earlier than 2008-02-28 | McGrath |
| 131 | **QSO Host Galaxies** | 325d? | 2006-12-04 A | 2008-02-28 |  |  |
| 132 | QSO Science Requirements | 325d? | 2006-12-04 A | 2008-02-28 | finish no earlier than 2008-02-28 | McGrath |
| 133 | QSO AO Requirements | 325d? | 2006-12-04 A | 2008-02-28 | finish no earlier than 2008-02-28 | McGrath |
| 134 | QSO Observing Requirements | 325d? | 2006-12-04 A | 2008-02-28 | finish no earlier than 2008-02-28 | McGrath |
| 135 | QSO Instrument Requirements | 325d? | 2006-12-04 A | 2008-02-28 | finish no earlier than 2008-02-28 | McGrath |

Removed: 13 Science Advisory Committee Telecons; 56 Point Source Companion Sensitivity Requirements; 57 Spectral Sensitivity & Spectral Resolution Requirements; 58 Observing Scenarios; 59 Science Instrument Requirements; 61 Performance Requirements; 62 Observing Scenarios; 63 Science Instrument Requirements; 65 Spatial Resolution Requirements; 66 Spectral Sensitivity & Spectral Resolution Requirements; 67 Observing Scenarios; 68 Science Instrument Requirements; 73 Science Instrument Requirements; 75 Performance Requirements; 76 Observing Scenarios; 77 Science Instrument Requirements; 112 Science Case Requirements Doc Final; 118 Observatory Requirements Rev 3; 119 Observatory Requirements Rev 4; 124 Traceability Matrix Rev 3; 125 Traceability Matrix Rev 4; 130 SRD Final SD Phase Version; 171 PSF Uniformity & Stability; 172 Other; 320 DNIRI Report ver 2; 331 SOI/LRS Near-IR ver 2; 332 SOI/LRS Visible ver 2; 343 SOIFU Near-IR ver 2; 344 SOIFU Visible ver 2; 345 Special Purpose High Contrast Instrument (HCI); 346 HCI Requirements Development; 347 HCI Concept Development; 348 HCI Concept & Need Review with Science Team; 351 Thermal Near-IR Imager

Changed:

| ID | Task | Start | Finish | Duration | Complete | Total float | Predecessors | Other |
| --- | --- | --- | --- | --- | --- | --- | --- | --- |
| 1 | **SD Phase Management** |  | 2008-04-17 → 2008-04-30 (+13d) | 477.4d? → 486d? | 51% → 72% |  |  |  |
| 2 | **Planning and Contracting** |  | 2007-11-29 → 2007-11-30 (+1d) | 377.83d? → 378.33d? |  | 99.57d → 143.3d |  |  |
| 10 | FY08 Replan | 2007-11-12 → 2007-11-13 (+1d) | 2007-11-29 → 2007-11-30 (+1d) |  |  | 99.57d → 143.3d |  |  |
| 11 | **Project Meetings** |  |  | 467d? → 467d | 42% → 75% | 10.4d → 54.63d |  |  |
| 13 | **Team Meetings** |  | 2008-01-09 → 2007-12-13 (-27d) | 345.5d → 327d | 85% → 82% | 70.9d → 133.63d |  |  |
| 25 | Team Meeting #12 | 2007-12-12 → 2007-12-13 (+1d) | 2007-12-12 → 2007-12-13 (+1d) |  |  | 90.4d → 133.63d |  | was named Team Meeting #12 (Keck); constraint start no earlier than 2007-12-12 → start no earlier than 2007-12-13; resources Wizinowich; Dekany; Gavel; Max; Bauman; Bouchez; Velur; Flicker; Neyman; Britton; Le Mignant → Wizinowich; Dekany; Gavel; Max; Bauman; Bouchez; Velur; Flicker; Neyman; Britton; Le Mignant; McGrath; Johansson; Kupke; Lockwood; Reinig; Bell |
| 26 | Team Videocon #13 | 2008-01-09 → 2007-01-23 (-351d) | 2008-01-09 → 2007-01-23 (-351d) | 0.5d → 1d |  | 70.9d → 366.63d |  | constraint start no earlier than 2008-01-09 → start no earlier than 2007-01-23; resources Wizinowich; Dekany; Gavel; Max; Bauman; Bouchez; Velur; Flicker; Neyman; Britton; Le Mignant → Wizinowich; Dekany; Gavel; Max; Adkins; Johansson; Velur; Flicker; Neyman; Britton; Le Mignant |
| 27 | **Tracking and Reporting** |  | 2008-04-03 → 2008-04-30 (+27d) | 405d? → 423d? |  | 9.4d → 0d |  |  |
| 36 | SSC meeting (Keck) | 2008-01-24 → 2008-02-20 (+27d) | 2008-01-24 → 2008-02-20 (+27d) |  |  | 60.4d → 50d |  | constraint start no earlier than 2008-01-24 → start no earlier than 2008-02-20 |
| 37 | SSC meeting (CA) | 2008-04-03 → 2008-04-30 (+27d) | 2008-04-03 → 2008-04-30 (+27d) |  |  | 9.4d → 0d |  | constraint finish no earlier than 2008-04-03 → start no earlier than 2008-04-30 |
| 41 | **System Design Report & Review** |  | 2008-04-17 → 2008-04-21 (+4d) | 143.4d? → 146d? |  | 0d → 6d |  |  |
| 42 | System Design Report | 2008-02-20 → 2008-03-03 (+12d) | 2008-03-03 → 2008-03-07 (+4d) | 8d? → 5d |  | 0d → 6d | 385, 362, SRD Final SD Phase Version → 385, 362 | constraint none → finish no earlier than 2008-03-07; resources Wizinowich [31.2%]; Gavel [7.8%]; Dekany [7.8%]; Adkins [7.8%]; Max [7.8%] → Wizinowich [50%]; Gavel [12.5%]; Dekany [12.5%]; Adkins [12.5%]; Max [12.5%] |
| 43 | **System Design Review** |  | 2008-04-17 → 2008-04-21 (+4d) | 143.4d? → 146d? |  | 0d → 6d |  |  |
| 45 | Review Package Distributed | 2008-03-03 → 2008-03-10 (+7d) | 2008-03-04 → 2008-03-10 (+6d) |  |  | 4d → 9d |  |  |
| 46 | Reviewer Comments Addressed | 2008-03-18 → 2008-03-25 (+7d) | 2008-03-25 → 2008-03-28 (+3d) | 5d? → 4d? |  | 4d → 9d |  | constraint finish no earlier than 2008-02-01 → finish no earlier than 2008-03-28; resources Wizinowich [75%]; Dekany [60%]; Gavel [60%]; Max [65%]; Adkins(IPM) [40%] → Wizinowich [93.8%]; Dekany [75%]; Gavel [75%]; Max [81.2%]; Adkins(IPM) [50%] |
| 47 | System Design Review Support | 2008-03-03 → 2008-03-07 (+4d) | 2008-03-31 → 2008-04-02 (+2d) | 20d? → 18d? |  | 0d → 6d |  | constraint start no earlier than 2007-01-16 → finish no earlier than 2008-04-02; resources Wizinowich [15%]; Dekany [15%]; Gavel [15%]; Max [15%]; Bauman [7.5%]; Bouchez [2.5%]; Velur [10%]; Flicker [10%]; Neyman [16.2%]; Le Mignant [10%]; Johansson [10%]; Adkins(IPM) [10%]; Chin [5%]; Kellner [5%]; Moore [10%] → Wizinowich [16.7%]; Dekany [16.7%]; Gavel [16.7%]; Max [16.7%]; Bauman [7.5%]; Bouchez [2.5%]; Velur [11.1%]; Flicker [10%]; Neyman [18.1%]; Le Mignant [11.1%]; Johansson [11.1%]; Adkins(IPM) [11.1%]; Chin [5%]; Kellner [5%]; Moore [10%] |
| 48 | System Design Review Meeting | 2008-03-31 → 2008-04-02 (+2d) | 2008-03-31 → 2008-04-02 (+2d) |  |  | 0d → 6d |  |  |
| 49 | Reviewer Report Received | 2008-04-14 → 2008-04-16 (+2d) | 2008-04-14 → 2008-04-16 (+2d) |  |  | 0d → 6d |  |  |
| 50 | Response to Reviewer Report & Distribution | 2008-04-14 → 2008-04-17 (+3d) | 2008-04-17 → 2008-04-21 (+4d) |  |  | 0d → 6d |  |  |
| 51 | **System Requirements** |  | 2007-11-02 → 2008-03-07 (+126d) | 286d? → 376d? | 50% → 2% | 118.4d → 72.63d |  |  |
| 52 | **Science Requirements** |  | 2007-10-15 → 2008-02-28 (+136d) | 272d? → 370d? | 50% → 1% | 132.4d → 78.63d |  |  |
| 53 | **Solar System Science Requirements** | 2006-10-02 A → 2006-12-04 A (+63d) | 2007-08-31 → 2008-02-28 (+181d) | 240d? → 325d? | 59% → 0% | 164.4d → 78.63d |  |  |
| 54 | **Multiplicity of Minor Planets (Key)** | 2006-10-02 A → 2006-12-04 A (+63d) | 2007-05-15 → 2008-02-28 (+289d) | 162d? → 325d? | 80% → 0% | 242.4d → 78.63d |  | was named Companions & Multiplicity of Small Solar System Bodies |
| 65 | **Giant Planets & Their Moons** |  | 2007-08-31 → 2008-02-28 (+181d) | 195d? → 325d? | 31% → 35% | 164.4d → 78.63d |  | was named Moons of the Giant Planets |
| 76 | **Shape & Size of Asteroids** | 2007-01-29 A → 2006-12-04 A (-56d) | 2007-05-15 → 2008-02-28 (+289d) | 77d? → 325d? | 69% → 0% | 242.4d → 0d |  |  |
| 81 | **Galactic Science Requirements** | 2006-10-02 A → 2006-11-27 A (+56d) | 2007-08-31 → 2008-02-28 (+181d) | 240d? → 330d? | 43% → 0% | 164.4d → 78.63d |  |  |
| 82 | **General Relativity at the Galactic Center (Key)** | 2006-10-02 A → 2006-12-04 A (+63d) | 2007-07-02 → 2008-02-28 (+241d) | 196d? → 325d? | 61% → 0% | 208.4d → 78.63d |  | was named Galactic Center Proper Motions: Astrometry |
| 83 | **GR Astrometry Requirements** | 2006-10-02 A → 2006-12-04 A (+63d) | 2007-07-02 → 2008-02-28 (+241d) | 196d? → 325d? | 40% → 1% | 208.4d → 78.63d |  | was named Astrometry requirements; constraint finish no earlier than 2007-07-02 → none; resources Student2 [37.5%] → none |
| 88 | **GR Radial Velocity Requirements** | 2006-11-27 A → 2006-12-04 A (+7d) | 2007-07-02 → 2008-02-28 (+241d) | 156d? → 325d? | 75% → 0% | 208.4d → 78.63d |  | was named Observing Scenarios; constraint finish no earlier than 2007-07-02 → none; resources Student2 [8.9%] → none |
| 93 | Resolved Stellar Populations at the Galactic Center |  | 2007-08-01 → 2006-11-27 (-247d) | 178d? → 1d? | 53% → 13% | 186.4d → 407.63d |  | was named Galactic Center Radial Velocities & Stellar Populations: Integral Field Spectroscopy |
| 95 | **Planets around Low Mass Stars & Brown Dwarfs: Companion Sensitivity (Key)** | 2006-10-02 A → 2006-12-04 A (+63d) | 2007-06-01 → 2008-02-28 (+272d) | 175d? → 325d? | 54% → 1% | 229.4d → 78.63d |  | was named Planets around Low Mass Stars & Brown Dwarfs: Companion Sensitivity |
| 96 | Companion Sensitivity Science Requirements | 2006-10-02 A → 2006-12-04 A (+63d) | 2007-06-01 → 2008-02-28 (+272d) | 175d? → 325d? | 60% → 0% | 229.4d → 78.63d |  | was named Companion Sensitivity Performance Requirements; constraint finish no earlier than 2007-06-01 → finish no earlier than 2008-02-28; resources Student2 [37.5%] → Max [37.5%] |
| 98 | Companion Sensitivity Observing Requirements | 2006-11-27 A → 2006-12-04 A (+7d) | 2007-06-01 → 2008-02-28 (+272d) | 135d? → 325d? | 40% → 2% | 229.4d → 78.63d |  | was named Observing Scenarios; constraint finish no earlier than 2007-06-01 → finish no earlier than 2008-02-28; resources Student2 [8.9%] → Max [8.9%] |
| 99 | Companion Sensitivity Instrument Requirements | 2006-11-27 A → 2006-12-04 A (+7d) | 2007-06-01 → 2008-02-28 (+272d) | 135d? → 325d? | 60% → 2% | 229.4d → 78.63d |  | was named Science Instrument Requirements; constraint finish no earlier than 2007-06-01 → finish no earlier than 2008-02-28; resources Student2 [8.9%] → Max [8.9%] |
| 100 | **Debris & Protoplanetary Disks** | 2007-01-29 A → 2006-12-04 A (-56d) | 2007-07-02 → 2008-02-28 (+241d) | 111d? → 325d? | 10% → 0% | 208.4d → 78.63d |  | was named Debris Disks, Protostellar Envelopes & Outflows: Contrast |
| 101 | Disk Science Requirements | 2007-01-29 A → 2006-12-04 A (-56d) | 2007-07-02 → 2008-02-28 (+241d) | 111d? → 282.58d? | 10% → 0% | 208.4d → 78.63d |  | was named Contrast Performance Requirements; constraint finish no earlier than 2007-07-02 → finish no earlier than 2008-02-28; resources Student2 [75%] → Max [75%]; Le Mignant [0.1%] |
| 103 | Disk Observing Requirements | 2007-03-05 A → 2006-12-04 A (-91d) | 2007-07-02 → 2008-02-28 (+241d) | 86d? → 325d? | 10% → 0% | 208.4d → 78.63d |  | was named Observing Scenarios; constraint finish no earlier than 2007-07-02 → finish no earlier than 2008-02-28; resources Student2 [12.5%] → Max [12.5%]; Le Mignant [0.1%] |
| 104 | Disk Instrument Requirements | 2007-03-05 A → 2006-12-04 A (-91d) | 2007-07-02 → 2008-02-28 (+241d) | 86d? → 325d? | 10% → 0% | 208.4d → 78.63d |  | was named Science Instrument Requirements; constraint finish no earlier than 2007-07-02 → finish no earlier than 2008-02-28; resources Student2 [12.5%] → Max [12.5%]; Le Mignant [0.1%] |
| 105 | **Young Stellar Objects** | 2007-05-15 → 2006-12-04 (-162d) | 2007-08-31 → 2008-02-28 (+181d) | 79d? → 325d? |  | 164.4d → 78.63d |  | was named Debris Disks, Protostellar Envelopes & Outflows: Polarimetry |
| 106 | YSO Science Requirements | 2007-05-15 → 2006-12-04 (-162d) | 2007-08-31 → 2008-02-28 (+181d) | 79d? → 325d? |  | 164.4d → 78.63d |  | was named Polarimetry Performance Requirements; constraint start no earlier than 2007-05-15 → start no earlier than 2006-12-04; resources Student2 [23.7%] → Max [0.2%]; McGrath |
| 108 | YSO Observing Requirements | 2007-05-15 → 2006-12-04 (-162d) | 2007-08-31 → 2008-02-28 (+181d) | 79d? → 325d? |  | 164.4d → 78.63d |  | was named Observing Scenarios; constraint start no earlier than 2007-05-15 → finish no earlier than 2008-02-28; resources Student2 [4%] → Max [0.2%]; McGrath |
| 109 | YSO Instrument Requirements | 2007-05-15 → 2006-12-04 (-162d) | 2007-08-31 → 2008-02-28 (+181d) | 79d? → 325d? |  | 164.4d → 78.63d |  | was named Science Instrument Requirements; constraint start no earlier than 2007-05-15 → finish no earlier than 2008-02-28; resources Student2 [4%] → Max [0.2%]; McGrath |
| 110 | **Extragalactic Science Requirements** | 2006-10-02 A → 2006-12-04 A (+63d) | 2007-10-01 → 2008-02-28 (+150d) | 262d? → 325d? | 52% → 1% | 142.4d → 78.63d |  |  |
| 111 | **Resolved Stellar Populations in Crowded Fields** | 2006-10-02 A → 2006-12-04 A (+63d) | 2007-10-01 → 2008-02-28 (+150d) | 262d? → 325d? | 57% → 2% | 142.4d → 78.63d |  |  |
| 112 | Stellar Populations Science Requirements | 2006-10-02 A → 2006-12-04 A (+63d) | 2007-10-01 → 2008-02-28 (+150d) | 261d? → 290.4d? | 60% → 1% | 142.4d → 78.63d |  | was named Performance Requirements; constraint finish no earlier than 2007-10-01 → finish no earlier than 2008-02-28; resources McGraw [52.1%] → McGrath [52.1%]; Max [0.1%] |
| 114 | Stellar Populations Observing Requirements | 2006-12-11 A → 2006-12-04 A (-7d) | 2007-10-01 → 2008-02-28 (+150d) | 211d? → 316d? | 60% → 4% | 142.4d → 78.63d |  | was named Observing Scenarios; constraint finish no earlier than 2007-10-01 → finish no earlier than 2008-02-28; resources McGraw [7.8%] → McGrath [7.8%]; Max [0.1%] |
| 115 | Stellar Populations Instrument Requirements | 2006-12-11 A → 2006-12-04 A (-7d) | 2007-10-01 → 2008-02-28 (+150d) | 211d? → 320d? | 50% → 4% | 142.4d → 78.63d |  | was named Science Instrument Requirements; constraint finish no earlier than 2007-10-01 → finish no earlier than 2008-02-28; resources McGraw [7.8%] → McGrath [7.8%]; Max [0.1%] |
| 116 | **High Redshift Galaxies (Key)** | 2006-10-02 A → 2006-12-04 A (+63d) | 2007-06-01 → 2008-02-28 (+272d) | 175d? → 325d? | 67% → 1% | 229.4d → 0d |  | was named High Redshift Galaxies |
| 117 | High Redshift Science Requirements | 2006-10-02 A → 2006-12-04 A (+63d) | 2007-06-01 → 2008-02-28 (+272d) | 175d? → 285.1d? | 70% → 1% | 229.4d → 0d |  | was named Encircled Energy (& d-IFU) Performance Requirements; constraint finish no earlier than 2007-06-01 → finish no earlier than 2008-02-28; resources McGraw [41.7%] → McGrath [41.7%]; Max [35%] |
| 119 | High Redshift Observing Requirements | 2006-12-11 A → 2006-12-04 A (-7d) | 2007-06-01 → 2008-02-28 (+272d) | 125d? → 297.6d? | 70% → 2% | 229.4d → 0d |  | was named Observing Scenarios; constraint finish no earlier than 2007-06-01 → finish no earlier than 2008-02-28; resources McGraw [15.6%] → McGrath [15.6%]; Max [35%] |
| 120 | High Redshift Instrument Requirements | 2006-12-11 A → 2006-12-04 A (-7d) | 2007-06-01 → 2008-02-28 (+272d) | 125d? → 301.6d? | 60% → 2% | 229.4d → 0d |  | was named Science Instrument Requirements; constraint finish no earlier than 2007-06-01 → finish no earlier than 2008-02-28; resources McGraw [15.6%] → McGrath [15.6%]; Max [35%] |
| 121 | **Nearby Active Galactic Nuclei (Key)** | 2006-12-11 A → 2006-12-04 A (-7d) | 2007-08-31 → 2008-02-28 (+181d) | 190d? → 325d? | 40% → 1% | 164.4d → 78.63d |  | was named Nearby Galaxies |
| 122 | AGN Science Requirements | 2006-12-11 A → 2006-12-04 A (-7d) | 2007-08-31 → 2008-02-28 (+181d) | 190d? → 325d? | 40% → 0% | 164.4d → 78.63d |  | was named Encircled Energy & PSF Performance Requirements; constraint finish no earlier than 2007-08-31 → finish no earlier than 2008-02-28; resources McGraw [31.2%] → Max [31.2%] |
| 124 | AGN Observing Requirements | 2007-03-05 A → 2006-12-04 A (-91d) | 2007-08-31 → 2008-02-28 (+181d) | 130d? → 325d? | 20% → 2% | 164.4d → 78.63d |  | was named Observing Scenarios; constraint finish no earlier than 2007-08-31 → finish no earlier than 2008-02-28; resources McGraw [7.8%] → Max [7.8%] |
| 125 | AGN Instrument Requirements | 2007-03-05 A → 2006-12-04 A (-91d) | 2007-08-31 → 2008-02-28 (+181d) | 130d? → 325d? | 60% → 2% | 164.4d → 78.63d |  | was named Science Instrument Requirements; constraint finish no earlier than 2007-08-31 → finish no earlier than 2008-02-28; resources McGraw [7.8%] → Max [7.8%] |
| 126 | **Gravitational Lensing** | 2006-12-11 A → 2006-12-04 A (-7d) | 2007-07-02 → 2008-02-28 (+241d) | 146d? → 325d? | 38% → 1% | 208.4d → 78.63d |  |  |
| 127 | Lensing Science Requirements | 2006-12-11 A → 2006-12-04 A (-7d) | 2007-07-02 → 2008-02-28 (+241d) | 146d? → 325d? | 30% → 0% | 208.4d → 78.63d |  | was named Encircled Energy & PSF Performance Requirements; constraint finish no earlier than 2007-07-02 → finish no earlier than 2008-02-28; resources McGraw [31.2%] → McGrath [31.2%] |
| 129 | Lensing Observing Requirements | 2007-03-05 A → 2006-12-04 A (-91d) | 2007-07-02 → 2008-02-28 (+241d) | 86d? → 325d? | 30% → 2% | 208.4d → 78.63d |  | was named Observing Scenarios; constraint finish no earlier than 2007-07-02 → finish no earlier than 2008-02-28; resources McGraw [7.8%] → McGrath [7.8%] |
| 130 | Lensing Instrument Requirements | 2007-03-05 A → 2006-12-04 A (-91d) | 2007-07-02 → 2008-02-28 (+241d) | 86d? → 325d? | 60% → 2% | 208.4d → 78.63d |  | was named Science Instrument Requirements; constraint finish no earlier than 2007-07-02 → finish no earlier than 2008-02-28; resources McGraw [7.8%] → McGrath [7.8%] |
| 136 | **Science Case Requirements Document** |  | 2007-10-15 → 2008-02-15 (+123d) | 272d? → 361d? | 33% → 14% | 132.4d → 87.63d |  |  |
| 138 | Science Case Requirements Doc Rev 2 |  | 2007-06-01 → 2007-12-20 (+202d) | 45d? → 190d? | 40% → 9% | 229.4d → 128.63d |  | constraint start no earlier than 2007-04-02 → finish no earlier than 2007-12-20 |
| 139 | Science Case Requirements Doc Rev 3 | 2007-06-05 → 2008-01-07 (+216d) | 2007-07-09 → 2008-02-15 (+221d) | 24.89d? → 30d? |  | 188.4d → 72.63d |  | constraint finish no earlier than 2007-07-09 → finish no earlier than 2008-02-15; resources Max [10%]; Wizinowich [10%] → Max [8.3%]; McGrath [8.3%] |
| 140 | **Observatory Requirements** |  | 2007-09-07 → 2007-12-20 (+104d) | 245d? → 320d? | 58% → 32% | 108.4d → 0d |  |  |
| 144 | Observatory Requirements Rev 2 |  | 2007-02-09 → 2007-12-20 (+314d) | 15d? → 240d? | 50% → 3% | 108.4d → 0d |  | constraint none → finish no earlier than 2007-12-20; resources Neyman [20%]; Meguro [8.3%]; Le Mignant [13.3%]; Adkins [8.3%]; Johansson [8.3%]; Chin [8.3%] → Neyman [20%]; Bell [8.3%]; Le Mignant [13.3%]; Adkins [8.3%]; Johansson [8.3%]; Chin [8.3%] |
| 145 | **System Requirements Document** |  | 2007-11-02 → 2008-03-07 (+126d) | 281d? → 371d? | 37% → 53% | 118.4d → 72.63d |  |  |
| 146 | **Traceability Matrix** |  | 2007-10-20 → 2007-02-27 (-235d) | 271d? → 102d? | 24% → 45% | 122.9d → 335.98d |  |  |
| 149 | **System Requirements Document** |  | 2007-11-02 → 2008-03-07 (+126d) | 246d → 336d | 46% → 56% | 118.4d → 72.63d |  |  |
| 151 | SRD Rev 2 |  | 2007-05-15 → 2007-12-28 (+227d) |  | 75% → 74% | 242.4d → 122.98d |  |  |
| 152 | SRD Rev 3 | 2007-08-13 → 2008-02-18 (+189d) | 2007-08-31 → 2008-03-07 (+189d) |  |  | 164.4d → 72.63d | 139, Traceability Matrix Rev 3, Observatory Requirements Rev 3 → 139 |  |
| 153 | **System Design** |  | 2008-03-21 → 2008-02-26 (-24d) | 421d? → 403d? | 48% → 50% | 18.4d → 44d |  |  |

| ID | Task | Start | Finish | Duration | Complete | Total float | Other |
| --- | --- | --- | --- | --- | --- | --- | --- |
| 154 | **Systems Engineering** |  | 2008-01-17 → 2008-02-26 (+40d) | 374.75d? → 403d? | 80% → 77% | 64.65d → 44d |  |
| 155 | **Performance Budgets** |  | 2007-11-27 → 2008-02-26 (+91d) | 337.75d? → 403d? | 76% → 75% | 101.65d → 44d |  |
| 166 | **Model/Tool Validation** |  |  |  | 45% → 55% | 209.4d → 253.63d |  |
| 169 | Anchor to Keck II LGS AO PSFs |  |  |  | 25% → 3% | 209.4d → 253.63d |  |
| 171 | Anchor to LAO Lab Experiments |  | 2007-06-29 A |  | 50% → 100% | 209.4d → none |  |
| 173 | **Background** |  | 2007-05-18 A |  | 99% → 100% | 170.53d → none |  |
| 174 | Document Proposal Analysis |  | 2006-10-02 A | 0.9d? → 0d? | 25% → 100% | 334.63d → none |  |
| 176 | **Wavefront Error vs Sky Coverage** |  | 2007-09-28 → 2008-02-05 (+130d) | 261d? → 353d? | 67% → 70% | 74.53d → 44d |  |
| 178 | Document WFE Budget Rev 2 | 2007-06-19 → 2007-11-05 (+139d) | 2007-09-28 → 2008-02-05 (+130d) | 75d? → 67d? |  | 74.53d → 44d | constraint finish no earlier than 2007-09-28 → finish no earlier than 2008-02-05; resources Dekany [6.7%]; Britton [17%] → Dekany [7.5%]; Britton [17%] |
| 182 | Polarimetric Accuracy |  |  |  | 75% → 23% | 165.53d → 209.77d |  |
| 184 | Observing Efficiency |  |  |  | 50% → 9% | 74.53d → 0d |  |
| 185 | Observing Uptime |  |  |  | 25% → 27% | 74.53d → 0d | resources Chin [19.7%]; Johansson [19.7%] → Chin [17.9%]; Johansson [17.9%] |
| 186 | **Performance Budgets Summary** |  | 2007-10-19 → 2008-02-26 (+130d) | 106d? → 198d? |  | 74.53d → 44d |  |
| 188 | Performance Budgets Summary Ver 2 | 2007-10-01 → 2008-02-05 (+127d) | 2007-10-19 → 2008-02-26 (+130d) |  |  | 74.53d → 44d | constraint none → start no earlier than 2008-01-07 |
| 189 | **Science Products** | 2007-10-01 → 2008-02-05 (+127d) | 2007-11-27 → 2008-02-15 (+80d) | 41.75d? → 7.5d? |  | 101.65d → 88.13d |  |
| 190 | All-In Science Simulations (cancelled) | 2007-10-01 → 2008-02-05 (+127d) | 2007-10-31 → 2008-02-05 (+97d) | 23d? → 0d? |  | 101.65d → 88.13d | was named All-In Science Simulations |
| 191 | **Additional Science Characterization Results** | 2007-11-01 → 2008-02-06 (+97d) | 2007-11-27 → 2008-02-15 (+80d) | 18.75d? → 7.5d? |  | 101.65d → 88.13d |  |
| 192 | Point Source Sensitivities | 2007-11-01 → 2008-02-06 (+97d) | 2007-11-27 → 2008-02-15 (+80d) | 18.75d? → 7.5d? |  | 101.65d → 88.13d | constraint start no earlier than 2007-04-02 → start no earlier than 2008-01-21; resources Bouchez [20%] → Bouchez [33.3%] |
| 193 | **Trade Studies** |  | 2007-07-27 → 2007-12-14 (+140d) | 205d? → 306d? | 97% → 86% |  |  |
| 203 | **Adaptive Optics System Trade Studies** |  | 2007-07-27 → 2007-12-14 (+140d) | 195d? → 296d? | 92% → 67% |  |  |
| 209 | d-IFU & LOWFS AO & Object Selection TS |  | 2007-07-27 → 2007-12-14 (+140d) | 45d? → 146d? | 50% → 11% |  | constraint start no earlier than 2007-05-28 → finish no earlier than 2007-12-14 |
| 215 | **System Architecture** |  | 2008-01-17 → 2008-02-15 (+29d) | 183.75d? → 205d? | 58% → 65% | 64.65d → 51d |  |
| 228 | **Functional Requirements** |  | 2008-01-17 → 2008-02-15 (+29d) | 183.75d? → 205d? | 42% → 48% | 10.78d → 51d |  |
| 233 | Laser System Functional Requirements Ver 2 |  |  |  | 40% → 29% | 44.53d → 88.77d | resources Chin [12.5%]; Velur [12.5%]; Johansson [8%] → Neyman [12.5%]; Velur [12.5%]; Johansson [8%] |
| 234 | Science Operations Functional Requirements Ver 1 | 2007-08-06 → 2007-12-03 (+119d) | 2007-08-31 → 2007-12-14 (+105d) | 20d? → 10d? |  | 110.53d → 78.77d | constraint finish no earlier than 2007-08-31 → start no earlier than 2007-12-03; resources Le Mignant [25%]; Wizinowich [31.2%] → Le Mignant [25%]; Wizinowich [31.2%]; McGrath |
| 235 | Science Operations Functional Requirements Ver 2 | 2007-10-29 → 2008-02-04 (+98d) | 2007-11-30 → 2008-02-15 (+77d) | 25d? → 10d? |  | 44.53d → 33.77d | constraint start no earlier than 2007-10-29 → finish no earlier than 2008-02-15; resources Le Mignant [20%]; Other [30%] → Le Mignant [25%]; McGrath [30%] |
| 238 | Technology Drivers Summary |  |  | 0.23d? → 0d? |  | 124.4d → 168.63d |  |
| 240 | Technical Risk Analysis Ver 2 | 2007-12-03 → 2008-01-16 (+44d) | 2007-12-28 → 2008-01-31 (+34d) | 20d? → 12d? |  | 24.53d → 44.77d | constraint start no earlier than 2007-12-03 → finish no earlier than 2008-01-31; resources Neyman [15.6%] → Neyman [10.4%]; Wizinowich [40%] |
| 241 | **AO System** |  |  |  | 16% → 14% | 34.53d → 96d |  |
| 244 | **Opto-mechanical** |  |  |  | 15% → 13% | 34.53d → 96d |  |
| 245 | Field Rotation |  |  |  |  | 45.53d → 9d | resources Bauman [8.3%]; Lockwood [4.2%] → Kupke [8.3%]; Lockwood [4.2%] |
| 246 | Optical Relay |  |  |  | 40% → 39% | 45.53d → 9d | resources Bauman [11.1%]; Lockwood [3.4%]; Dekany [2.8%] → Kupke [11.1%]; Lockwood [3.4%]; Dekany [2.8%] |
| 247 | Optical Switchyard |  |  |  |  | 45.53d → 9d | resources Bauman [6.9%]; Lockwood [6.9%] → Kupke [6.9%]; Lockwood [6.9%] |
| 248 | Optical Support Structure | 2007-11-05 A → 2007-11-15 A (+10d) |  | 20d? → 12d? | 5% → 8% | 44.53d → 0d | resources Lockwood [18.8%]; Bauman [9.4%] → Lockwood [32.4%]; Bauman [9.4%] |
| 249 | **Wavefront Sensors** |  |  |  | 9% → 8% | 54.53d → 116d |  |
| 250 | High Order LGS Wavefront Sensors |  |  |  |  | 54.53d → 98.77d | resources Velur [11.9%]; Meguro [4%] → Velur [11.9%]; Bell [4%] |
| 251 | High Order NGS Wavefront Sensor |  |  |  |  | 54.53d → 98.77d | resources Velur [5.9%]; Meguro [2%] → Velur [5.9%]; Bell [2%] |
| 252 | Low Order NGS Wavefront Sensors |  |  |  | 5% → 2% | 54.53d → 98.77d | resources Kellner [3.2%]; Meguro [4%]; Velur [7.9%]; Moore [40%] → Kellner [3.2%]; Bell [4%]; Velur [7.9%]; Moore [40%] |
| 255 | Tip/Tilt Corrector |  |  |  |  | 44.53d → 0d | resources Flicker [2.8%]; Bauman [2.8%] → Neyman [2.8%]; Bauman [2.8%] |
| 257 | Tip/tilt Vibration Mitigation |  |  |  | 2% → 0% | 45.43d → 0d |  |
| 261 | Atmospheric Dispersion Correction |  |  |  | 30% → 16% |  |  |
| 262 | Alignment, Calibration, Diagnostics, Metrology and Monitoring |  | 2007-06-29 → 2007-08-02 (+34d) | 24d? → 48d? | 25% → 19% | 155.53d → 0d |  |
| 263 | Atmospheric Profiler |  |  | 30.14d? → 2.41d? | 2% → 6% | 87.53d → 149d | resources Britton [20.7%] → Britton [20.7%]; Gavel [35%]; Neyman [83%] |
| 264 | d-IFU & LOWFS AO & Object Selection | 2007-08-22 → 2007-08-23 (+1d) | 2007-11-07 → 2007-12-14 (+37d) | 56.14d? → 82.93d? |  | 61.53d → 78.77d | constraint finish no earlier than 2007-11-07 → finish no earlier than 2007-12-14; resources Moore [17.8%]; Gavel; Meguro → Moore [10.9%]; Gavel; Bell; Velur [75%] |
| 265 | PSF Monitoring Camera |  | 2007-10-26 → 2007-11-23 (+28d) | 20d? → 40d? | 2% → 0% | 69.53d → 93.77d |  |
| 266 | **Non-real-time Control** |  |  |  | 10% → 3% | 50.53d → 112d |  |
| 267 | Non-RTC Software |  |  |  | 10% → 5% | 110.53d → 154.77d | constraint start no earlier than 2007-06-25 → finish no earlier than 2007-08-31 |
| 268 | Non-RTC Electronics |  |  |  | 10% → 2% | 50.53d → 0d |  |
| 269 | **Real-time Control** |  |  |  | 16% → 11% | 43.53d → 105d |  |
| 270 | RTC Architecture Analysis and Design Study |  |  |  | 20% → 16% | 50.23d → 0d |  |
| 271 | RTC Software Module Definition |  |  |  | 10% → 9% | 43.53d → 87.77d |  |
| 272 | RTC Hardware Module Definition |  |  |  | 20% → 13% | 43.53d → 87.77d |  |
| 273 | **Laser Facility** |  |  |  | 9% → 10% | 31.53d → 93d |  |
| 275 | Laser Enclosure |  |  |  |  | 31.53d → 75.77d | constraint none → finish no earlier than 2007-12-19; resources Meguro [23.3%] → Bell [23.3%] |
| 277 | **Laser Launch Facility** |  |  |  | 4% → 3% | 105.53d → 0d |  |
| 279 | Laser Pointing & Diagnostics |  |  |  | 5% → 2% | 105.53d → 0d |  |
| 281 | **Laser Safety Systems** |  |  |  | 6% → 4% | 64.53d → 126d |  |
| 282 | Personnel and Equipment Safety Systems |  |  | 20d? → 6d? | 10% → 2% | 64.53d → 126d | constraint start no earlier than 2007-10-08 → finish no earlier than 2007-11-02; resources Chin [12.5%] → Neyman [12.5%] |
| 283 | Aircraft, Satellite & Laser Traffic Control Safety Systems |  |  | 20d? → 2d? | 2% → 8% | 64.53d → 126d | constraint start no earlier than 2007-10-08 → finish no earlier than 2007-11-02; resources Chin [12.5%] → Summers [12.5%]; Neyman [83%] |
| 286 | Laser System Electronics |  |  | 55d? → 23.57d? | 5% → 4% | 34.53d → 96d | resources Chin [15.9%] → Chin [15.9%]; Neyman [83%] |
| 288 | **Astronomical Observations Operations** |  |  |  | 9% → 10% | 34.53d → 96d |  |
| 290 | AO Guide Star Interface |  |  |  |  | 115.53d → 159.77d | resources McGraw [11.4%] → McGrath [11.4%] |
| 291 | Science Observations Simulation Tools |  |  |  |  | 115.53d → 159.77d | resources McGraw [22.7%] → McGrath [22.7%] |
| 293 | Acquisition |  |  |  |  | 137.53d → 181.77d | resources McGraw [5.8%] → McGrath [5.8%] |
| 294 | Observing Sequences |  |  |  |  | 137.53d → 181.77d | resources McGraw [5.8%] → McGrath [5.8%] |
| 295 | Instrument, AO & Telescope Observer Interfaces |  |  |  | 2% → 1% | 137.53d → 181.77d | constraint start no earlier than 2007-05-28 → finish no earlier than 2007-07-25; resources Johansson [5.8%] → Le Mignant [5.8%] |
| 296 | Science Data Quality Monitoring |  |  | 43d? → 21.5d? |  | 34.53d → 96d | resources McGraw [5.8%] → Le Mignant [5.8%] |
| 297 | **Post-Observing Interfaces** |  |  |  | 2% → 1% | 44.53d → 106d |  |
| 298 | Generic Data Products |  |  |  | 2% → 1% | 47.53d → 91.77d | constraint start no earlier than 2007-10-01 → finish no earlier than 2007-11-27; resources McGraw [6%] → Le Mignant [6%] |
| 299 | Science Data Quality Assessment |  |  |  | 2% → 1% | 47.53d → 91.77d | constraint start no earlier than 2007-10-01 → finish no earlier than 2007-11-27; resources McGraw [6%] → Le Mignant [6%] |

| ID | Task | Start | Finish | Duration | Complete | Total float | Predecessors | Other |
| --- | --- | --- | --- | --- | --- | --- | --- | --- |
| 300 | Science Data Archiving |  |  |  | 2% → 1% | 47.53d → 91.77d |  | constraint start no earlier than 2007-10-01 → finish no earlier than 2007-11-27; resources McGraw [11.9%] → Le Mignant [11.9%] |
| 301 | PSF Reconstruction |  |  | 45d? → 22.5d? | 2% → 1% | 44.53d → 106d |  |  |
| 304 | AO-Instrument Observing Modes |  |  |  |  | 160.53d → 204.77d |  | constraint start no earlier than 2007-05-22 → finish no earlier than 2007-06-22; resources Le Mignant [20.8%]; McGraw [20.8%] → Le Mignant [20.8%]; McGrath [20.8%] |
| 305 | AO-Instrument Operations Support |  |  | 15d? → 7.5d? |  | 145.53d → 207d |  |  |
| 306 | AO-Instrument Configuration & Setup |  |  | 83d? → 41.5d? |  | 69.53d → 131d |  |  |
| 307 | AO-Instrument Calibrations |  |  |  | 2% → 1% | 92.53d → 136.77d |  | constraint start no earlier than 2007-06-04 → finish no earlier than 2007-09-25; resources van Dam [3%] → Le Mignant [3%] |
| 308 | AO-Instrument Nighttime Operation Modes |  |  | 83d? → 41.5d? |  | 92.53d → 154d |  | constraint start no earlier than 2007-06-04 → finish no earlier than 2007-09-25 |
| 309 | AO-Instrument Science Acquisition & Control |  |  |  |  | 72.53d → 116.77d |  | constraint start no earlier than 2007-07-02 → finish no earlier than 2007-10-23; resources McGraw [3%] → McGrath [3%] |
| 310 | AO-Instrument Health Monitoring & Automated Recovery | 2007-06-11 A → 2007-10-02 (+113d) |  | 83d? → 0d? | 2% → 0% | 87.53d → 131.77d |  | constraint start no earlier than 2007-06-11 → finish no earlier than 2007-10-02 |
| 312 | AO-Instrument User Interfaces |  |  | 20d? → 10d? |  | 69.53d → 131d |  | constraint start no earlier than 2007-10-01 → finish no earlier than 2007-10-26 |
| 313 | AO-Instrument Maintenance Plan | 2007-10-01 A → 2007-10-26 (+25d) |  | 20d? → 0d? | 2% → 0% | 69.53d → 113.77d |  | constraint start no earlier than 2007-10-01 → finish no earlier than 2007-10-26 |
| 314 | **AO-Instrument Operations Optimization** |  |  |  | 2% → 1% | 135.53d → 197d |  |  |
| 315 | AO-Instrument Performance Prediction |  |  |  | 2% → 0% | 135.53d → 0d |  | constraint start no earlier than 2007-06-18 → finish no earlier than 2007-07-27; resources Flicker [25%]; van Dam [8.3%] → Le Mignant [25%]; Johansson [8.3%] |
| 316 | AO-Instrument Real-Time Optimization |  |  |  | 2% → 1% | 135.53d → 179.77d |  | constraint start no earlier than 2007-06-18 → finish no earlier than 2007-07-27; resources Flicker [25%]; van Dam [8.3%] → Johansson [25%]; Le Mignant [8.3%] |
| 317 | AO-Instrument Environment Monitoring | 2007-06-18 A → 2007-07-06 (+18d) |  | 15d? → 0d? | 2% → 0% | 150.53d → 194.77d |  | constraint start no earlier than 2007-06-18 → finish no earlier than 2007-07-06 |
| 318 | **Science Instruments** |  | 2008-03-21 → 2008-01-25 (-56d) | 386d? → 346d? | 31% → 45% | 18.4d → 67d |  |  |
| 326 | Revised Summary Descriptions of Instruments |  |  |  |  | 58.4d → 67d |  | constraint finish no earlier than 2008-01-25 → start no earlier than 2008-01-14; resources Adkins [25%] → Adkins [10%] |
| 328 | Hardware Instrument Interfaces |  |  |  |  | 214.4d → 223d |  | resources Adkins [19.2%]; Meguro → Adkins [7.7%]; Meguro |
| 329 | Software Instrument Interfaces |  |  |  |  | 209.4d → 218d |  | resources Adkins [17.9%]; Johansson → Adkins [7.1%]; Johansson |
| 330 | **Deployable NIR IFU (DNIRI)** |  | 2008-03-07 → 2007-09-18 (-171d) | 221d? → 98d? | 60% → 75% | 28.4d → 160d |  |  |
| 332 | **DNIRI AO Interface Issues** |  |  |  | 97% → 92% |  |  |  |
| 335 | DNIRI AO Boundary |  |  |  | 80% → 20% |  |  |  |
| 338 | DNIRI Concept Review with AO Team |  |  |  |  | 98.53d → 161d |  | resources Adkins [25%]; Mechanical Engineer 1; Optical Engineer 1; Moore → Adkins [25%]; Bell; Gavel; Moore |
| 340 | **Single Object Imagers/Low Resolution Spectrographs (SOI/LRS)** |  | 2008-03-10 → 2007-10-17 (-145d) | 222d? → 119d? | 42% → 53% | 27.4d → 139d |  |  |
| 341 | SOI/LRS Coronagraph Requirements |  | 2007-06-01 A | 20d? → 10d? | 50% → 100% | 10d → none |  |  |
| 343 | SOI/LRS Concept Development |  | 2007-06-29 → 2007-07-13 (+14d) | 10d? → 20d? | 50% → 25% |  |  | resources Adkins [10%]; Mechanical Engineer 2; Optical Engineer 2 → Adkins [10%]; Bell; Optical Engineer 2 |
| 344 | **SOI/LRS Concept Review** | 2007-07-02 → 2007-07-16 (+14d) | 2007-07-03 → 2007-07-17 (+14d) |  |  | 169.9d → 168.5d |  |  |
| 345 | SOI/LRS Concept Review with Science Team | 2007-07-02 → 2007-07-16 (+14d) | 2007-07-02 → 2007-07-16 (+14d) |  |  | 169.9d → 168.5d |  |  |
| 346 | SOI/LRS Concept Review with AO Team | 2007-07-03 → 2007-07-17 (+14d) | 2007-07-03 → 2007-07-17 (+14d) |  |  | 169.9d → 168.5d |  |  |
| 347 | **SOI/LRS Reports** |  | 2008-03-10 → 2007-10-17 (-145d) | 179d? → 76d? | 41% → 55% | 27.4d → 139d |  |  |
| 348 | SOI/LRS Near-IR ver 1 |  |  |  |  | 131.4d → 140d |  | constraint start no earlier than 2007-07-05 → finish no earlier than 2007-10-16 |
| 349 | SOI/LRS Visibile ver 1 |  |  | 75d? → 62.5d? | 50% → 60% | 130.4d → 139d |  |  |
| 350 | **Single Object IFUs (SOIFU)** |  | 2008-02-29 → 2008-01-11 (-49d) | 221d? → 186d? | 4% → 10% | 33.4d → 77d |  |  |
| 352 | Visible IFU Requirements Review |  | 2007-10-16 → 2007-10-02 (-14d) | 21d? → 10.5d? |  | 68.4d → 120.5d |  |  |
| 353 | Visible IFU Concept Development | 2007-10-17 → 2007-11-28 (+42d) |  | 31d? → 0d? |  | 68.4d → 79d |  |  |
| 354 | **SOIFU Concept Review** |  |  | 2d? → 1d? |  | 68.4d → 77d |  |  |
| 355 | SOIFU Concept Review with Science Team |  |  | 1d? → 0d? |  | 68.4d → 78d |  |  |
| 356 | SOIFU Concept Review with AO Team |  |  | 1d? → 0d? |  | 68.4d → 77d |  |  |
| 357 | **Single Object IFU Reports** |  | 2008-02-29 → 2008-01-11 (-49d) | 65d? → 30d? |  | 33.4d → 77d |  |  |
| 358 | SOIFU Near-IR ver 1 |  |  |  |  | 68.4d → 77d |  | constraint finish no earlier than 2007-12-14 → start no earlier than 2007-12-03; resources Adkins [15%] → Adkins [7.5%] |
| 359 | SOIFU Visible ver 1 |  |  |  |  | 68.4d → 77d |  | resources Adkins [18.8%] → Adkins [1.2%] |
| 360 | Interferometer |  |  |  | 25% → 42% | 121.4d → 0d |  | resources Neyman [10.2%]; Other [7.3%]; Wizinowich [2.5%] → Neyman [7.7%]; Other [4.1%]; Wizinowich [2.5%] |
| 361 | OHANA |  |  |  |  | 266.4d → 275d |  | constraint finish no earlier than 2007-04-11 → start no earlier than 2007-02-01; resources Neyman [2.5%]; Woillez [7.5%] → Neyman [1.5%]; Woillez [7.5%] |
| 362 | **System Design Manual (SDM)** |  | 2008-02-05 → 2008-02-15 (+10d) | 127.62d? → 136d? | 66% → 56% | 10.78d → 16d |  |  |
| 364 | SDM v2 | 2008-01-17 → 2008-01-21 (+4d) | 2008-02-05 → 2008-02-15 (+10d) | 12.87d? → 20d? |  | 10.78d → 16d | 186, 228, 240, 241, 273, 287, 339 → 241, 273, 287, 339 | constraint finish no earlier than 2008-01-30 → finish no earlier than 2008-02-15; resources Wizinowich [34%]; Dekany; Gavel → Wizinowich [21.9%]; Dekany; Gavel |
| 365 | **Systems Engineering Management Plan (SEMP)** |  | 2008-02-20 → 2008-02-29 (+9d) | 253.4d? → 261d? | 14% → 16% | 0d → 6d |  |  |
| 366 | **Project Plan** | 2007-09-25 → 2007-10-04 (+9d) | 2007-12-20 → 2008-02-11 (+53d) | 61.64d? → 92.6d? |  | 28.19d → 13d |  |  |
| 367 | WBS and Task Definition | 2007-09-25 → 2007-10-04 (+9d) |  | 34d? → 27.6d? |  | 42.02d → 60.5d |  | constraint start no earlier than 2007-09-25 → finish no earlier than 2007-11-12; resources Wizinowich [22.1%]; Dekany [22.1%]; Gavel [22.1%]; Max [35%] → Wizinowich [18.1%]; Dekany [18.1%]; Gavel [18.1%]; Max [35%] |
| 368 | Cost Estimation | 2007-10-26 → 2008-01-07 (+73d) | 2007-11-30 → 2008-02-11 (+73d) | 25.57d? → 26d? |  | 5.69d → 13d |  | constraint start no earlier than 2007-10-26 → finish no earlier than 2008-02-11; resources Wizinowich [4.9%]; Dekany [14.7%]; Gavel [14.7%]; Bauman [14.7%]; Meguro [9.8%]; Johansson [9.8%]; Chin [9.8%]; Velur [14.7%]; Adkins [9.8%]; Le Mignant [4.9%] → Wizinowich [9.6%]; Dekany [14.7%]; Gavel [14.7%]; Bauman [14.7%]; Bell [9.8%]; Johansson [9.8%]; Chin [9.8%]; Velur [14.7%]; Adkins [9.8%]; Le Mignant [4.9%] |
| 370 | Develop Full Schedule (MS Project Plan) | 2007-11-30 → 2008-01-14 (+45d) | 2007-12-20 → 2008-01-31 (+42d) |  |  | 5.69d → 6.37d | 368 → none | constraint none → start no earlier than 2008-01-14 |
| 372 | **Preliminary Design Phase Plan** |  | 2008-01-24 → 2008-02-20 (+27d) | 234.71d? → 253.63d? |  | 5.69d → 6.37d |  |  |
| 374 | Preliminary Design Phase Plan Version 2 |  |  |  | 10% → 7% | 40.15d → 59.75d |  |  |
| 375 | Preliminary Design Phase Plan Final Version | 2008-01-03 → 2008-01-31 (+28d) | 2008-01-24 → 2008-02-20 (+27d) | 15.57d? → 14.06d? |  | 5.69d → 6.37d | 370FS+2w → 370 | constraint none → finish no earlier than 2008-02-13 |
| 376 | **Integration and Test Plans** |  |  | 70.4d? → 71d? |  | 0d → 19d |  |  |
| 377 | **Subsystem Testing Plans** |  |  | 70.4d? → 71d? |  | 0d → 19d |  |  |
| 381 | Science Instruments Test Plan | 2008-01-08 → 2008-01-09 (+1d) |  | 17.6d? → 18d? |  | 0d → 19d |  | constraint none → start no earlier than 2008-01-09; resources Adkins [14.2%] → Adkins [2.8%] |
| 383 | Configuration Management Plan | 2007-10-26 → 2007-12-07 (+42d) |  | 60.5d? → 30.5d? |  | 9.9d → 29d |  | constraint start no earlier than 2007-10-26 → finish no earlier than 2008-01-18; resources Johansson [10.3%]; Randolph [10%]; Chin [5%] → Johansson [8.2%]; Bell [10%]; Chin [5%] |
| 384 | Project Management Plan | 2007-12-20 → 2008-01-31 (+42d) | 2008-01-17 → 2008-02-18 (+32d) | 20d? → 12.43d? |  | 11.26d → 8d |  | constraint start no earlier than 2007-02-12 → finish no earlier than 2008-02-18; resources Wizinowich [12.5%]; Dekany [12.5%]; Gavel [12.5%]; Max [12.5%] → Wizinowich [20.1%]; Dekany [20.1%]; Gavel [20.1%]; Max [20.1%] |
| 385 | SEMP Document | 2008-02-01 → 2008-02-21 (+20d) | 2008-02-20 → 2008-02-29 (+9d) | 13d? → 7d |  | 0d → 6d |  | constraint none → finish no earlier than 2008-02-29; resources Wizinowich [30.8%]; Dekany [15.4%]; Gavel [15.4%]; Max [15.4%] → Wizinowich [57.1%]; Dekany [28.6%]; Gavel [28.6%]; Max [28.6%] |

## Version 18 (saved 2008-02-02, file NGAO_SD_schedule_v30_tracked.mpp)

Last finish stays 2008-04-30. Complete tasks 87 → 100.

Changed:

| ID | Task | Start | Finish | Duration | Complete | Total float | Other |
| --- | --- | --- | --- | --- | --- | --- | --- |
| 1 | **SD Phase Management** |  |  |  | 72% → 85% |  |  |
| 2 | **Planning and Contracting** |  | 2007-11-30 A |  | 79% → 100% | 143.3d → none |  |
| 10 | FY08 Replan | 2007-11-13 A | 2007-11-30 A |  | 0% → 100% | 143.3d → none |  |
| 11 | **Project Meetings** |  |  |  | 75% → 90% | 54.63d → 19d |  |
| 12 | Executive Committee Telecons |  |  |  | 75% → 90% | 54.63d → 19d |  |
| 13 | **Team Meetings** |  | 2007-12-13 → 2008-01-23 A (+41d) | 327d → 356d | 82% → 100% | 133.63d → none |  |
| 24 | Team Videocon #11 |  | 2007-11-05 A |  | 20% → 100% | 162.13d → none |  |
| 25 | Team Meeting #12 | 2007-12-13 A | 2007-12-13 A |  | 0% → 100% | 133.63d → none |  |
| 26 | Team Videocon #13 | 2007-01-23 → 2008-01-23 A (+365d) | 2007-01-23 → 2008-01-23 A (+365d) |  | 0% → 100% | 366.63d → none | constraint start no earlier than 2007-01-23 → start no earlier than 2008-01-23 |
| 35 | SSC meeting (CA) |  | 2007-11-06 A |  | 20% → 100% | 126d → none |  |
| 41 | **System Design Report & Review** | 2007-10-01 A |  |  | 0% → 48% |  |  |
| 43 | **System Design Review** | 2007-10-01 A |  |  | 0% → 51% |  |  |
| 44 | Identify Reviewers | 2007-10-01 A |  |  | 0% → 75% |  |  |
| 51 | **System Requirements** |  |  |  | 2% → 54% | 72.63d → 37d |  |
| 52 | **Science Requirements** |  |  |  | 1% → 54% | 78.63d → 43d |  |
| 53 | **Solar System Science Requirements** |  |  |  | 0% → 81% | 78.63d → 43d |  |
| 54 | **Multiplicity of Minor Planets (Key)** |  |  |  | 0% → 88% | 78.63d → 43d |  |
| 55 | **Minor Planets Survey Requirements** |  |  |  | 0% → 75% | 78.63d → 43d |  |
| 56 | MP Survey Science Requirements |  |  |  | 0% → 75% | 78.63d → 43d |  |
| 57 | MP Survey AO Requirements |  |  |  | 0% → 75% | 78.63d → 43d |  |
| 58 | MP Survey Observing Requirements |  |  |  | 0% → 75% | 78.63d → 43d |  |
| 59 | MP Survey Instrument Requirements |  |  |  | 0% → 75% | 78.63d → 43d |  |
| 60 | **Minor Planet Orbit Determination Requirements** |  | 2008-02-28 A |  | 0% → 100% | 78.63d → none |  |
| 61 | MP Orbit Science Requirements |  | 2008-02-28 A |  | 0% → 100% | 78.63d → none |  |
| 62 | MP Orbit AO Requirements |  | 2008-02-28 A |  | 0% → 100% | 78.63d → none |  |
| 63 | MP Orbit Observing Requirements |  | 2008-02-28 A |  | 0% → 100% | 78.63d → none |  |
| 64 | MP Orbit Instrument Requirements |  | 2008-02-28 A |  | 0% → 100% | 78.63d → none |  |
| 65 | **Giant Planets & Their Moons** |  |  |  | 35% → 80% | 78.63d → 43d |  |
| 66 | **Giant Planet Requirements** |  |  |  | 10% → 80% | 78.63d → 43d |  |
| 67 | GP Science Requirements |  |  |  | 10% → 80% | 78.63d → 43d |  |
| 68 | GP AO Requirements |  |  |  | 10% → 80% | 78.63d → 43d |  |
| 69 | GP Observing Requirements |  |  |  | 10% → 80% | 78.63d → 43d |  |
| 70 | GP Instrument Requirements |  |  |  | 10% → 80% | 78.63d → 43d |  |
| 71 | **Giant Planet Moons Requirements** |  |  |  | 50% → 80% | 78.63d → 43d |  |
| 72 | GP Moons Science Requirements |  |  |  | 50% → 80% | 78.63d → 43d |  |
| 73 | GP Moons AO Requirements |  |  |  | 50% → 80% | 78.63d → 43d |  |
| 74 | GP Moons Observing Requirements |  |  |  | 50% → 80% | 78.63d → 43d |  |
| 75 | GP Moons Instrument Requirements |  |  |  | 50% → 80% | 78.63d → 43d |  |
| 76 | **Shape & Size of Asteroids** |  |  |  | 0% → 67% |  |  |
| 77 | Asteroids Science Requirements |  |  |  | 0% → 67% |  |  |
| 78 | Asteroids AO Requirements |  |  |  | 0% → 67% |  |  |
| 79 | Asteroids Observing Requirements |  |  |  | 0% → 67% |  |  |
| 80 | Asteroids Instrument Requirements |  |  |  | 0% → 67% |  |  |
| 81 | **Galactic Science Requirements** |  |  |  | 0% → 46% | 78.63d → 43d |  |
| 82 | **General Relativity at the Galactic Center (Key)** |  |  |  | 0% → 70% | 78.63d → 43d |  |
| 83 | **GR Astrometry Requirements** |  |  |  | 1% → 50% | 78.63d → 43d |  |
| 84 | GR Astrometry Science Requirements |  |  |  | 1% → 50% | 78.63d → 43d |  |
| 85 | GR Astrometry AO Requirements |  |  |  | 1% → 50% | 78.63d → 43d |  |
| 86 | GR Astrometry Observing Requirements |  |  |  | 1% → 50% | 78.63d → 43d |  |
| 87 | GR Astrometry Instrument Requirements |  |  |  | 1% → 50% | 78.63d → 43d |  |
| 88 | **GR Radial Velocity Requirements** |  |  |  | 0% → 90% | 78.63d → 43d |  |
| 89 | GR RV Science Requirements |  |  |  | 0% → 90% | 78.63d → 43d |  |
| 90 | GR RV AO Requirements |  |  |  | 0% → 90% | 78.63d → 43d |  |
| 91 | GR RV Observing Requirements |  |  |  | 0% → 90% | 78.63d → 43d |  |
| 92 | GR RV Instrument Requirements |  |  |  | 0% → 90% | 78.63d → 43d |  |
| 95 | **Planets around Low Mass Stars & Brown Dwarfs: Companion Sensitivity (Key)** |  |  |  | 1% → 88% | 78.63d → 43d |  |
| 96 | Companion Sensitivity Science Requirements |  |  |  | 0% → 88% | 78.63d → 43d |  |
| 97 | Companion Sensitivy AO Requirements |  |  |  | 0% → 88% | 78.63d → 43d |  |
| 98 | Companion Sensitivity Observing Requirements |  |  |  | 2% → 88% | 78.63d → 43d |  |
| 99 | Companion Sensitivity Instrument Requirements |  |  |  | 2% → 88% | 78.63d → 43d |  |
| 110 | **Extragalactic Science Requirements** |  |  |  | 1% → 45% | 78.63d → 43d |  |
| 111 | **Resolved Stellar Populations in Crowded Fields** |  |  |  | 2% → 0% | 78.63d → 43d |  |
| 112 | Stellar Populations Science Requirements |  |  |  | 1% → 0% | 78.63d → 43d |  |
| 114 | Stellar Populations Observing Requirements |  |  |  | 4% → 1% | 78.63d → 43d |  |
| 115 | Stellar Populations Instrument Requirements |  |  |  | 4% → 1% | 78.63d → 43d |  |
| 116 | **High Redshift Galaxies (Key)** |  |  |  | 1% → 84% |  |  |
| 117 | High Redshift Science Requirements |  |  |  | 1% → 84% |  |  |
| 118 | High Redshift AO Requirements |  |  |  | 0% → 83% |  |  |
| 119 | High Redshift Observing Requirements |  |  |  | 2% → 84% |  |  |
| 120 | High Redshift Instrument Requirements |  |  |  | 2% → 84% |  |  |

| ID | Task | Start | Finish | Complete | Total float |
| --- | --- | --- | --- | --- | --- |
| 121 | **Nearby Active Galactic Nuclei (Key)** |  |  | 1% → 55% | 78.63d → 43d |
| 122 | AGN Science Requirements |  |  | 0% → 58% | 78.63d → 43d |
| 123 | AGN AO Requirements |  |  | 0% → 58% | 78.63d → 43d |
| 124 | AGN Observing Requirements |  |  | 2% → 43% | 78.63d → 43d |
| 125 | AGN Instrument Requirements |  |  | 2% → 59% | 78.63d → 43d |
| 126 | **Gravitational Lensing** |  |  | 1% → 49% | 78.63d → 43d |
| 127 | Lensing Science Requirements |  |  | 0% → 50% | 78.63d → 43d |
| 128 | Lensing AO Requirements |  |  | 0% → 50% | 78.63d → 43d |
| 129 | Lensing Observing Requirements |  |  | 2% → 44% | 78.63d → 43d |
| 130 | Lensing Instrument Requirements |  |  | 2% → 51% | 78.63d → 43d |
| 131 | **QSO Host Galaxies** |  |  | 0% → 38% | 78.63d → 43d |
| 132 | QSO Science Requirements |  |  | 0% → 38% | 78.63d → 43d |
| 133 | QSO AO Requirements |  |  | 0% → 38% | 78.63d → 43d |
| 134 | QSO Observing Requirements |  |  | 0% → 38% | 78.63d → 43d |
| 135 | QSO Instrument Requirements |  |  | 0% → 38% | 78.63d → 43d |
| 136 | **Science Case Requirements Document** |  |  | 14% → 89% | 87.63d → 37d |
| 138 | Science Case Requirements Doc Rev 2 |  | 2007-12-20 A | 9% → 100% | 128.63d → none |
| 139 | Science Case Requirements Doc Rev 3 | 2008-01-07 A |  | 0% → 15% | 72.63d → 37d |
| 145 | **System Requirements Document** |  |  | 53% → 65% | 72.63d → 37d |
| 146 | **Traceability Matrix** |  |  | 45% → 73% | 335.98d → 302.61d |
| 148 | Traceability Matrix Rev 2 | 2007-02-12 A |  | 0% → 50% | 335.98d → 302.61d |
| 149 | **System Requirements Document** |  |  | 56% → 61% | 72.63d → 37d |
| 151 | SRD Rev 2 |  |  | 74% → 85% | 122.98d → 87.34d |
| 153 | **System Design** |  |  | 50% → 64% | 44d → 45d |
| 215 | **System Architecture** |  |  | 65% → 68% | 51d → 52d |
| 228 | **Functional Requirements** |  |  | 48% → 53% | 51d → 52d |
| 231 | AO System Functional Requirements Ver 2 |  |  | 25% → 50% | 88.77d → 107d |
| 233 | Laser System Functional Requirements Ver 2 |  |  | 29% → 39% | 88.77d → 0d |
| 241 | **AO System** |  |  | 14% → 68% | 96d → 97d |
| 242 | AO System Architecture |  | 2007-11-23 A | 60% → 100% | 93.77d → none |
| 243 | AO Enclosure |  |  | 2% → 75% | 105.77d → 124d |
| 244 | **Opto-mechanical** |  |  | 13% → 72% | 96d → 97d |
| 245 | Field Rotation |  |  | 40% → 90% | 9d → 18.84d |
| 246 | Optical Relay |  |  | 39% → 88% | 9d → 0d |
| 247 | Optical Switchyard |  |  | 2% → 90% | 9d → 18.84d |
| 248 | Optical Support Structure |  |  | 8% → 90% |  |
| 249 | **Wavefront Sensors** |  |  | 8% → 89% | 116d → 117d |
| 250 | High Order LGS Wavefront Sensors |  |  | 10% → 90% | 98.77d → 117d |
| 251 | High Order NGS Wavefront Sensor |  |  | 15% → 90% | 98.77d → 117d |
| 252 | Low Order NGS Wavefront Sensors |  |  | 2% → 87% | 98.77d → 117d |
| 253 | Calibration Wavefront Sensor |  |  | 5% → 90% | 98.77d → 117d |
| 254 | **Wavefront Correctors** |  |  | 2% → 40% |  |
| 255 | Tip/Tilt Corrector |  |  | 2% → 90% |  |
| 258 | **Acquisition Cameras** |  |  | 50% → 75% | 131d → 132d |
| 259 | NGS Acquisition Camera |  |  | 50% → 75% | 113.77d → 132d |
| 260 | LGS Acquisition Camera |  |  | 50% → 75% | 113.77d → 132d |
| 261 | Atmospheric Dispersion Correction |  |  | 16% → 40% |  |
| 262 | Alignment, Calibration, Diagnostics, Metrology and Monitoring |  |  | 19% → 38% |  |
| 263 | Atmospheric Profiler |  | 2007-10-02 A | 6% → 100% | 149d → none |
| 264 | d-IFU & LOWFS AO & Object Selection | 2007-08-23 A |  | 0% → 83% | 78.77d → 0d |
| 265 | PSF Monitoring Camera |  |  | 0% → 69% | 93.77d → 0d |
| 266 | **Non-real-time Control** |  |  | 3% → 10% | 112d → 0d |
| 267 | Non-RTC Software |  |  | 5% → 18% | 154.77d → 0d |
| 268 | Non-RTC Electronics |  |  | 2% → 6% |  |
| 269 | **Real-time Control** |  |  | 11% → 82% | 105d → 0d |
| 270 | RTC Architecture Analysis and Design Study |  |  | 16% → 82% |  |
| 271 | RTC Software Module Definition |  |  | 9% → 88% | 87.77d → 0d |
| 272 | RTC Hardware Module Definition |  |  | 13% → 75% | 87.77d → 0d |
| 273 | **Laser Facility** |  |  | 10% → 58% | 93d → 94d |
| 274 | Laser System Architecture |  | 2007-10-19 A | 25% → 100% | 80.07d → none |
| 275 | Laser Enclosure |  |  | 10% → 72% | 75.77d → 94d |
| 276 | Laser |  |  | 10% → 50% | 83.77d → 102d |
| 277 | **Laser Launch Facility** |  |  | 3% → 70% |  |
| 278 | Laser Beam Transport |  |  | 2% → 75% |  |
| 279 | Laser Pointing & Diagnostics |  |  | 2% → 59% |  |
| 280 | Laser Launch Telescope |  |  | 5% → 75% |  |
| 281 | **Laser Safety Systems** |  |  | 4% → 68% | 126d → 127d |
| 282 | Personnel and Equipment Safety Systems |  |  | 2% → 75% | 126d → 127d |
| 283 | Aircraft, Satellite & Laser Traffic Control Safety Systems |  |  | 8% → 46% | 126d → 127d |
| 284 | **Laser System Control** |  |  | 8% → 21% | 96d → 97d |

| ID | Task | Start | Complete | Total float |
| --- | --- | --- | --- | --- |
| 285 | Laser System Software |  | 10% → 25% | 78.77d → 97d |
| 286 | Laser System Electronics |  | 4% → 11% | 96d → 97d |
| 318 | **Science Instruments** |  | 45% → 54% |  |
| 319 | **Instrument Requirements & Initial Definitions** |  | 31% → 43% |  |
| 320 | Top Level Instrument Requirements & Definitions |  | 50% → 75% |  |
| 324 | **Instrument Suite Version 2** | 2008-01-10 A | 0% → 25% |  |
| 326 | Revised Summary Descriptions of Instruments | 2008-01-14 A | 0% → 30% |  |
| 327 | **Instrument Interfaces** | 2007-06-06 A | 0% → 3% |  |
| 328 | Hardware Instrument Interfaces | 2007-06-06 A | 0% → 7% |  |
| 330 | **Deployable NIR IFU (DNIRI)** |  | 75% → 84% |  |
| 339 | DNIRI Report ver 1 | 2007-08-10 A | 0% → 40% |  |
| 340 | **Single Object Imagers/Low Resolution Spectrographs (SOI/LRS)** |  | 53% → 71% |  |
| 342 | SOI/LRS Spectrograph Requirements |  | 50% → 75% | 5d → 11d |
| 343 | SOI/LRS Concept Development |  | 25% → 55% |  |
| 347 | **SOI/LRS Reports** |  | 55% → 72% |  |
| 348 | SOI/LRS Near-IR ver 1 |  | 50% → 69% |  |
| 349 | SOI/LRS Visibile ver 1 |  | 60% → 75% |  |
| 365 | **Systems Engineering Management Plan (SEMP)** |  | 16% → 19% |  |
| 366 | **Project Plan** | 2007-10-04 A | 0% → 14% | 13d → 13.35d |
| 367 | WBS and Task Definition | 2007-10-04 A | 0% → 18% | 60.5d → 62.73d |
| 368 | Cost Estimation | 2008-01-07 A | 0% → 8% | 13d → 13.35d |
| 369 | Major Project Milestones | 2007-10-26 A | 0% → 33% | 83.43d → 83.78d |
| 370 | Develop Full Schedule (MS Project Plan) | 2008-01-14 A | 0% → 10% | 6.37d → 6.72d |
| 372 | **Preliminary Design Phase Plan** |  | 64% → 66% | 6.37d → 6.72d |
| 374 | Preliminary Design Phase Plan Version 2 |  | 7% → 17% | 59.75d → 60.1d |
| 385 | SEMP Document | 2008-02-21 A | 0% → 5% |  |
